# 3GPP_Release-2000

Schedule from MS Project, 1998-12-07 to 2011-09-16, A marks actual dates.

## Calendars

- Standard: Mon-Fri 08:00-12:00, 13:00-17:00; Sat-Sun off. Exceptions (off unless hours are given): 2000-01-15 08:00-12:00, 13:00-17:00, 2009-05-30 08:00-12:00, 13:00-17:00.

## Resources

| Resource |
| --- |
| NP |
| N1 |
| N2 |
| N3 |
| N4 |
| N5 |
| TP |
| T1 |
| T2 |
| T3 |
| RP |
| R1 |
| R2 |
| R3 |
| R4 |
| SP |
| S1 |
| S2 |
| S3 |
| S4 |
| S5 |
| PCG |
| GP |
| No |
| CN4 |
| ? |
| WG G2 |
| G2 |
| G1 |
| G4 |
| G3 |
| All |
| Generic |
| MLST |
| G5 |
| S3, G2 |
| WG T2 |
| GP,G1 |
| G4,G5 |
| OMA |
| GP-G2 |
| Yes |
| GP, |
| N4, |
| GP, N1 |
| CT5 |
| C5 |
| C1 |
| C4 |
| C3 |
| C6 |
| G1, |
| 4 |
| ct |
| c,s,r |
| CT,RAN,SA |
| G2, |
| G1, G3 |
| CT6 |
| CT1 |
| CT1, CT3, CT4 |
| C1, C3, C4 |
| CP |
| R5 |
| C |
| Rel-8 |
| GP, G2 |
| R1,R4 |
| S5,C1 |
| CT,RAN,SA,GERAN |
| S3,C1,C4 |
| 5 |
| S1,C1,C3,C4,S5 |
| S1,C1,C3,C5 |
| S1,C1,C3,C4 |
| S1,S5 |
| S2,S3 |
| RAN,SA |
| RP,S5 |
| S2,CT |
| S1,CT |
| S1,CT,GERAN |
| S1,C5 |
| S3,CT |
| S4,CT |
| C1,SA |
| S1,S2 |
| S1,S4 |
| S2,S2,S3,CT |
| S2,S3,CT |
| S1,CT,GX |
| S1,S4,CT |
| S2,S2,S3,S5,CT |
| S1,S2,CT |
| S1,S2,S3,CT |
| S1,S2,S3,S5CT |
| S1,S2,S3,S5,CT |
| S2,S5,CT |
| S4,S3 |
| S1,C1 |
| CP,C1 |
| C1,C3 |
| C1,C3,C4 |
| S1,S5,CT |
| C4,C3 |
| CP,RAN,SA,GERAN |
| S1,S2,S3,S5,CP |
| S2,S3,CP |
| S2,CP |
| S1,CP,GX |
| S1,CP |
| S1,S4,CP |
| S1,S2,CP |
| S1,S2,S3,CP |
| S2,S5,CP |
| S3,CP |
| S1,S5,CP |
| RAN,SA,GERAN |
| S1,S2,S3,S5,C1,C3,C4,C6 |
| S2,S3,C1,C3,C4 |
| S2,C4 |
| S2,C1,C3,C4 |
| S2,C1,C4 |
| S2,S3,C1,C4 |
| S1,C1,C4,G2 |
| C1,C4 |
| S1,C1,C3 |
| S1,S4,C1,C3,C4 |
| S1,S2,S3,C1,C3,C4 |
| S2,S5,C3 |
| S1,S2,C1,C4 |
| S2,C1 |
| S2,C1,C3 |
| S3,C1,C3,C4 |
| S1,S5,C1,C3,C4 |
| S2,C3,C4 |
| C3,C1 |
| R2,R4 |
| R2,R5 |
| RP,R5 |
| RP,S5,R5 |
| R1,R5 |
| S1,C1,R5 |
| S1,C1,S4,R5 |
| GERAN |
| G3new |
| G1, G3new |
| C4,C1,C3 |
| R1.R4 |
| R1, R4 |
| R2,R3 |
| C3,C4 |
| S4,C3 |
| S4,C3,C1,C4 |
| S1,S2,C1 |
| S1,S2<C1,C3,C4 |
| S1,S2,C1,C3,C4 |
| S5,C1,C3,C4 |
| GP,C4 |
| C4,C1 |
| S2,S1 |
| RP,SP,GP |
| RP,SP,CP,GP |
| CP,GP,RP,SP |
| GP,C4,S4 |
| S1,C1,C4 |
| S1,S2,C3,C1 |
| R2,R4,R3 |
| CP,GP, RP,SP |
| S2,S1,C1,S5 |
| S2,S1,C1 |
| S1,C1,S4 |
| S1,S2,GP,C4,R2 |
| S1,GP,R2 |
| S1,C6 |
| S1,S2,C1,S4 |
| S2,S3,S5,C1,C3,C4 |
| S2,S5,C1 |
| S2,S3,S5 |
| CP,GP, RP,SP,TP |
| S2,C4,C1 |
| S1,C1,C4,S3 |
| S2,S5 |
| S3,C1 |
| S3,C4 |
| S1,C4 |
| S2,S5,C3,C1 |
| S2,S1,S5,C1,C4 |
| S1,R1,C3 |
| S1,C1,R2 |
| S2,S1,C1,C4 |
| S1,C1,C6 |
| GP,S4,C4,C1,C3 |
| C3,C1,C4 |
| S1,C4,C1 |
| S1,S3 |
| S1,S2,S5,C3,C4 |
| R4,G1 |
| G1,R4 |
| RP,GP |
| R4,GP |
| R3,R2 |
| C6,RP,SP |
| R5,C6 |
| CP,RP,SP |
| RP,SP,CP |
| R3,S5 |
| S1,S2,RP |
| S1,S2,S5,RP |
| S2,S1,RP |
| Rel-9 |
| S3,C6 |
| S1,S2,S3,S5,RP |
| S2,S1,S3 |
| S1,S2,S3 |
| S1,S2,S3,S5 |
| C6,R5 |
| S1,S2,RP,GP |
| S1,S2,S4,S5,RP,GP |
| GP,G2 |
| GP,GP, N1 |
| GP,S2,G1,G2 |
| GP,R2,R3,S2,G1,G2 |
| GP,S2,S5,R2,R3,G2,G1 |
| GP,R3 |
| N4,S2 |
| GP,RP |
| GP,S2,RP |
| G5,G4 |
| G4,R3 |
| S2,R2,R4 |
| S1,S2,R2,R4 |
| GP,S5 |
| S1,S2,S5 |
| R4,R5 |
| R4,R2,R3,R5 |
| S2,S5,N4,RP |
| S1,S2,S3,S5,NP |
| S2,S4,S5 |
| T2,S1,S4,S5 |
| SP,RP |
| S2,RP |
| S1,S2,CP,G2 |
| CP,SP |
| S1,G2 |
| SP,CP |
| S1,S2,S5,C3 |
| S1,C1,S3 |
| G1,G3new |
| C4, C3, C1C4 |
| C4,C3,C1 |
| S1,S2,S3,S5,R2,R3,R4 |
| S1,S2,S3,R2 |
| S2,S3,S5,C4,R2 |
| S1,S5,C1 |
| S1,S2,S3,C1,C3,C4,R2 |
| Ggp |
| S3,S2,C1,C4,G2 G3new |
| R1,R2,R3,R4 |
| R4,R1,R2,R3 |
| R4,R2,R3 |
| S1,C1,C4,R2 |
| R4,R2 |
| S2,C4,R2,R4 |
| S2,C4,R2 |
| S2,S3,S5,C3,C4,R2 |
| S1,S2,S4,T2 |
| S1,S2,S4 |
| S1,S2,S4,R5 |
| S3,S2,C1,C4,G2,G3new |
| GP,C1 |
| S1,S5,C4 |
| S1,S2,S3,S5,R2,R3,R4,GP |
| GP,C4,C3,C1 |
| SMG9 |
| SMG1 |
| SMG2 |
| N3,R5 |
| N1, N2, N4, G1, G2, R3, S1, SMG2 |
| S1,SMG1 |
| SMG1,N4 |
| N1,C1,N4,S1,T2,G2,SMG1,SMG2,SMG3,SMG7,SMG9 |
| SMG1,N2 |
| S1,S2,N2,N4 |
| N4,N2 |
| G1,G2 |
| G1,G2,C1 |
| G1,G2,N1 |
| SMG2, SMG1, SMG3, SMG4, SMG7, SMG9, SMG10, G1, G2, G3, N1, N3, T2 |
| SMG2,G1 |
| S1,G1,G2 |
| SMG1,N1,G1,G2 |
| G2,G1 |
| G1,G2,G3,S1,S2,SMG1,SMG2,SMG7,N1,N2,N3,N4,T2 |
| 23.003, 23.008, 29.060 |
| S1, S2, SMG1, SMG2, SMG12, G2, N1, N2, N4 |
| S1,S2,SMG1,SMG2,SMG12,G2,N1,N2,N4 |
| S1,SMG2,N1,N2,N4 |
| SMG1,T2 |
| S1,N1,N2,N4 |
| S1,S2,N5 |
| SMG2,SMG7,G2,T2 |
| S3,N1,N2,N3 |
| S3,N1,N2,N4 |
| SMG9,T3 |
| SMG2,SMG3,SMG7,G2,N2 |
| SMG2,N1,G1,G2 |
| S1,N2 |
| N1,N3 |
| S2,N1 |
| N1,N2,N4 |
| N2,N1,N4 |
| N2,N4 |
| S1,T3 |
| T2,N3 |
| S3,N2 |
| T2,S1 |
| S1,N4 |
| SMG1,SMG2,SMG7 |
| N1,S1,T1 |
| SMG1,SMG3 |
| N4,S2,N1 |
| S1,S2,SMG1,SMG2,SMG7,G1,G2,G3,N1,N2,N3,N4,T2 |
| SMG1,N3 |
| S1,N3 |
| CP,SP,SMG |
| CP,SP,TP,GP,SMG |
| NP,SP,TP,GP,SMG |
| NP,GP, RP,SP,TP |
| SMG2,SMG1,SMG3,SMG4,SMG7,SMG9,SMG10,G1,G2,G3,N1,N3,T2 |
| S1,N2,N4 |
| S1,S2,S3,C1,C3,C4,R2,R3 |
| R2,R3,R1,R4 |
| R2,R3,R4 |
| R2,R1,R3,R4 |
| S2,C4,R2,R3,R4 |
| S2,C4,R2,R1,R3,R4 |
| S2,S3,S5,C3,C4,R2,R3,R4 |
| R1,R2,R4 |
| R3,R1,R4 |
| S2, |
| S2,G2, |
| S1,S2,G2, |
| S1,S2,G2,R2,R3, |
| S1,S2,C4,G2,R2,R3 |
| S1,S2,N4,G2,R2,R3 |
| S1,S2,SMG1,SMG2,SMG12,G2,N1,N2,N4,R2,R3 |
| S1,SMG1,T2 |
| S1,SMG1,S2 |
| S1,N4,N2 |
| T2,N1,N3 |
| S3,N2,N4 |
| SMG1,SMG2,SMG3,SMG7,SMG9,N1,C1,N4,S1,T2,G2 |
| SMG1,N2,N4 |
| S2,T2,N1,N2,N4 |
| S1,T2 |
| S1,S2,C4 |
| S1,S2,N4,RP |
| S2,N4 |
| S1,S2,N3,N4,RP |
| S1,S2,SMG1,SMG2,SMG12,T2,G2,N1,N2,N4,R2,R3 |
| S1,T2,N1,N3 |
| S1,S2,SMG1,SMG2,SMG12,T2,G2,N1,N2,N3,N4,R2,R3 |
| S1,S2,S3,SMG1,SMG2,SMG12,G2,N1,N2,N4,R2,R3 |
| S1,S2,SMG,G1,G2,G3,N1,N2,N3,N4,T2 |
| S1,S2,SMG,T2,G2,N1,N2,N3,N4,R2,R3 |
| S1,S3,SMG,G1,G2,G3,N1,N2,N3,N4,T2 |
| S1,S3,T2,N2,N4 |
| S1,S2,SMG,T2,G1,G2,G3,N1,N2,N3,N4 |
| G2,S2 |
| T1,R5 |
| R5,T1 |
| S1,S2,S4,T1,R5 |
| S1,S2,S4,S5,T1,RP,GP |
| S1,S2,S3,S5,R2,R3,R4,GP,C1 |
| S1,S2,S3,SMG1,SMG2,SMG12,N1,N2,N4,R2,R3 |
| S1,S2,SMG,T2,N1,N2,N3,N4,R2,R3 |
| NP,SP,TP,SMG |
| S1,S2,SMG,T2,N1,N2,N3,N4 |
| SMG,N1 |
| SMG |
| S1,S2,SMG1,SMG2,SMG7,N1,N2,N3,N4,T2 |
| SMG2,SMG1,SMG3,SMG4,SMG7,SMG9,SMG10,N1,N3,T2 |
| S1,SMG |
| SMG2,SMG7,T2 |
| SMG2,S2 |
| N1,N2,N4,R3,S1,SMG |
| SMG2,SMG3,SMG7,N2 |
| SMG1,SMG2,SMG3,SMG7,SMG9,N1,C1,N4,S1,T2 |
| S1,S2,SMG,N3,N4,RP |
| S1,S2,S4,SMG,N3,N4,RP |
| S2,C1,C4,R2,R1,R3,R4 |
| R2,S2,S4 |
| G3new,R5 |
| GP,R4 |
| S2,S4,R2 |
| SP,GP |
| RP,SP |
| S2,S1,S3,S5 |
| S3,S1 |
| N4,N1,N2,S2 |
| S2,G1,G2,R2,R3 |
| S2,G1,G2 |
| G1,G2,R2,R3 |
| N4,T3 |
| S3,S2,N1,N4,T3,OMA |
| T2,S1,S4,S5,OMA |
| S2,N3 |
| S4,S1 |
| N4,N3,S1 |
| R5,G3new |
| R4,R2,R1 |
| S2,R2 |
| C3, C4,C1 |
| S3,C1,C4,C3 |
| C1,C4,C3 |
| S2,C1,C4,C3 |
| R3,R5 |
| S1,S2,C3 |
| R1,R2 |
| S3,C1,C4,G2,G3new |
| R1,R3 |

## Schedule

| ID | WBS | Task | Type | Duration | Start | Finish | Complete | Remaining | Baseline start | Baseline finish | Baseline duration | Total slack | Constraint | Resources | Work | Actual work | Text6 | Text1 | Text2 | Text4 | Text5 | Text7 | Text8 |
| --- | --- | --- | --- | --- | --- | --- | --- | --- | --- | --- | --- | --- | --- | --- | --- | --- | --- | --- | --- | --- | --- | --- | --- |
| 1 | 1 | Version 2010 Feb 14 |  | 3318d? | 1998-12-07 | 2011-08-22 |  |  | 1998-12-07 | 2011-08-22 | 3318d? | 19d | start no earlier than 1998-12-07 | S1 | 26544h |  |  |  |  |  |  |  |  |
| 2 | 2 | SA1 extract for SA1#49 | milestone | 0d | 1998-12-07 | 1998-12-07 |  |  | 1998-12-07 | 1998-12-07 | 0d | 3337d | finish no earlier than 1998-12-07 | S1 |  |  |  |  |  |  |  |  |  |
| 3 | 3 | "CTRL + a" to display all the 3GPP fields | milestone | 0d | 1998-12-07 | 1998-12-07 |  |  | 1998-12-07 | 1998-12-07 | 0d | 3337d | finish no earlier than 1998-12-07 | S1 |  |  |  |  |  |  |  |  |  |
| 4 | 4 | Gantt: dark blue=done; light blue=to be done; grey: previous values; black=summary | milestone | 0d? | 1998-12-07 | 1998-12-07 |  |  | 1998-12-07 | 1998-12-07 | 0d? | 3337d | finish no earlier than 1998-12-07 | S1 |  |  |  |  |  |  |  |  |  |
| 6 | 5 | Release 11 Studies | milestone | 0d? | 2000-01-01 | 2000-01-01 |  |  | 2000-01-01 | 2000-01-01 | 0d? | 3057d | start no earlier than 2000-01-01 | S1 |  |  | Rel-11 |  |  |  |  |  |  |
| 7 | 6 | Study on Non Voice Emergency Services |  | 206d? | 2009-12-10 | 2010-09-23 |  |  | 2009-12-10 | 2010-09-23 | 206d? | 256d | start no earlier than 2009-12-10 | S1 | 1648h |  | Rel-11 | FS_NOVES | PCG-24 | Qualcomm Europe | dwilliams@qualcomm.com | SP-46 | Alain |
| 8 | 7 | Study on UICC/USIM enhancements |  | 206d? | 2009-12-10 | 2010-09-23 |  |  | 2009-12-10 | 2010-09-23 | 206d? | 256d | start no earlier than 2009-12-10 | S1 | 1648h |  | Rel-11 | FS_U2e | PCG-24 | Giesecke & Devrient | Ilario Macchi | SP-46 | Alain |
| 9 | 8 | Release 10 Features | milestone | 0d? | 2000-01-01 | 2000-01-01 |  |  | 2000-01-01 | 2000-01-01 | 0d? | 3057d |  | S1 |  |  | Rel-10 |  |  |  |  |  |  |
| 10 | 9 | **Extended H(e)NB features** |  | 467d? | 2008-12-11 A | 2010-09-23 | 32% | 316.26d? | 2008-12-11 | 2010-09-23 | 467d? | 256d |  | S1,S2 | 7012.8h | 1541.6h | Rel-10 | EHNBF | PCG-23 | NEC | joerg.swetina@nw.neclab.eu | SP-45 | Alain |
| 11 | 9.1 | Stage 1 of Extended H(e)NB features |  | 131d? | 2009-09-24 A | 2010-03-25 | 5% | 124.7d? | 2009-09-24 | 2010-03-25 | 131d? | 386d | finish no earlier than 2010-03-25 | S1 | 1048h | 50.4h | Rel-10 | EHNBF | PCG-23 | NEC | joerg.swetina@nw.neclab.eu | SP-45 | Alain |
| 12 | 9.2 | IMS aspects of Architecture for Home NodeB |  | 466d? | 2008-12-11 A | 2010-09-23 | 40% | 279.6d? | 2008-12-11 | 2010-09-23 | 466d? | 256d | finish no earlier than 2010-09-23 | S2 | 3728h | 1491.2h | Rel-10 | EHNB-IMS | PCG-22 | Alcatel-Lucent | Nicolas Drevon | SP-42 | Maurice |
| 13 | 10 | **Network Improvements for Machine-Type Communications** |  | 523d? | 2008-09-18 A | 2010-09-17 | 39% | 320.49d? | 2008-09-18 | 2010-09-17 | 523d? | 260d |  | S1,S2,S3 | 10929.2h | 4231.94h | Rel-10 | NIMTC | PCG-21 | KPN | Toon Norp (toon.norp AT tno.nl) | SP-41 | Alain |
| 14 | 10.1 | Stage 1 for NIMTC |  | 397d? | 2008-09-18 A | 2010-03-25 | 79% | 83.37d? | 2008-09-18 | 2010-03-25 | 397d? | 386d | finish no earlier than 2009-12-10 | S1 | 3176h | 2509.04h | Rel-10 | NIMTC | PCG-21 | KPN | Toon Norp (toon.norp AT tno.nl) | SP-41 | Alain |
| 15 | 10.2 | Stage 2 for NIMTC |  | 257d? | 2009-09-24 A | 2010-09-17 | 5% | 244.15d? | 2009-09-24 | 2010-09-17 | 257d? | 260d | finish no earlier than 2010-09-17 | S2 | 2056h | 102.8h | Rel-10 | NIMTC | PCG-23 | Samsung | Erik Guttman (erik.guttman@partner.samsung.com) | SP-45 | Maurice |
| 16 | 10.3 | Security for NIMTC |  | 189.15d? | 2009-12-10 | 2010-09-17 |  |  | 2009-12-10 | 2010-09-17 | 189.15d? | 260d | start no earlier than 2009-12-10 | S3 | 1513.2h |  | Rel-10 | NIMTC | PCG-24 | Samsung | Rajavelsamy R (rajvel@samsung.com) | SP-46 | Dionisio |
| 17 | 11 | **GTP-based S8 chaining** |  | 327d? | 2008-12-11 A | 2010-03-11 | 35% | 212.55d? | 2008-12-11 | 2010-03-11 | 327d? | 396d |  | S2 | 5232h | 1831.2h | Rel-10 | GTPchaining | PCG-22 | Huawei | Haining Wang (wanghaining@huawei.com) | SP-42 | Maurice |
| 18 | 11.1 | Stage 2 for GTPchaining |  | 327d? | 2008-12-11 A | 2010-03-11 | 35% | 212.55d? | 2008-12-11 | 2010-03-11 | 327d? | 396d | finish no earlier than 2010-03-11 | S2 | 2616h | 915.6h | Rel-10 | GTPchaining | PCG-22 | Huawei | Haining Wang (wanghaining@huawei.com) | SP-42 | Maurice |
| 19 | 12 | Multi Access PDN Connectivity |  | 261d? | 2009-03-13 A | 2010-03-11 | 75% | 65.25d? | 2009-03-13 | 2010-03-11 | 261d? | 396d | finish no earlier than 2010-03-11 | S2 | 2088h | 1566h | Rel-10 | MAPCON | PCG-22 | Telecom Italia | ivano.guardini@telecomitalia.it | SP-43 | Maurice |
| 20 | 13 | **IMS Service Continuity – Inter Device Transfer enhancements** |  | 266d? | 2009-06-04 A | 2010-06-10 | 58% | 113d? | 2009-06-04 | 2010-06-10 | 266d? | 331d |  | S1,S2 | 5304h | 2466.8h | Rel-10 | IMS_SC_eIDT | PCG-23 | Huawei | Amar Deol (adeol@huawei.com) | SP-44 | Alain |
| 21 | 13.1 | Stage 1 for IMS_SC_eIDT |  | 211d? | 2009-06-04 A | 2010-03-25 | 95% | 10.55d? | 2009-06-04 | 2010-03-25 | 211d? | 386d | finish no earlier than 2010-03-25 | S1 | 1688h | 1603.6h | Rel-10 | IMS_SC_eIDT | PCG-23 | Huawei | Amar Deol (adeol@huawei.com) | SP-44 | Alain |
| 22 | 13.2 | IMS Inter-UE Transfer enhancements (Stage 2) |  | 186d? | 2009-09-24 A | 2010-06-10 | 15% | 158.1d? | 2009-09-24 | 2010-06-10 | 186d? | 331d | finish no earlier than 2010-06-10 | S2 | 1488h | 223.2h | Rel-10 | IMS_SC_eIDT | PCG-23 | Huawei | HengLiang Zhang (hl_zhang@huawei.com) | SP-45 | Maurice |
| 23 | 14 | **IP-Short-Message-Gateway enhancements for CPM-SMS Interworking** |  | 192d? | 2009-09-24 A | 2010-06-18 | 52% | 93.08d? | 2009-09-24 | 2010-06-18 | 192d? | 325d |  | S1,S2,C3 | 5192.8h | 2242.48h | Rel-10 | CPM-SMS | PCG-23 | China Mobile | Qing Huang | SP-45 | Alain |
| 24 | 14.1 | Stage 1 for CPM-SMS |  | 131d? | 2009-09-24 A | 2010-03-25 | 95% | 6.55d? | 2009-09-24 | 2010-03-25 | 131d? | 386d | finish no earlier than 2010-03-25 | S1 | 1048h | 995.6h | Rel-10 | CPM-SMS | PCG-23 | China Mobile | Qing Huang | SP-45 | Alain |
| 25 | 14.2 | Stage 2 for CPM-SMS |  | 185.1d? | 2009-09-24 A | 2010-06-10 | 60% | 74.04d? | 2009-09-24 | 2010-06-10 | 185.1d? | 331d | finish no earlier than 2010-06-10 | S2 | 1480.8h | 888.48h | Rel-10 | CPM-SMS | PCG-23 | Orange | Antoine Mouquet | SP-45 | Maurice |
| 26 | 14.3 | Stage 3 for CPM-SMS |  | 141d? | 2009-12-04 | 2010-06-18 |  |  | 2009-12-04 | 2010-06-18 | 141d? | 325d | finish no earlier than 2010-06-18 | C3 | 1128h |  | Rel-10 | CPM-SMS | PCG-24 | Ericsson | Jan Holm | CP-46 | Gwiho |

Notes:
- 1: -
- 2: -
- 3: -
- 4: -
- 6: -
- 7: - / Text3: 22.8xx Study on Non Voice Emergency Services
- 8: Triggered by GSMA Smart SIM and 3GNBK projects, and to evolve from traditional USAT to multimedia USIM toolkit support, particularly to Smart Card Web Server / Text3: 22.8xx Study on UICC/USIM enhancements
- 9: -
- 10: Items beyond Rel-9 UID_400035 Enhanced Home NodeB / eNodeB (EHNB)
- 11: - / Text3: 22.220
- 12: SP#46 completion 06/10 (was 12/09)=>09/10 / Text3: new 23.832, 23.232
- 13: SP#46 updated WID SP-090658 =>SP-090832 (added SA3 part). Stage 2 completion 06/10=>09/10. Triggered by Rel-8 UID_7027 Study on Facilitating Machine to Machine Communication in GSM and UMTS (FS_M2M) TR 22.868
- 14: - / Text3: new 22.368
- 15: SP#46 Stage 2 completion 06/10=>09/10 / Text3: new 23.888 (Architectural Enhancements for machine-type communications)
- 16: SP#46 updated WID SP-090658=>SP-090832 (added SA3 part) / Text3: new 33.868
- 17: Stage 1 in UID_320022 Rel-8 Requirements for evolution of the 3GPP system architecture (AIPN-SAE): 22.278, 22.011, 22.246
- 18: SP#46 completion 12/09=>09/10 / Text3: 23.402 (Chaining GTP-S8 based architecture and procedures)
- 19: SP#45 WID updated SP-090100=>SP-090659. Triggered by TR 23.861 UID_410043 FS_MAPIM. Stage 1 in Rel-9 22.278 (6.2 - IP session control) / Text3: 23.401, 23.402, 23.237
- 20: Rel-9 set Inter-Device Transfer requirements UID_410033 (IMS_SCC-IDT). Add additional scenarios and requirements for IDT.
- 21: - / Text3: 22.228
- 22: - / Text3: 23.237, 23.292, new 23.831
- 23: IP-SM-GW enhancements for interworking with OMA CPM
- 24: External requirements (Stage 1 in OMA-RD-CPM-V1_0-20090310-C) / Text3: 22.340
- 25: SP#46 TR 23.824v100 for Information / Text3: 23.204, new TR 23.824
- 26: Linked to Rel-8 UID_340031 Service-Level Interworking for Messaging Services (MESSIW) 23.204 / Text3: 29.311

| ID | WBS | Task | Duration | Start | Finish | Complete | Remaining | Baseline start | Baseline finish | Baseline duration | Total slack | Constraint | Resources | Work | Actual work | Text1 | Text2 | Text4 | Text6 | Text7 | Text8 |
| --- | --- | --- | --- | --- | --- | --- | --- | --- | --- | --- | --- | --- | --- | --- | --- | --- | --- | --- | --- | --- | --- |
| 27 | 15 | **Completion of Communications on Not Logged-in** | 1d? | 2009-09-24 A | 2009-09-24 A | 100% |  | 2009-09-24 | 2009-09-24 | 1d? |  |  | S1 | 16h | 16h | CCNL | PCG-23 | Deutsche Telekom | Rel-10 | SP-45 | Alain |
| 28 | 15.1 | Stage 1 for CCNL | 1d? | 2009-09-24 A | 2009-09-24 A | 100% |  | 2009-09-24 | 2009-09-24 | 1d? |  | start no earlier than 2009-09-24 | S1 | 8h | 8h | CCNL | PCG-23 | Deutsche Telekom | Rel-10 | SP-45 | Alain |
| 29 | 16 | **Local IP Access and Selected Internet IP Traffic Offload** | 321d? | 2009-09-24 A | 2010-12-16 | 13% | 277.8d? | 2009-09-24 | 2010-12-16 | 321d? | 196d |  | S2,S1,S3,S5 | 13384h | 1455.6h | LIPA_SIPTO | PCG-23 | Huawei, China Mobile | Rel-10 | SP-45 | Maurice |
| 30 | 16.1 | TR on LIPA_SIPTO | 186d? | 2009-09-24 A | 2010-06-10 | 45% | 102.3d? | 2009-09-24 | 2010-06-10 | 186d? | 331d | finish no earlier than 2010-06-10 | S2 | 1488h | 669.6h | LIPA_SIPTO | PCG-23 | Huawei, China Mobile | Rel-10 | SP-45 | Maurice |
| 31 | 16.2 | Stage 1 for LIPA_SIPTO | 131d? | 2009-09-24 A | 2010-03-25 | 75% | 32.75d? | 2009-09-24 | 2010-03-25 | 131d? | 386d | finish no earlier than 2010-03-25 | S1 | 1048h | 786h | LIPA_SIPTO | PCG-23 | Huawei, China Mobile | Rel-10 | SP-45 | Alain |
| 32 | 16.3 | Stage 2 for LIPA_SIPTO | 257d? | 2009-09-24 | 2010-09-17 |  |  | 2009-09-24 | 2010-09-17 | 257d? | 260d | finish no earlier than 2010-09-17 | S2 | 2056h |  | LIPA_SIPTO | PCG-23 | Huawei, China Mobile | Rel-10 | SP-45 | Maurice |
| 33 | 16.4 | Security for LIPA_SIPTO | 256d? | 2009-09-24 | 2010-09-16 |  |  | 2009-09-24 | 2010-09-16 | 256d? | 261d | finish no earlier than 2010-09-16 | S3 | 2048h |  | LIPA_SIPTO | PCG-23 | Huawei, Qualcomm Europe | Rel-10 | SP-45 | Dionisio |
| 34 | 16.5 | OAM&P for LIPA_SIPTO | 256d? | 2009-09-24 | 2010-09-16 |  |  | 2009-09-24 | 2010-09-16 | 256d? | 261d | finish no earlier than 2010-09-16 | S5 | 2048h |  | LIPA_SIPTO | PCG-23 | Huawei, China Mobile | Rel-10 | SP-45 | Dionisio |
| 35 | 16.6 | Charging for LIPA_SIPTO | 266d? | 2009-12-10 | 2010-12-16 |  |  | 2009-12-10 | 2010-12-16 | 266d? | 196d | finish no earlier than 2010-12-16 | S5 | 2128h |  | LIPA_SIPTO | PCG-24 | Huawei, China Mobile | Rel-10 | SP-46 | Dionisio |
| 36 | 17 | **IP Flow Mobility and seamless WLAN offload** | 186d? | 2009-09-24 A | 2010-06-10 | 46% | 100.07d? | 2009-09-24 | 2010-06-10 | 186d? | 331d |  | S2,S1 | 3424h | 1581.83h | IFOM | PCG-23 | Qualcomm Europe | Rel-10 | SP-45 | Maurice |
| 37 | 17.1 | Stage 1 for IFOM | 56d? | 2009-09-24 A | 2009-12-10 A | 100% |  | 2009-09-24 | 2009-12-10 | 56d? |  | finish no earlier than 2009-12-10 | S1 | 448h | 448h | IFOM | PCG-23 | Qualcomm Europe | Rel-10 | SP-45 | Alain |
| 38 | 17.2 | Stage 2 for IFOM | 186d? | 2009-09-24 A | 2010-06-10 | 30% | 130.2d? | 2009-09-24 | 2010-06-10 | 186d? | 331d | finish no earlier than 2010-06-10 | S2 | 1488h | 446.4h | IFOM | PCG-23 | Qualcomm Europe | Rel-10 | SP-45 | Maurice |
| 39 | 18 | **Enabling Coder Selection and Rate Adaptation for UTRAN and E-UTRAN for Load Adaptive Applications** | 257d? | 2009-09-24 A | 2010-09-17 | 2% | 251.6d? | 2009-09-24 | 2010-09-17 | 257d? | 260d |  | S2,S4,R2 | 5600h | 117.56h | ECSRA_LAA | PCG-23 | Qualcomm Europe | Rel-10 | SP-45 | Maurice |
| 40 | 18.1 | TR on ECSRA_LAA | 186d? | 2009-09-24 A | 2010-06-10 | 5% | 176.7d? | 2009-09-24 | 2010-06-10 | 186d? | 331d | finish no earlier than 2010-06-10 | S2,S4,R2 | 1488h | 74.4h | ECSRA_LAA | PCG-23 | Qualcomm Europe | Rel-10 | SP-45 | Maurice |
| 41 | 18.2 | Stage 2 for ECSRA_LAA | 257d? | 2009-09-24 | 2010-09-17 |  |  | 2009-09-24 | 2010-09-17 | 257d? | 260d | finish no earlier than 2010-09-17 | S2 | 2056h |  | ECSRA_LAA | PCG-23 | Qualcomm Europe | Rel-10 | SP-45 | Maurice |
| 42 | 19 | Support BroadBand Forum (BBF) Accesses Interworking | 76d? | 2009-12-10 | 2010-03-25 |  |  | 2009-12-10 | 2010-03-25 | 76d? | 386d | start no earlier than 2009-12-10 | S1 | 608h |  | BBAI | PCG-24 | Ericsson | Rel-10 | SP-46 | Alain |
| 43 | 20 | Optimal Media Routeing | 76d? | 2009-12-10 | 2010-03-25 |  |  | 2009-12-10 | 2010-03-25 | 76d? | 386d | finish no earlier than 2010-03-25 | S2 | 608h |  | OMR | PCG-24 | Alcatel-Lucent | Rel-10 | SP-46 | Maurice |
| 44 | 21 | Enhanced Multimedia Priority Service - Phase 2 | 137d? | 2009-12-10 | 2010-06-18 |  |  | 2009-12-10 | 2010-06-18 | 137d? | 325d | finish no earlier than 2010-06-18 | S2 | 1096h |  | PRIOR2 | PCG-24 | Telcordia, NTT DoCoMo | Rel-10 | SP-46 | Maurice |
| 45 | 22 | EEA3 and EIA3 (new Encryption & Integrity EPS security algorithms) | 401d? | 2009-06-04 | 2010-12-16 |  |  | 2009-06-04 | 2010-12-16 | 401d? | 196d | finish no earlier than 2010-12-16 | S3 | 3208h |  | EEA3_EIA3 | PCG-23 | CATR | Rel-10 | SP-44 | Dionisio |
| 46 | 23 | **OAM&P 10** | 332d? | 2009-12-10 | 2011-03-18 |  |  | 2009-12-10 | 2011-03-18 | 332d? | 130d |  | S5 | 14352h |  | OAM10 | PCG-24 |  | Rel-10 | SP-46 | Dionisio |
| 47 | 23.1 | **Network Infrastructure Management** | 332d? | 2009-12-10 | 2011-03-18 |  |  | 2009-12-10 | 2011-03-18 | 332d? | 130d |  | S5 | 5312h |  | OAM10-NIM | PCG-24 |  | Rel-10 | SP-46 | Dionisio |
| 48 | 23.1.1 | Common RAT Network Resource Model (NRM) | 332d? | 2009-12-10 | 2011-03-18 |  |  | 2009-12-10 | 2011-03-18 | 332d? | 130d | finish no earlier than 2011-03-18 | S5 | 2656h |  | RAT_NRM_common | PCG-24 | Ericsson | Rel-10 | SP-46 | Dionisio |
| 49 | 23.2 | **Self-Organizing Networks (SON) - OAM aspects** | 266d? | 2009-12-10 | 2010-12-16 |  |  | 2009-12-10 | 2010-12-16 | 266d? | 196d |  | S5 | 6384h |  | OAM10-SON | PCG-24 |  | Rel-10 | SP-46 | Dionisio |
| 50 | 23.2.1 | SON Self-optimization management continuation | 266d? | 2009-12-10 | 2010-12-16 |  |  | 2009-12-10 | 2010-12-16 | 266d? | 196d | finish no earlier than 2010-12-16 | S5 | 2128h |  | LTE-SON-OAM_SO | PCG-24 | Huawei | Rel-10 | SP-46 | Dionisio |
| 51 | 23.2.2 | SON Self-healing management | 266d? | 2009-12-10 | 2010-12-16 |  |  | 2009-12-10 | 2010-12-16 | 266d? | 196d | finish no earlier than 2010-12-16 | S5 | 2128h |  | LTE-SON-OAM_SH | PCG-24 | ZTE | Rel-10 | SP-46 | Dionisio |
| 52 | 24 | Definition of 3GPP UICC services over the new high-speed interface | 786d? | 2007-12-10 A | 2010-12-10 | 15% | 666.6d? | 2007-12-10 | 2010-12-10 | 786d? | 200d | finish no earlier than 2010-12-10 | C6 | 6288h | 955.2h | UICCHS | PCG-21 | Gemalto | Rel-10 | CP-38 | Xavier |

Notes:
- 27: SP#45 WID approved. Stage 1 completed / Text5: Kurt Bischinger
- 28: SP#45 WID approved. Stage 1 completed / Text3: 22.173 CR#0056r1 Call Completion on Not Logged in (CCNL) / Text5: Kurt Bischinger
- 29: SP#46 updated WID SP-090618=>SP-090761 (added SA5 aspects). UID_400035 Enhanced Home NodeB/eNodeB (EHNB) formerly covered Local IP Access to Internet and Local access to Home Network from the Home NodeB/eNodeB Features now covered by this WI / Text5: patrice.hede@huawei.com, Tao Sun (suntao@chinamobile.com)
- 30: SP#46 completion 03/10=>06/10 / Text3: new 23.829 / Text5: patrice.hede@huawei.com, Tao Sun (suntao@chinamobile.com)
- 31: - / Text3: 22.101, 22.220 / Text5: Amar Deol (adeolf@huawei.com), Gang Li (ligangyf@chinamobile.com)
- 32: SP#46 completion 06/10=>09/10 / Text3: 23.060, 23.203, 23.401 / Text5: patrice.hede@huawei.com, Tao Sun (suntao@chinamobile.com)
- 33: - / Text3: 33.102, 33.107, 33.108, 33.320, 33.401 / Text5: Marcus Wong (mwong@huawei.com), Brian Rosenberg (bmr@qualcomm.com)
- 34: SP#46 updated WID SP-090618=>SP-090761 (added SA5 aspects) / Text3: 32.101, 32.102, 32.405, 32.425, 32.452, 32.453, 32.581, 32.582, 32.583, 32.584, 32.591, 32.592, 32.593, 32.594, 32.64x, 32.76x / Text5: Zou Lan (zlan@huawei.com), Chen Gang (chengang@chinamobile.com)
- 35: SP#46 updated WID SP-090618=>SP-090761 (added SA5 aspects) / Text3: 32.240, 32.251, 32.298, 32.299 / Text5: shan.mingjun@huawei.com, Ai Chen (chenai@chinamobile.com)
- 36: SP#46 WID updated SP-090616=>SP-090804. Triggered by Rel-10 TR 23.861 (UID_410043 Study on Multi Access PDN connectivity and IP flow mobility - MAPIM) / Text5: Gerardo Giaretta (gerardo@qualcomm.com)
- 37: SP#46 completed / Text3: 22.278 / Text5: David Williams (dwilliam@qualcomm.com)
- 38: SP#46 WID nupdated SP-090616=>SP-090804. / Text3: 23.203, 23.402, new TS 23.261 (IP Flow Mobility and Seamless WLAN Offload) / Text5: Gerardo Giaretta (gerardo@qualcomm.com)
- 39: Triggered by Rel-9 UID_440013 Vocoder rate adaptation for LTE / Text5: AC Mahendran (ac@qualcomm.com)
- 40: Needs Liaison with SA4, RAN2 / Text3: new 23.860 / Text5: AC Mahendran (ac@qualcomm.com)
- 41: SP#46 completion 06/10=>09/10 / Text3: 23.060, 23.203, 23.228, 23.401 / Text5: AC Mahendran (ac@qualcomm.com)
- 42: Triggered by BBF WT 203. Interworking between the 3GPP EPS and the fixed broadband accesses as defined by BBF / Text3: 22.278 / Text5: Peter Bleckert
- 43: Triggered by TR 23.894 (UID_370050 Study on System enhancements for the use of IMS services in local breakout) / Text3: 23.228 (IMS Stage 2) / Text5: andy.bennett@alcatel-lucent.com
- 44: - / Text3: 23.203, 23.272, 23.401, new TR 23.8yz (Enhanced Multimedia Priority Service for E-UTRAN) / Text5: Vijay Varma, Katsutoshi Nishida
- 45: develop new EPS algorithms acceptable to regions such as China / Text3: 35.xxx (EEA3 & EIA3 Algorithm Specification, Implementers’ test data, Design and evaluation report, Final project report), 33.401 (SAE Security Architecture) / Text5: Yuan Qi, yuanqi@mail.ritt.com.cn
- 46: -
- 47: -
- 48: To reduce costs, some equipment can be shared between several RATs, e.g. RET, TMA and repeaters. With existing modelling it is very difficult for an operator to see that several cells are affected when an antenna tilt is changed etc / Text3: new (TR 32.9xx, TSs 32.7x1, 32.7x2, 32.7x3, 32.7x5), 32.615, 32.642, 32.643, 32.645, 32.652, 32.653, 32.655, 32.762, 32.763, 32.765 / Text5: Robert Petersen
- 49: umbrella BB
- 50: Continuation of Rel-9 work UID_390007 SON self-optimization management / Text3: 32.425, 32.521, 32.522, 32.752, 32.753, 32.755, 32.762, 32.763, 32.765 / Text5: Lan Zou (zlan@huawei.com)
- 51: Work moved to Rel-10 after split of the Rel-9 UID_390007 SON self-optimization (removed Self-Healing handling) / Text3: new TS (32.541, 32.542, 32.543), 32.752, 32.753, 32.755, 32.762, 32.763, 32.765 / Text5: zhu.weihong@zte.com.cn
- 52: CP#46 moved to Rel-10. Provide updated WID at CP#47 / Text3: 31.xyz / Text5: Denis L'Heriteau

| ID | WBS | Task | Duration | Start | Finish | Complete | Remaining | Baseline start | Baseline finish | Baseline duration | Total slack | Constraint | Resources | Work | Actual work | Text1 | Text2 | Text4 | Text5 | Text6 | Text7 | Text8 | Text11 |
| --- | --- | --- | --- | --- | --- | --- | --- | --- | --- | --- | --- | --- | --- | --- | --- | --- | --- | --- | --- | --- | --- | --- | --- |
| 53 | 25 | **UMTS/LTE 3500 MHz** | 657d? | 2007-11-30 A | 2010-06-04 | 26% | 486.6d? | 2007-11-30 | 2010-06-04 | 657d? | 335d |  | R4,R2,R3,R5 | 13754h | 3567.27h | RInImp8-UMTSLTE3500 | PCG-21 | Ericsson | Jjohan.skold@ericsson.com | Rel-10 | RP-38 | Issam |  |
| 54 | 25.1 | UMTS/LTE 3500 MHz | 645d? | 2007-11-30 A | 2010-06-04 | 55% | 290.25d? | 2007-11-30 | 2010-06-04 | 645d? | 335d | finish no earlier than 2010-06-04 | R4,R2,R3 | 5160h | 2838h | RInImp8-UMTSLTE3500 | PCG-21 | Ericsson | Jjohan.skold@ericsson.com | Rel-10 | RP-38 | Issam | RP-091032 |
| 55 | 25.2 | Conformance Test Aspects – LTE 3500 | 392d? | 2008-12-05 A | 2010-06-04 | 2% | 383.96d? | 2008-12-05 | 2010-06-04 | 392d? | 335d | finish no earlier than 2010-06-04 | R5 | 3136h | 64.32h | LTE-UEConTest_LTE3500 | PCG-22 | Ericsson | fredrik.sundstrom@ericsson.com | Rel-10 | RP-42 | Ingbert | RP-091063 |
| 56 | 25.3 | Conformance Test Aspects – UMTS 3500 | 392d? | 2008-12-05 A | 2010-06-04 | 2% | 384.16d? | 2008-12-05 | 2010-06-04 | 392d? | 335d | finish no earlier than 2010-06-04 | R5 | 3136h | 62.72h | RInImp-UEConTest_UMTS3500 | PCG-22 | Nokia | jukka.vikstedt@nokia.com | Rel-10 | RP-42 | Ingbert | RP-091064 |
| 57 | 26 | 1.28 Mcps TDD Repeater | 654d? | 2007-12-04 A | 2010-06-04 | 85% | 98.1d? | 2007-12-04 | 2010-06-04 | 654d? | 335d | finish no earlier than 2010-06-04 | R4 | 5232h | 4447.2h | RANimp-Repeaters1.28TDD | PCG-21 | RITT | qinyan@chinattl.com | Rel-10 | RP-38 | Issam | RP-091053 |
| 58 | 27 | 1.28 Mcps TDD Multi-carrier HSUPA | 321d? | 2009-09-18 A | 2010-12-10 | 5% | 305.2d? | 2009-09-18 | 2010-12-10 | 321d? | 200d | finish no earlier than 2010-12-10 | R1,R2,R3,R4 | 2568h | 126.4h | TDD_MC_HSUPA | PCG-23 | CATR | Aihui Song (songaihui@mail.ritt.com.cn) | Rel-10 | RP-45 | Patrick | RP-091056 |
| 59 | 28 | **1.28 Mcps TDD Home NodeB RF requirements** | 266d? | 2009-12-04 | 2010-12-10 |  |  | 2009-12-04 | 2010-12-10 | 266d? | 200d |  | R4 | 5384h |  | HNB_LCRTDD_RF | PCG-24 | TD Tech | Li Rong (lirong@td-tech.com) | Rel-10 | RP-46 | Issam |  |
| 60 | 28.1 | Core - 1.28 Mcps TDD Home NodeB RF requirements | 141d? | 2009-12-04 | 2010-06-18 |  |  | 2009-12-04 | 2010-06-18 | 141d? | 325d | finish no earlier than 2010-06-18 | R4 | 1128h |  | HNB_LCRTDD_RF-Core | PCG-24 | TD Tech | Li Rong (lirong@td-tech.com) | Rel-10 | RP-46 | Issam |  |
| 61 | 28.2 | Perf - 1.28 Mcps TDD Home NodeB RF requirements | 266d? | 2009-12-04 | 2010-12-10 |  |  | 2009-12-04 | 2010-12-10 | 266d? | 200d | finish no earlier than 2010-12-10 | R4 | 2128h |  | HNB_LCRTDD_RF-Perf | PCG-24 | TD Tech | Li Rong (lirong@td-tech.com) | Rel-10 | RP-46 | Issam |  |
| 62 | 29 | UTRAN 2 ms TTI uplink range improvement | 402d? | 2009-03-06 A | 2010-09-17 | 8% | 369.84d? | 2009-03-06 | 2010-09-17 | 402d? | 260d | finish no earlier than 2010-09-17 | R1,R2,R3,R4 | 3216h | 257.28h | RANimp-2mTTI_ULimp | PCG-22 | Nokia Siemens Networks | Karri Ranta-aho (karri.ranta-aho@nsn.com) | Rel-10 | RP-43 | Patrick | RP-091054 |
| 63 | 30 | A-GNSS Minimum Performance for UTRAN | 261d? | 2009-09-18 | 2010-09-17 |  |  | 2009-09-18 | 2010-09-17 | 261d? | 260d | finish no earlier than 2010-09-17 | R4 | 2088h |  | AGNSSPerf_UTRAN | PCG-23 | Thales | Michel.monnerat@thalesaleniaspace.com | Rel-10 | RP-45 | Issam | RP-091055 |
| 64 | 31 | UE Over The Air (Antenna) conformance testing methodology - Laptop mounted equipment Free Space test | 521d? | 2009-09-18 A | 2011-09-16 | 5% | 494.95d? | 2009-09-18 | 2011-09-16 | 521d? | 0d | finish no earlier than 2011-09-16 | R4 | 4168h | 208.4h | UEAnt_FSTest | PCG-23 | CATR | Guo Lin (guolin@emcite.com) | Rel-10 | RP-45 | Issam | RP-091057 |
| 65 | 32 | **Inclusion of "RF Pattern Matching Technologies" as positioning method in the UTRAN** | 141d? | 2009-12-04 | 2010-06-18 |  |  | 2009-12-04 | 2010-06-18 | 141d? | 325d |  | R2,R3 | 2256h |  | LCS_UMTS_RFPMT | PCG-24 | Polaris Wireless | Norman Shaw | Rel-10 | RP-46 | Joern |  |
| 66 | 32.1 | Core - Inclusion of “RF Pattern Matching Technologies” as positioning method in the UTRAN | 141d? | 2009-12-04 | 2010-06-18 |  |  | 2009-12-04 | 2010-06-18 | 141d? | 325d | finish no earlier than 2010-06-18 | R2,R3 | 1128h |  | LCS_UMTS_RFPMT | PCG-24 | Polaris Wireless | Norman Shaw | Rel-10 | RP-46 | Joern |  |
| 67 | 33 | **Minimization of Drive Tests for E-UTRAN and UTRAN** | 266d? | 2009-12-04 | 2010-12-10 |  |  | 2009-12-04 | 2010-12-10 | 266d? | 200d |  | R2,R4,R3 | 4256h |  | MDT_UMTSLTE | PCG-24 | Nokia Siemens Networks | Malgorzata Tomala | Rel-10 | RP-46 | Joern |  |
| 68 | 33.1 | Core - MDT for E-UTRAN and UTRAN | 266d? | 2009-12-04 | 2010-12-10 |  |  | 2009-12-04 | 2010-12-10 | 266d? | 200d | finish no earlier than 2010-12-10 | R2,R4,R3 | 2128h |  | MDT_UMTSLTE-Core | PCG-24 | Nokia Siemens Networks | Malgorzata Tomala | Rel-10 | RP-46 | Joern |  |
| 69 | 34 | **Fixed Wireless Customer-Premises Equipment (CPE) RF Requirements** | 270d? | 2009-12-04 | 2010-12-16 |  |  | 2009-12-04 | 2010-12-16 | 270d? | 196d |  | R4,R5 | 6008h |  | FW_CPE_RF | PCG-24 | Verizon Wireless | zheng.zhao@verizonwireless.com | Rel-10 | RP-46 | Issam |  |
| 70 | 34.1 | Core - Fixed Wireless CPE RF Requirements | 211d? | 2009-12-04 | 2010-09-24 |  |  | 2009-12-04 | 2010-09-24 | 211d? | 255d | finish no earlier than 2010-09-24 | R4 | 1688h |  | FW_CPE_RF-Core | PCG-24 | Verizon Wireless | zheng.zhao@verizonwireless.com | Rel-10 | RP-46 | Issam |  |
| 71 | 34.2 | Test - Fixed Wireless CPE RF Requirements | 270d? | 2009-12-04 | 2010-12-16 |  |  | 2009-12-04 | 2010-12-16 | 270d? | 196d | finish no earlier than 2010-12-16 | R5 | 2160h |  | FW_CPE_RF-UEConfTest | PCG-24 | Verizon Wireless | zheng.zhao@verizonwireless.com | Rel-10 | RP-46 | Ingbert |  |
| 72 | 35 | **Four carrier HSDPA** | 400d? | 2009-12-04 | 2011-06-16 |  |  | 2009-12-04 | 2011-06-16 | 400d? | 66d |  | R1,R2,R3,R4 | 8528h |  | 4C_HSDPA | PCG-24 | Qualcomm Europe | Arjun Bharadwaj (arjunb@qualcomm.com) | Rel-10 | RP-46 | Patrick |  |
| 73 | 35.1 | Core - Four carrier HSDPA | 266d? | 2009-12-04 | 2010-12-10 |  |  | 2009-12-04 | 2010-12-10 | 266d? | 200d | finish no earlier than 2010-12-10 | R1,R2,R3,R4 | 2128h |  | 4C_HSDPA-Core | PCG-24 | Qualcomm Europe | Arjun Bharadwaj (arjunb@qualcomm.com) | Rel-10 | RP-46 | Patrick |  |
| 74 | 35.2 | Perf - Four carrier HSDPA | 400d? | 2009-12-04 | 2011-06-16 |  |  | 2009-12-04 | 2011-06-16 | 400d? | 66d | finish no earlier than 2011-06-16 | R4 | 3200h |  | 4C_HSDPA-Perf | PCG-24 | Qualcomm Europe | Arjun Bharadwaj (arjunb@qualcomm.com) | Rel-10 | RP-46 | Issam |  |
| 75 | 36 | **Carrier Aggregation for LTE** | 400d? | 2009-12-04 | 2011-06-16 |  |  | 2009-12-04 | 2011-06-16 | 400d? | 66d |  | R1,R2,R3,R4 | 8528h |  | LTE_CA | PCG-24 | Nokia | Asbjørn Grøvlen | Rel-10 | RP-46 | Patrick |  |
| 76 | 36.1 | Core - Carrier Aggregation for LTE | 266d? | 2009-12-04 | 2010-12-10 |  |  | 2009-12-04 | 2010-12-10 | 266d? | 200d | finish no earlier than 2010-12-10 | R1,R2,R3,R4 | 2128h |  | LTE_CA-Core | PCG-24 | Nokia | Asbjørn Grøvlen | Rel-10 | RP-46 | Patrick |  |
| 77 | 36.2 | Perf - Carrier Aggregation for LTE | 400d? | 2009-12-04 | 2011-06-16 |  |  | 2009-12-04 | 2011-06-16 | 400d? | 66d | finish no earlier than 2011-06-16 | R4 | 3200h |  | LTE_CA-Perf | PCG-24 | Nokia | Asbjørn Grøvlen | Rel-10 | RP-46 | Issam |  |

Notes:
- 53: RP#46 moved to Rel-10. WID updated RP-081096=>RP-091380
- 54: RP#46 moved to Rel-10. WID updated RP-081096=>RP-091380 / Text3: 25.101, 25.104, 25.113, 25.133, 25.141, 25.307, 25.307, 25.331, 25.461, 25.463, 34.124, 36.101, 36.104, 36.113, 36.141, 36.331
- 55: RP#46 moved to Rel-10 / Text3: 36.508, 36.521-1, 36.521-2, 36.521-3
- 56: RP#46 moved to Rel-10 / Text3: 34.108, 34.121-1, 34.121-2
- 57: RP#45 completion 12/09=>06/10 / Text3: 25.113, new 25.116, 25.153 (testing)
- 58: - / Text3: 25.102, 25.105, 25.123, 25.221, 25.222, 25.223, 25.224, 25.225, 25.306, 25.319, 25.321, 25.331, 25.423, 25.427, 25.433
- 59: Triggered by FS_RAN-HNBLCRTDD UID_410016 Study on 1.28 Mcps TDD Home NodeB (TR 25.866)
- 60: - / Text3: 25.105
- 61: - / Text3: 25.142
- 62: RP#46 moved to Rel-10 (No activity in WGs=>RP#47 to decide a way forward). Cell sets the TTI (Transmission Time Interval) to 2 ms / Text3: 25.133, 25.212, 25.214, 25.321, 25.331
- 63: RP#46 definition of GNSS min performance reqs in GERAN delayed. Triggered by Rel-7 UID_20050 (GNSS in UTRAN) and Rel-8 UID_400051 (Support for Additional NSS). Linked to GERAN Rel-9 UID_38002 (A-GNSS Performances and Testing Procedures) / Text3: 25.171, 34.108, 34.123, 34.171, 34.109
- 64: - / Text3: 25.144, 25.914, 34.114
- 65: Triggered by Study UID_380079 Evaluation of the inclusion of Path Loss Based Technology in the UTRAN (25.907)
- 66: - / Text3: 25.305, 25.453
- 67: Triggered by UID_430021 TR 36.805 (Study on Minimization of drive-tests in NGN)
- 68: - / Text3: 25.133, 25.215, 25.304, 25.331, 25.423, 36.133, 36.214, 36.300, 36.304, 36.331, 36.413, 36.423
- 69: Add new power classes in E-UTRAN UL to allow CPE type applications to be operated at higher max output power
- 70: - / Text3: 36.101
- 71: - / Text3: 36.521-1
- 72: -
- 73: - / Text3: 25.101, 25.104, 25.133, 25.211, 25.212, 25.213, 25.214, 25.215, 25.308, 25.331, 25.423, 25.433, 26.306
- 74: - / Text3: 25.101, 25.104, 25.133, 25.141
- 75: Triggered by FS_RAN_LTEA (Study on LTE-Advanced) 36.912, 36. 814
- 76: - / Text3: 36.101, 36.104, 36.133, 36.211, 36.212, 36.213, 36.300, 36.302, 36.306, 36.321, 36.331, 36.413, 36.423
- 77: - / Text3: 36.101, 36.104, 36.133, 36.141, 36.211, 36.212, 36.213, 36.300, 36.302, 36.306, 36.321, 36.331, 36.413, 36.423

| ID | WBS | Task | Type | Duration | Start | Finish | Complete | Remaining | Baseline start | Baseline finish | Baseline duration | Total slack | Constraint | Resources | Work | Actual work | Text1 | Text2 | Text4 | Text6 | Text7 | Text8 | Text9 | Text12 | Text11 |
| --- | --- | --- | --- | --- | --- | --- | --- | --- | --- | --- | --- | --- | --- | --- | --- | --- | --- | --- | --- | --- | --- | --- | --- | --- | --- |
| 78 | 37 | **Enhanced Downlink Multiple Antenna Transmission for LTE** |  | 400d? | 2009-12-04 | 2011-06-16 |  |  | 2009-12-04 | 2011-06-16 | 400d? | 66d |  | R1,R2,R4 | 8528h |  | LTE_eDL_MIMO | PCG-24 | NTT DoCoMo | Rel-10 | RP-46 | Patrick |  |  |  |
| 79 | 37.1 | Core - Enhanced Downlink Multiple Antenna Transmission for LTE |  | 266d? | 2009-12-04 | 2010-12-10 |  |  | 2009-12-04 | 2010-12-10 | 266d? | 200d | finish no earlier than 2010-12-10 | R1,R2,R4 | 2128h |  | LTE_eDL_MIMO-Core | PCG-24 | NTT DoCoMo | Rel-10 | RP-46 | Patrick |  |  |  |
| 80 | 37.2 | Perf - Enhanced Downlink Multiple Antenna Transmission for LTE |  | 400d? | 2009-12-04 | 2011-06-16 |  |  | 2009-12-04 | 2011-06-16 | 400d? | 66d | finish no earlier than 2011-06-16 | R4 | 3200h |  | LTE_eDL_MIMO-Perf | PCG-24 | NTT DoCoMo | Rel-10 | RP-46 | Issam |  |  |  |
| 81 | 38 | **Uplink Multiple Antenna Transmission for LTE** |  | 400d? | 2009-12-04 | 2011-06-16 |  |  | 2009-12-04 | 2011-06-16 | 400d? | 66d |  | R1,R2,R4 | 8528h |  | LTE_UL_MIMO | PCG-24 | Huawei | Rel-10 | RP-46 | Patrick |  |  |  |
| 82 | 38.1 | Core - UL Multiple Antenna Transmission for LTE |  | 266d? | 2009-12-04 | 2010-12-10 |  |  | 2009-12-04 | 2010-12-10 | 266d? | 200d | finish no earlier than 2010-12-10 | R1,R2,R4 | 2128h |  | LTE_UL_MIMO-Core | PCG-24 | Huawei | Rel-10 | RP-46 | Patrick |  |  |  |
| 83 | 38.2 | Perf - UL Multiple Antenna Transmission for LTE |  | 400d? | 2009-12-04 | 2011-06-16 |  |  | 2009-12-04 | 2011-06-16 | 400d? | 66d | finish no earlier than 2011-06-16 | R4 | 3200h |  | LTE_UL_MIMO-Perf | PCG-24 | Huawei | Rel-10 | RP-46 | Issam |  |  |  |
| 84 | 39 | **Latency reductions for LTE** |  | 266d? | 2009-12-04 | 2010-12-10 |  |  | 2009-12-04 | 2010-12-10 | 266d? | 200d |  | R1,R2 | 4256h |  | LTE_LATRED | PCG-24 | Ericsson | Rel-10 | RP-46 | Patrick |  |  |  |
| 85 | 39.1 | Core - Latency reductions for LTE |  | 266d? | 2009-12-04 | 2010-12-10 |  |  | 2009-12-04 | 2010-12-10 | 266d? | 200d | finish no earlier than 2010-12-10 | R1,R2 | 2128h |  | LTE_LATRED-Core | PCG-24 | Ericsson | Rel-10 | RP-46 | Patrick |  |  |  |
| 86 | 40 | **Relays for LTE** |  | 336d? | 2009-12-04 | 2011-03-18 |  |  | 2009-12-04 | 2011-03-18 | 336d? | 130d |  | R1,R2,R4 | 7504h |  | LTE_Relay | PCG-24 | Ericsson | Rel-10 | RP-46 | Patrick |  |  |  |
| 87 | 40.1 | Core - Relays for LTE |  | 266d? | 2009-12-04 | 2010-12-10 |  |  | 2009-12-04 | 2010-12-10 | 266d? | 200d | finish no earlier than 2010-12-10 | R1,R2,R4 | 2128h |  | LTE_Relay-Core | PCG-24 | Ericsson | Rel-10 | RP-46 | Patrick |  |  |  |
| 88 | 40.2 | Perf - Relays for LTE |  | 336d? | 2009-12-04 | 2011-03-18 |  |  | 2009-12-04 | 2011-03-18 | 336d? | 130d | finish no earlier than 2011-03-18 | R4 | 2688h |  | LTE_Relay-Perf | PCG-24 | Ericsson | Rel-10 | RP-46 | Issam |  |  |  |
| 89 | 41 | (Small) Technical Enhancements and Improvements for Rel-10 |  | 136d? | 2009-06-04 | 2009-12-10 |  |  | 2009-06-04 | 2009-12-10 | 136d? | 461d | finish no earlier than 2009-12-10 | All | 1088h |  | TEI10 | PCG-23 | ALL | Rel-10 | SP-44 |  |  |  |  |
| 90 | 42 | **Deleted - Network Selection for non-3GPP Access** |  | 471d? | 2007-12-07 A | 2009-09-24 A | 100% |  | 2007-12-07 | 2009-09-24 | 471d? |  |  | S1,C6 | 10452.8h | 10452.8h | N3GtoNSP | PCG-21 | Telefonica O2 | Rel-10 | SP-38 | Alain | PCG-23 | SP-45 |  |
| 91 | 42.1 | Deleted - Stage 1 for N3GtoNSP |  | 471d? | 2007-12-07 A | 2009-09-24 A | 100% |  | 2007-12-07 | 2009-09-24 | 471d? |  | finish no earlier than 2009-12-10 | S1 | 3768h | 3768h | N3GtoNSP | PCG-21 | Telefonica O2 | Rel-10 | SP-38 | Alain | PCG-23 | SP-45 |  |
| 92 | 42.2 | Deleted - CT6 issues for N3GtoNSP |  | 471d? | 2007-12-07 A | 2009-09-24 A | 100% |  | 2007-12-07 | 2009-09-24 | 471d? |  | finish no earlier than 2009-12-04 | C6 | 3768h | 3768h | N3GtoNSP | PCG-21 | Telefonica O2 | Rel-10 | CP-38 | Xavier | PCG-23 | CP-45 |  |
| 93 | 43 | **Deleted - Registration in Densely-populated area (RED)** |  | 665d? | 2007-03-12 A | 2009-09-24 A | 100% |  | 2007-03-12 | 2009-09-24 | 665d? |  |  | S1 | 9544h | 9544h | RED |  | NTT DoCoMo | Rel-10 | SP-35 | Alain | PCG-24 | SP-46 |  |
| 94 | 43.1 | Deleted - Stage 1 for RED |  | 4d? | 2007-03-12 A | 2007-03-15 A | 100% |  | 2007-03-12 | 2007-03-15 | 4d? |  | start no earlier than 2007-03-12 | S1 | 32h | 32h | RED |  | NTT DoCoMo | Rel-10 | SP-35 | Alain | PCG-24 | SP-46 |  |
| 95 | 43.2 | Deleted - Stage 2 for RED |  | 524d? | 2007-09-25 A | 2009-09-24 A | 100% |  | 2007-09-25 | 2009-09-24 | 524d? |  | finish no earlier than 2009-09-24 | S2 | 4192h | 4192h | RED |  | NTT DoCoMo | Rel-10 | SP-37 | Maurice | PCG-23 | SP-45 |  |
| 96 | 44 | **Deleted - Network Selection for non-3GPP Access** |  | 471d? | 2007-12-07 A | 2009-09-24 A | 100% |  | 2007-12-07 | 2009-09-24 | 471d? |  |  | S1,C6 | 10452.8h | 10452.8h | N3GtoNSP | PCG-21 | Telefonica O2 | Rel-10 | SP-38 | Alain | PCG-23 | SP-45 |  |
| 97 | 44.1 | Deleted - Stage 1 for N3GtoNSP |  | 471d? | 2007-12-07 A | 2009-09-24 A | 100% |  | 2007-12-07 | 2009-09-24 | 471d? |  | finish no earlier than 2009-12-10 | S1 | 3768h | 3768h | N3GtoNSP | PCG-21 | Telefonica O2 | Rel-10 | SP-38 | Alain | PCG-23 | SP-45 |  |
| 98 | 44.2 | Deleted - CT6 issues for N3GtoNSP |  | 471d? | 2007-12-07 A | 2009-09-24 A | 100% |  | 2007-12-07 | 2009-09-24 | 471d? |  | finish no earlier than 2009-12-04 | C6 | 3768h | 3768h | N3GtoNSP | PCG-21 | Telefonica O2 | Rel-10 | CP-38 | Xavier | PCG-23 | CP-45 |  |
| 99 | 45 | Deleted - Enhanced Home NodeB / eNodeB continuation of Rel-9 |  | 337d? | 2008-12-11 A | 2010-03-25 A | 100% |  | 2008-12-11 | 2010-03-25 | 337d? |  |  | S2 | 2696h | 2696h | eEHNB | PCG-23 | Alcatel-Lucent | Rel-10 | SP-44 | Maurice | PCG-24 | SP-47 |  |
| 100 | 46 | Release 10 Studies | milestone | 0d? | 2000-01-01 | 2000-01-01 |  |  | 2000-01-01 | 2000-01-01 | 0d? | 3057d | start no earlier than 2000-01-01 | S1 |  |  |  |  |  | Rel-10 |  |  |  |  |  |
| 101 | 47 | **Study on enhanced voice service requirements for the Evolved Packet System (EPS)** |  | 670d? | 2007-09-03 A | 2010-03-25 A | 100% |  | 2007-09-03 | 2010-03-25 | 670d? |  |  | S1,S4 | 13384h | 13384h | FS_EV_EPS |  | Orange | Rel-10 | SP-37 | Alain |  |  |  |
| 102 | 47.1 | Use cases definition and service and system requirements |  | 334d? | 2007-09-03 A | 2008-12-11 A | 100% |  | 2007-09-03 | 2008-12-11 | 334d? |  | finish no earlier than 2008-12-11 | S1 | 2672h | 2672h | FS_EV_EPS-S1 |  | Orange | Rel-10 | SP-37 | Alain |  |  |  |
| 103 | 47.2 | Codec specific part of FS_EV_EPS |  | 669d? | 2007-09-03 A | 2010-03-25 A | 100% |  | 2007-09-03 | 2010-03-25 | 669d? |  | finish no earlier than 2010-03-25 | S4 | 5352h | 5352h | FS_EV_EPS-S4 |  | Ericsson | Rel-10 | SP-37 | Paolo |  |  |  |
| 104 | 48 | Study on advanced requirements for IP interconnect |  | 528d? | 2007-12-04 A | 2009-12-10 A | 100% |  | 2007-12-04 | 2009-12-10 | 528d? |  | finish no earlier than 2009-12-10 | S1 | 4224h | 4224h | FS_IPXS | PCG-21 | Telefonica O2 | Rel-10 | SP-38 | Alain |  |  |  |
| 105 | 49 | Study on Unauthenticated PS Emergency Calls |  | 471d? | 2008-06-05 A | 2010-03-25 | 20% | 376.8d? | 2008-06-05 | 2010-03-25 | 471d? | 386d | finish no earlier than 2010-03-25 | S1 | 3768h | 753.6h | FS_UAPSEC | PCG-21 | Nokia Siemens Networks | Rel-10 | SP-40 | Alain |  |  |  |
| 106 | 50 | Study on Personal Broadcast Service |  | 397d? | 2008-09-18 A | 2010-03-25 | 90% | 39.7d? | 2008-09-18 | 2010-03-25 | 397d? | 386d | finish no earlier than 2010-03-25 | S1 | 3168h | 2850.4h | FS_PBS | PCG-21 | ETRI | Rel-10 | SP-41 | Alain |  |  |  |
| 107 | 51 | Study on LCS support in SAE for non-3GPP accesses |  | 397d? | 2008-09-18 A | 2010-03-25 | 70% | 119.1d? | 2008-09-18 | 2010-03-25 | 397d? | 386d | finish no earlier than 2010-03-25 | S1 | 3168h | 2215.2h | FS_LCS_n3GPP | PCG-21 | SK Telecom | Rel-10 | SP-41 | Alain |  |  |  |
| 108 | 52 | Study on Haptic Services |  | 272d? | 2009-03-12 A | 2010-03-25 | 80% | 54.4d? | 2009-03-12 | 2010-03-25 | 272d? | 386d | finish no earlier than 2010-03-25 | S1 | 2168h | 1732.8h | FS_Haptics | PCG-22 | SK Telecom | Rel-10 | SP-43 | Alain |  |  |  |
| 109 | 53 | Study on IMS based Peer-to-Peer Content Distribution Services |  | 196d? | 2009-09-24 A | 2010-06-24 | 50% | 98d? | 2009-09-24 | 2010-06-24 | 196d? | 321d | finish no earlier than 2010-06-24 | S1,S2 | 1568h | 784h | FS_IMS_P2P | PCG-23 | China Mobile | Rel-10 | SP-45 | Alain |  |  |  |
| 110 | 54 | Study on System enhancements for the use of IMS services in Local BreakOut and Optimal Routing of Media |  | 575d? | 2007-10-01 A | 2009-12-10 A | 100% |  | 2007-10-01 | 2009-12-10 | 575d? |  | finish no earlier than 2009-12-10 | S2 | 4600h | 4600h | FS_IMS_LBO_ORM |  | Telecom Italia, BT | Rel-10 | SP-37 | Maurice |  |  |  |
| 111 | 55 | Study on Intra Domain Connection of RAN Nodes to Multiple CN Nodes |  | 533d? | 2008-03-12 A | 2010-03-25 | 70% | 159.9d? | 2008-03-12 | 2010-03-25 | 533d? | 386d | finish no earlier than 2010-03-25 | S2 | 4264h | 2984.8h | FS_IDC | PCG-21 | China Mobile | Rel-10 | SP-39 | Maurice |  |  |  |
| 112 | 56 | Study on IMS Evolution |  | 397d? | 2008-09-18 A | 2010-03-25 | 70% | 119.1d? | 2008-09-18 | 2010-03-25 | 397d? | 386d | finish no earlier than 2010-03-25 | S2 | 3176h | 2223.2h | FS_eIMS | PCG-21 | China Mobile | Rel-10 | SP-41 | Maurice |  |  |  |
| 113 | 57 | Study on enhancements to IMS border functions for IMS Interconnection of services |  | 452d? | 2008-09-18 A | 2010-06-10 | 30% | 315.5d? | 2008-09-18 | 2010-06-10 | 452d? | 331d | finish no earlier than 2010-06-10 | S2 | 3616h | 1092h | FS_eIMS_IBCF | PCG-21 | Starent Networks | Rel-10 | SP-41 | Maurice |  |  |  |
| 114 | 58 | Study on Multi Access PDN connectivity and IP flow Mobility |  | 397d? | 2008-09-18 A | 2010-03-25 | 75% | 99.25d? | 2008-09-18 | 2010-03-25 | 397d? | 386d | finish no earlier than 2010-03-25 | S2,S1 | 3176h | 2382h | FS_MAPIM | PCG-21 | Qualcomm Europe | Rel-10 | SP-41 | Maurice |  |  |  |
| 115 | 59 | Study on Policy solutions and enhancements |  | 401d? | 2009-06-04 A | 2010-12-16 | 15% | 339.95d? | 2009-06-04 | 2010-12-16 | 401d? | 196d | finish no earlier than 2010-12-16 | S2,S1 | 3208h | 488.4h | FS_PP | PCG-23 | AT&T | Rel-10 | SP-44 | Maurice |  |  |  |
| 116 | 60 | Study on IPv6 Migration |  | 266d? | 2009-06-04 A | 2010-06-10 | 25% | 198.75d? | 2009-06-04 | 2010-06-10 | 266d? | 331d | finish no earlier than 2010-06-10 | S2 | 2128h | 538h | FS_IP6M | PCG-23 | China Mobile | Rel-10 | SP-44 | Maurice |  |  |  |
| 117 | 61 | Study on SR-VCC Enhancements |  | 337d? | 2009-06-04 A | 2010-09-17 | 20% | 269.4d? | 2009-06-04 | 2010-09-17 | 337d? | 260d | finish no earlier than 2010-09-17 | S2 | 2696h | 540.8h | FS_eSRVCC | PCG-23 | China Mobile | Rel-10 | SP-44 | Maurice |  |  |  |
| 118 | 62 | Study on SR-VCC from UTRAN/GERAN to E-UTRAN/HSPA |  | 137d? | 2009-12-10 | 2010-06-18 |  |  | 2009-12-10 | 2010-06-18 | 137d? | 325d | finish no earlier than 2010-06-18 | S2 | 1096h |  | FS_rSRVCC | PCG-24 | Orange | Rel-10 | SP-46 | Maurice |  |  |  |
| 119 | 63 | Study on UTRAN key management enhancements |  | 592d? | 2007-12-20 A | 2010-03-25 | 30% | 415.6d? | 2007-12-20 | 2010-03-25 | 592d? | 386d | finish no earlier than 2010-03-25 | S3 | 4736h | 1411.2h | FS_UKM | PCG-21 | Ericsson | Rel-10 | SP-38 | Dionisio |  |  |  |
| 120 | 64 | Study on Surround Sound codec extension for PSS and MBMS |  | 326d? | 2009-03-12 A | 2010-06-10 | 60% | 130.4d? | 2009-03-12 | 2010-06-10 | 326d? | 331d | finish no earlier than 2010-06-10 | S4 | 2608h | 1564.8h | FS_SS_PSS_MBMS | PCG-22 | Fraunhofer Gesellschaft | Rel-10 | SP-43 | Paolo |  |  |  |
| 121 | 65 | Study on Rc Reference Point Functionalities and Message Flows |  | 587d? | 2008-09-18 A | 2010-12-16 | 90% | 58.7d? | 2008-09-18 | 2010-12-16 | 587d? | 196d | finish no earlier than 2010-12-16 | S5 | 4688h | 4218.48h | FS_OAM_Rc | PCG-21 | Huawei | Rel-10 | SP-41 | Dionisio |  |  |  |
| 122 | 66 | Study on Telecommunication Management; Energy Savings Management |  | 461d? | 2009-03-12 A | 2010-12-16 | 60% | 184.4d? | 2009-03-12 | 2010-12-16 | 461d? | 196d | finish no earlier than 2010-12-16 | S5 | 3688h | 2212.8h | FS_OAM_ESM | PCG-22 | Orange, Vodafone | Rel-10 | SP-43 | Dionisio |  |  |  |
| 123 | 67 | Study on Integration of Device Management Information with Itf-N |  | 401d? | 2009-06-04 A | 2010-12-16 | 40% | 240.6d? | 2009-06-04 | 2010-12-16 | 401d? | 196d | finish no earlier than 2010-12-16 | S5 | 3208h | 1283.2h | FS_IDMI_Itf-N | PCG-23 | Motorola | Rel-10 | SP-44 | Dionisio |  |  |  |
| 124 | 68 | Study on EPC Charging enhancement |  | 401d? | 2009-06-04 A | 2010-12-16 | 5% | 380.65d? | 2009-06-04 | 2010-12-16 | 401d? | 196d | finish no earlier than 2010-12-16 | S5 | 3208h | 162.8h | FS_EPCcharg | PCG-23 | Nokia Siemens Networks | Rel-10 | SP-44 | Dionisio |  |  |  |
| 125 | 69 | Study on Alignment of 3GPP Generic NRM IRP and TMF Shared Information Data (SID) model |  | 131d? | 2000-01-03 | 2000-06-30 |  |  | 2000-01-03 | 2000-06-30 | 131d? | 2926d |  | S5 | 1048h |  | FS_3GNRM_TMFSID | PCG-24 | Nokia Siemens Networks | Rel-10 | SP-46 | Dionisio |  |  |  |
| 126 | 70 | Study on Harmonization of 3GPP Alarm IRP and TMF Interface Program (TIP) Fault Management |  | 131d? | 2009-12-10 | 2010-06-10 |  |  | 2009-12-10 | 2010-06-10 | 131d? | 331d | finish no earlier than 2010-06-10 | S5 | 1048h |  | FS_3G_TMF_FM | PCG-24 | Nokia Siemens Networks, Alcatel-Lucent | Rel-10 | SP-46 | Dionisio |  |  |  |
| 127 | 71 | Study on Policy and Charging Rules Function (PCRF) failure and restoration |  | 186d? | 2009-08-18 A | 2010-06-04 | 50% | 93d? | 2009-08-18 | 2010-06-04 | 186d? | 335d | finish no earlier than 2010-06-04 | C3 | 1488h | 744h | FS_PCRF-FR | PCG-23 | NEC | Rel-10 | CP-45 | Gwiho |  |  |  |
| 128 | 72 | Study on Measurement of Radiated Performance for MIMO and multi-antenna reception for HSPA and LTE terminals |  | 256.8d? | 2009-03-06 A | 2010-06-04 | 35% | 166.92d? | 2009-03-06 | 2010-06-04 | 256.8d? | 335d | finish no earlier than 2010-06-04 | R4 | 2054.4h | 719.03h | FS_HSPA_LTE_measRP_MIMO_multi-antenna | PCG-22 | Vodafone | Rel-10 | RP-43 | Issam |  |  | RP-091410 |
| 129 | 73 | Study on Extending 850 MHz |  | 266d? | 2009-05-30 A | 2010-06-04 | 5% | 252.7d? | 2009-05-30 | 2010-06-04 | 266d? | 335d | finish no earlier than 2010-06-04 | R4 | 2128h | 106.4h | FS_e850 | PCG-23 | Ericsson | Rel-10 | RP-44 | Issam |  |  | RP-091085 |
| 130 | 74 | Study on Uplink Tx Diversity for HSPA |  | 208.4d? | 2009-08-18 A | 2010-06-04 | 20% | 166.72d? | 2009-08-18 | 2010-06-04 | 208.4d? | 335d | finish no earlier than 2010-06-04 | R4 | 1667.2h | 333.43h | FS_UL-TxDiv-HSPA | PCG-23 | Qualcomm Europe | Rel-10 | RP-45 | Issam |  |  | RP-091086 |
| 131 | 75 | Study on RAN improvements for Machine-Type Communications |  | 186d? | 2009-09-18 | 2010-06-04 |  |  | 2009-09-18 | 2010-06-04 | 186d? | 335d | finish no earlier than 2010-06-04 | R2,R1,R3,R4 | 1488h |  | FS_NIMTC_RAN | PCG-23 | Huawei | Rel-10 | RP-45 | Joern |  |  | RP-091087 |
| 132 | 76 | Study on GERAN improvements for Machine-Type Communications |  | 206d? | 2009-11-20 | 2010-09-03 |  |  | 2009-11-20 | 2010-09-03 | 206d? | 270d | finish no earlier than 2010-09-03 | GP | 1648h |  | FS_NIMTC_GERAN | PCG-24 | Ericsson | Rel-10 | GP-44 | Paolo |  |  |  |
| 133 | 77 | Study on Solutions for energy saving within UTRA Node B |  | 141d? | 2009-12-04 | 2010-06-18 |  |  | 2009-12-04 | 2010-06-18 | 141d? | 325d | finish no earlier than 2010-06-18 | R1,R3 | 1128h |  | FS_Energy_UMTS | PCG-24 | Vodafone | Rel-10 | RP-46 | Patrick |  |  |  |

Notes:
- 78: Triggered by FS_RAN_LTEA (Study on LTE-Advanced) 36.912, 36. 814 / Text5: Hidekazu Taoka
- 79: - / Text3: 36.101, 36.104, 36.133, 36.201, 36.211, 36.212, 36.213, 36.300, 36.306, 36.321, 36.331 / Text5: Hidekazu Taoka
- 80: - / Text3: 36.101, 36.104, 36.133, 36.141 / Text5: Hidekazu Taoka
- 81: Triggered by FS_RAN_LTEA (Study on LTE-Advanced) 36.912, 36. 814 / Text5: Mattias Wennström
- 82: - / Text3: 36.101, 36.104, 36.133, 36.201, 36.211, 36.212, 36.213, 36.300, 36.306, 36.321, 36.331 / Text5: Mattias Wennström
- 83: - / Text3: 36.101, 36.104, 36.133, 36.141 / Text5: Mattias Wennström
- 84: Triggered by FS_RAN_LTEA (Study on LTE-Advanced) 36.912, 36. 814 / Text5: Henrik Enbuske
- 85: - / Text3: 36.213, 36.300, 36.306, 36.321, 36.331 / Text5: Henrik Enbuske
- 86: Triggered by FS_RAN_LTEA (Study on LTE-Advanced) 36.912, 36. 814 / Text5: Christian Hoymann
- 87: - / Text3: 36.133, 36.201, 36.211, 36.212, 36.213, 36.300, 36.321, 36.323, 36.331 / Text5: Christian Hoymann
- 88: - / Text3: 36.133 / Text5: Christian Hoymann
- 89: -
- 90: SP#45 work stopped/abandoned / Text5: chris.friel@O2.com
- 91: SP#45 work stopped/abandoned / Text3: 22.011 / Text5: chris.friel@O2.com
- 92: SP#45 work stopped/abandoned / Text3: 36.300 / Text5: chris.friel@O2.com
- 93: SP#35 Stage 1 completed. SP#45 Stage 2 work stopped. SP#46 work stopped/abandoned / Text3: WID identifies also impacted CT1 24.008, RAN2 25.331 / Text5: tanakai@nttdocomo.co.jp
- 94: SP#35 completed. SP#46 work stopped/abandoned / Text3: 22.101 CR#0207 / Text5: takakurat@s1.nttdocomo.co.jp
- 95: SP#45 Stage 2 work stopped / Text3: draft TR 23.880 withdrawn, 23.002, 23.060, 23.221, 23.236 / Text5: tanakai@nttdocomo.co.jp
- 96: SP#45 work stopped/abandoned / Text5: chris.friel@O2.com
- 97: SP#45 work stopped/abandoned / Text3: 22.011 / Text5: chris.friel@O2.com
- 98: SP#45 work stopped/abandoned / Text3: 36.300 / Text5: chris.friel@O2.com
- 99: SP#47 deleted (SA2 work moved under SA1 UID_450053). SP#44 Umbrella Feature created to host WIs moved out of Rel-9 (SA2 UID_420034 on IMS aspects of Architecture for Home NodeB) / Text5: Nicolas Drevon
- 100: -
- 101: SP#47 completed. TR 22.813-100 for Approval / Text3: 22.813 / Text5: tim.haysom@orange-ftgroup.com
- 102: SP#47 completed. TR 22.813-100 for Approval / Text3: 22.813 / Text5: tim.haysom@orange-ftgroup.com
- 103: SP#47 completed. TR 22.813-100 for Approval / Text3: 22.813 / Text5: stefan.bruhn@ericson.com
- 104: SP#46 completed. Linked to Rel-8 Feature UID_380060 IP Interconnection of Services (IPinterc) / Text3: 22.893 / Text5: chris.friel@O2.com
- 105: SP#44/45/46 stagnating at 20% / Text3: 22.984 / Text5: Juergen Merkel
- 106: SP#45 TR 22.947 for Information / Text3: 22.947 / Text5: Jaihyung Cho
- 107: SP#44 TR 22.913 for Information / Text3: 22.913 / Text5: Donghee Shim
- 108: SP#46 TR 22.987 for Information. Covers Mobile/Fixed/Cordless/etc terminals. Haptic (human-machine tactile communication) extend service offering & richness of user experience beyond current visual & auditory senses / Text3: 22.987 / Text5: Jinhan Song
- 109: Linked to OMA work? / Text3: 22.8xy / Text5: Li Gang (ligangyf@chinamobile.com)
- 110: SP#46 completed. Spin-off Feature UID_460028 Optimal Media Routeing (OMR). Linked to Study on Multimedia Session Continuity UID_350051, Study on Centralized IMS Service Control UID_330012, IMS inter-operator service interconnection interface UID_360011 / Text3: 23.894 / Text5: mario.madella@telecomitalia.it, victor.kueh@bt.com
- 111: SP#45 TR 23.823 for Information. Completion 12/09=>03/10. Linked to 23.236 / Text3: 23.823 / Text5: LIU HONG (liuhongyfw@chinamobile.com)
- 112: - / Text3: 23.812 / Text5: Li Gang (ligangyf@chinamobile.com), Yu Qing (yuqing@chinamobile.com)
- 113: SP#46 updated WID SP-080559=>SP-090809 (extended scope to include the IMS AGW) / Text3: 23.848 / Text5: Rajat Ghai (rghai@starentnetworks.com)
- 114: SP#45 completion 09/09=>03/10 (SA1 completed). Spin-off UID_430035 MAPCON and UID_450041 IFOM / Text3: 23.861 / Text5: Gerardo Giaretta (gerardog@qualcomm.com)
- 115: SP#46 updated WID SP-090361=>SP-090805. Study an evolved policy solution through enhancement of 3GPP policy framework (Stage 2). Consider aspects such as DPI, traffic steering, enhancing service policies / Text3: 23.813 / Text5: farooq.bari@att.com
- 116: Study how to migrate from IPv4 to IPv6-only with the help of transition mechanisms defined in IETF, and how to handle scenarios where not all services are provided via IPv6. Some of these solutions may have impacts on 3GPP network elements and terminals. / Text3: 23.975 / Text5: Li Lianyuan (lilianyuan@chinamobile.com), Liu Hong (liuhongyfw@chinamobile.com)
- 117: SP#45 completion 03/10=>09/10. Analyze current performance of SR-VCC solution in Rel-8 from E-UTRAN/HSPA to UTRAN/GERAN, and then evaluate additional mechanisms to improve user experience. Study if SR-VCC performance needs to be enhanced. / Text3: 23.856 / Text5: Hou zhiqiang (houzhiqiang@chinamobile.com), Jiang Yi (jiangyi@chinamobile.com)
- 118: Study on "reverse direction" from UTRAN/GERAN to E-UTRAN/HSPA (Rel-8 SRVCC was in the other direction E-UTRAN/HSPA to GERAN/UTRAN) / Text3: 23.885 / Text5: delphin.barankanira@orange-ftgroup.com
- 119: SP#44 SID updated SP-070782=>SP-090283 (removed UTRAN/E-UTRAN IRAT signalling cases from Study scope (while IRAT handling is left as specified by 33.401). Study also focuses on support for a key hierarchy locally in UTRAN and intra-UTRAN mobility cases.) / Text3: 33.8xy / Text5: Karl Norrman
- 120: SP#47 moved to Rel-10. TR 26.950-100 for Information. Work to extend Rel-8 UID_34043 PSS_MBMS_OMTV (Extending PSS and MBMS User Services for optimized Mobile TV) / Text3: 26.950 / Text5: jan.plogsties@iis.franhofer.de
- 121: SP#44 for SA Information / Text3: 32.825 / Text5: shan.mingjun@huawei.com
- 122: Study result might impact Feature UID_420011 Self Organising Networks (SON) / Text3: 32.826 / Text5: Jean-Michel Cornilly (Orange)
- 123: Study the missing Itf-N part in the Framework. Study changes to Itf-N to utilize UE based measurements / Text3: 32.827 / Text5: Yizhi Yao (yzyao@motorola.com)
- 124: Study grouping the investigation of various minor EPC charging enhancements / Text3: It has to be decided whether it will be a new TR or Rel-10 CRs on TR 32.820 / Text5: Gerald.Goermer@nsn.com
- 125: - / Text3: 32.8xy / Text5: Olaf Pollakowski
- 126: - / Text3: 32.8xy / Text5: Olaf Pollakowski, Padma Sudarsan
- 127: CP#46 completion 03/10=>06/10. WID updated CP-090588=>CP-090861 / Text3: 29.816 / Text5: gottfried.punz@nw.neclab.eu
- 128: RP#46 completion 12/09=>06/10 / Text3: TR (25/36) / Text5: soonleh.ling@vodafone.com
- 129: RP#46 completion 12/09=>06/10 / Text3: TR xx.yyy / Text5: Christian Bergljung (christian.bergljung@stericsson.com)
- 130: - / Text3: 25.8xx / Text5: Heechoon Lee (heechoon@qualcomm.com)
- 131: Triggered by UID_7027 Study on Facilitating Machine to Machine Communication in GSM and UMTS (M2M) TR 22.868 and Rel-10 UID_410030 Network Improvements for Machine-Type Communications (NIMTC) / Text3: 37.868 / Text5: arnaud.meylan@huawei.com
- 132: SA1 TS 22.36 (Stage 1) to be approved before GERAN work starts / Text3: 45.8/9xy / Text5: Paul Schliwa-Bertling
- 133: Linked to SA5 Rel-9 UID_430044 TR 32.826 (Study on Telecommunication Management; Energy Savings Management) / Text3: 25.927 / Text5: Prakash Bhat

| ID | WBS | Task | Duration | Start | Finish | Complete | Remaining | Baseline start | Baseline finish | Baseline duration | Total slack | Constraint | Resources | Work | Actual work | Text1 | Text2 | Text6 | Text7 | Text8 | Text4 | Text5 | Text11 |
| --- | --- | --- | --- | --- | --- | --- | --- | --- | --- | --- | --- | --- | --- | --- | --- | --- | --- | --- | --- | --- | --- | --- | --- |
| 134 | 78 | **LCS for LTE and EPS** | 468d? | 2008-06-05 A | 2010-03-19 | 73% | 126.9d? | 2008-06-05 | 2010-03-19 | 468d? | 390d |  | S2,C1,C4,R2,R1,R3,R4 | 17832h | 13316.8h | LCS_LTE_EPS | PCG-22 | Rel-9 | SP-43 | Maurice |  |  |  |
| 135 | 78.1 | **LCS Control Plane Solution for EPS** | 468d? | 2008-06-05 A | 2010-03-19 | 81% | 86.9d? | 2008-06-05 | 2010-03-19 | 468d? | 390d |  | S2,C4,C1 | 9224h | 7511.16h | LCS_EPS-CPS | PCG-21 | Rel-9 | SP-40 | Maurice | Polaris Wireless | Robert Gross |  |
| 136 | 78.1.1 | Stage 2 for LCS_CPS_EPS | 261d? | 2008-06-05 A | 2009-06-04 A | 100% |  | 2008-06-05 | 2009-06-04 | 261d? |  | finish no earlier than 2009-06-04 | S2 | 2088h | 2088h | LCS_EPS-CPS | PCG-21 | Rel-9 | SP-40 | Maurice | Polaris Wireless | Robert Gross |  |
| 137 | 78.1.2 | CT4 aspects - Control Plane LCS in the EPC | 212d? | 2009-05-29 A | 2010-03-19 | 80% | 42.4d? | 2009-05-29 | 2010-03-19 | 212d? | 390d | finish no earlier than 2010-03-19 | C4 | 1696h | 1356.8h | LCS_EPS-CPS | PCG-23 | Rel-9 | CP-44 | Kimmo | Polaris Wireless | Robert Gross | CP-090808 |
| 138 | 78.1.3 | CT1 aspects - Control Plane LCS in the EPC | 212d? | 2009-05-29 A | 2010-03-19 | 60% | 84.8d? | 2009-05-29 | 2010-03-19 | 212d? | 390d | finish no earlier than 2010-03-19 | C1 | 1696h | 1017.6h | LCS_EPS-CPS | PCG-23 | Rel-9 | CP-44 | Frederic | Polaris Wireless | Robert Gross | CP-090876 |
| 139 | 78.2 | Positioning Support for LTE | 337d? | 2008-12-05 A | 2010-03-19 | 90% | 33.7d? | 2008-12-05 | 2010-03-19 | 337d? | 390d | finish no earlier than 2010-03-19 | R2,R1,R3,R4 | 2696h | 2426.4h | LCS_LTE | PCG-22 | Rel-9 | RP-42 | Joern | Qualcomm Europe | Nathan Tenny (ntenny@qualcomm.com) | RP-091042 |
| 140 | 78.3 | Network-Based Positioning Support in LTE | 271d? | 2009-03-09 A | 2010-03-19 | 30% | 189.7d? | 2009-03-09 | 2010-03-19 | 271d? | 390d | finish no earlier than 2010-03-19 | R2,R3,R4 | 2168h | 650.4h | LCS_LTE-NBPS | PCG-22 | Rel-9 | RP-43 | Joern | TruePosition | terri.brooks@trueposition.com | RP-091043 |
| 141 | 79 | **MBMS support in EPS** | 468d? | 2008-06-05 A | 2010-03-19 | 99% | 5d? | 2008-06-05 | 2010-03-19 | 468d? | 390d |  | S2,S3,S5,C3,C4,R2,R3,R4 | 13880h | 13731.6h | MBMS_EPS | PCG-21 | Rel-9 | SP-40 | Maurice | China Mobile | Liu Hong (liuhongyfw@chinamobile.com) |  |
| 142 | 79.1 | Stage 2 for MBMS_EPS | 261d? | 2008-06-05 A | 2009-06-04 A | 100% |  | 2008-06-05 | 2009-06-04 | 261d? |  | finish no earlier than 2009-06-04 | S2 | 2088h | 2088h | MBMS_EPS | PCG-21 | Rel-9 | SP-40 | Maurice | China Mobile | Liu Hong (liuhongyfw@chinamobile.com) |  |
| 143 | 79.2 | Security for MBMS_EPS | 261d? | 2008-12-11 A | 2009-12-10 A | 100% |  | 2008-12-11 | 2009-12-10 | 261d? |  | finish no earlier than 2009-12-10 | S3 | 2088h | 2088h | MBMS_EPS | PCG-22 | Rel-9 | SP-42 | Dionisio | China Mobile | Liu Hong (liuhongyfw@chinamobile.com) |  |
| 144 | 79.3 | MBMS Charging in EPS | 201d? | 2009-03-06 A | 2009-12-10 A | 100% |  | 2009-03-06 | 2009-12-10 | 201d? |  | finish no earlier than 2009-12-10 | S5 | 1600h | 1600h | MBMS_EPS | PCG-22 | Rel-9 | SP-43 | Dionisio | ZTE | guo.wenjie1@zte.com.cn |  |
| 145 | 79.4 | CT4 aspects of MBMS support in EPS (Stage 3) | 137d? | 2009-05-29 A | 2009-12-04 A | 100% |  | 2009-05-29 | 2009-12-04 | 137d? |  | finish no earlier than 2009-12-04 | C4 | 1096h | 1096h | MBMS_EPS | PCG-23 | Rel-9 | CP-44 | Kimmo | China Mobile, ZTE | wangjingyf@chinamobile.com, lu.fei1@zte.com.cn |  |
| 146 | 79.5 | CT3 aspects of MBMS support in EPS (Stage 3) | 137d? | 2009-05-29 A | 2009-12-04 A | 100% |  | 2009-05-29 | 2009-12-04 | 137d? |  | start no earlier than 2009-05-29 | C3 | 1096h | 1096h | MBMS_EPS | PCG-23 | Rel-9 | CP-44 | Gwiho | ZTE, China Mobile | zhou.xiaoyun@zte.com.cn, wangjingyf@chinamobile.com |  |
| 147 | 79.6 | MBMS support in LTE | 271d? | 2009-03-06 A | 2010-03-19 | 95% | 13.55d? | 2009-03-06 | 2010-03-19 | 271d? | 390d | finish no earlier than 2010-03-19 | R2,R3,R4 | 2168h | 2059.6h | MBMS_LTE | PCG-22 | Rel-9 | RP-43 | Joern | Huawei | arnaud.meylan@huawei.com | RP-091044 |
| 148 | 80 | **Access Network Discovery and Selection Function enhancements** | 333d? | 2008-12-11 A | 2010-03-19 | 85% | 50.92d? | 2008-12-11 | 2010-03-19 | 333d? | 390d |  | S2,C1 | 4720h | 2757.6h | eANDSF | PCG-22 | Rel-9 | SP-42 | Maurice | Motorola | Apostolis Salkintzis (salki@motorola.com) |  |
| 149 | 80.1 | Stage 2 for eANDSF | 126d? | 2008-12-11 A | 2009-06-04 A | 100% |  | 2008-12-11 | 2009-06-04 | 126d? |  | finish no earlier than 2009-06-04 | S2 | 1008h | 1008h | eANDSF | PCG-22 | Rel-9 | SP-42 | Maurice | Motorola | Apostolis Salkintzis (salki@motorola.com) |  |
| 150 | 80.2 | CT1 aspects - eANDSF | 131d? | 2009-09-18 A | 2010-03-19 | 70% | 39.3d? | 2009-09-18 | 2010-03-19 | 131d? | 390d | finish no earlier than 2010-03-19 | C1 | 1048h | 733.6h | eANDSF | PCG-23 | Rel-9 | CP-45 | Frederic | Panasonic | benjamin.limck@sg.panasonic.com | CP-090869 |
| 151 | 81 | **Multiple PDN Connection to the Same APN for PMIP-based Interfaces** | 267d? | 2009-03-13 A | 2010-03-19 | 95% | 14.1d? | 2009-03-13 | 2010-03-19 | 267d? | 390d |  | S2,C4,C1 | 4120h | 2367.2h | MUPSAP | PCG-22 | Rel-9 | SP-43 | Maurice | Samsung | erik.guttman@partner.samsung.com |  |
| 152 | 81.1 | Stage 2 for MUPSAP | 61d? | 2009-03-13 A | 2009-06-04 A | 100% |  | 2009-03-13 | 2009-06-04 | 61d? |  | finish no earlier than 2009-06-04 | S2 | 488h | 488h | MUPSAP | PCG-22 | Rel-9 | SP-43 | Maurice | Samsung | erik.guttman@partner.samsung.com |  |
| 153 | 81.2 | MUPSAP - CT4 aspects | 56d? | 2009-09-18 A | 2009-12-04 A | 100% |  | 2009-09-18 | 2009-12-04 | 56d? |  | finish no earlier than 2009-12-04 | C4 | 448h | 448h | MUPSAP | PCG-23 | Rel-9 | CP-45 | Kimmo | Samsung | Surjyakanta Mohapatra (surjya.kanta@samsung.com) |  |
| 154 | 81.3 | MUPSAP - CT1 aspects | 131d? | 2009-09-18 A | 2010-03-19 | 90% | 13.1d? | 2009-09-18 | 2010-03-19 | 131d? | 390d | finish no earlier than 2010-03-19 | C1 | 1048h | 943.2h | MUPSAP | PCG-23 | Rel-9 | CP-45 | Frederic | Samsung | Surjyakanta Mohapatra (surjya.kanta@samsung.com) | CP-090878 |
| 155 | 82 | Access Security Enhancements | 505d? | 2007-07-02 A | 2009-06-04 A | 100% |  | 2007-07-02 | 2009-06-04 | 505d? |  | finish no earlier than 2009-06-03 | S3 | 4040h | 4040h | ACCSEC2 |  | Rel-9 | SP-26 | Dionisio | Ericsson | Bengt.Sahlin@ericsson.com |  |
| 156 | 83 | **IMS Media Plane Security** | 271d? | 2009-03-13 A | 2010-03-25 | 52% | 130.97d? | 2009-03-13 | 2010-03-25 | 271d? | 386d |  | S3,C1,C4,C3 | 6467.2h | 2118.21h | MEDIASEC | PCG-22 | Rel-9 | SP-43 | Dionisio | Vodafone | Peter.Howard@vodafone.com |  |
| 157 | 83.1 | SA3 aspects - MEDIASEC | 271d? | 2009-03-13 A | 2010-03-25 | 95% | 13.55d? | 2009-03-13 | 2010-03-25 | 271d? | 386d | finish no earlier than 2010-03-25 | S3 | 2168h | 2059.6h | MEDIASEC | PCG-22 | Rel-9 | SP-43 | Dionisio | Vodafone | Peter.Howard@vodafone.com |  |

Notes:
- 134: -
- 135: Triggered by abandoned Study UID_380068 (FS_LCS_EPS). Linked to UID_380064 Feature IMS_EMER_GPRS_EPS.
- 136: SP#44 completed (Some alignments might be needed later on based on RAN progress) / Text3: 23.891, 23.271, 23.401, 23.402
- 137: CP#46 exception to 03/10 in CP-090808. WID updated CP-090518=>CP-090811. Stage 3 SLs and SLg interfaces & transport of positioning messages between E-SMLC and MME in the scope of UID_420006 (Positioning Support for LTE) / Text3: 24.080, 29.002 new 24.171, 29.171, 29.172, 29.173
- 138: CP#46 exception to 03/10 in CP-090876 / Text3: 24.301
- 139: RP#46 exception to 03/10 in RP-091390. WID updated RP-080995=>RP-091389. UID_400038 (LCS Control Plane Solution for EPS) depends on this WI / Text3: 34.213, 36.133, 36.171, 36.211, 36.214, 36.300, 36.305, 36.331, 36.355, 36.410, 36.413, 36.455
- 140: RP#46 exception to 03/10 in RP-091391 / Text3: 36.300, 36.331, 36.355, 36.413, new R4 36.xxx (Performance Requirements for LMU)
- 141: SP#42 WID updated SP-080442=>SP-080737 (add SA3 task)
- 142: SP#44 completed / Text3: 23.246
- 143: SP#46 completed / Text3: 33.246
- 144: SP#46 completed / Text3: 32.273, 32.251, 32.298, 32.299
- 145: CP#46 completed / Text3: 29.274, 29.281, 23.007, 23.008
- 146: CP#46 completed / Text3: 29.061
- 147: RP#46 exception to 03/10 in RP-091221. WID updated RP-090619=>RP-091457 / Text3: 25.446, 36.101, 36.104, 36.141, 36.300, 36.304, 36.321, 36.322, 36.323, 36.331, 36.440, 36.441, 36.442, 36.444, 36.445
- 148: SP#44 Stage 2 completed. No new Rel-9 use cases defined. Implement service requirements not covered in Rel-8 / Text3: 22.278, SA3 33.402 CR#0055
- 149: SP#44 completed / Text3: 23.402, 23.002
- 150: CP#46 exception to 03/10 in CP-090869 / Text3: 24.302, 24.312
- 151: SP#44 Stage 2 completed. Continues Rel-8 SAES Stage 2 UID_320005. Stage 1 in 22.278 (EPS Service requirements)
- 152: SP#44 completed / Text3: 23.060, 23.203, 23.401, 23.402
- 153: CP#46 completed / Text3: 29.275, 23.008, 29.282
- 154: CP#46 exception to 03/10 in CP-090878 / Text3: 24.302
- 155: SP#44 completed. Stopped TR 33.801. CRs 33.102,43.020 on A5/2 removal done long time ago. A5/4 introduction CRs will be done under UID_440057 128 bit encryption for GSM and GPRS. SP#26 approved WID (improved GERAN security) / Text3: 33.102, 43.020, Stopped TR 33.801 “Access security review” (Reason: draft contained useful material for planning A5/2 removal and A5/4 introduction. Completion would require significant effort)
- 156: CP#46 Stage 3 exception to 03/10
- 157: SP#46 completion 12/09=>03/10. TR 33.828 3rd time for Information. TS 33.328 for Approval / Text3: new 33.828, 33.328

| ID | WBS | Task | Duration | Start | Finish | Complete | Remaining | Baseline start | Baseline finish | Baseline duration | Total slack | Constraint | Resources | Work | Actual work | Text1 | Text2 | Text4 | Text5 | Text6 | Text7 | Text8 | Text11 | Text9 | Text12 |
| --- | --- | --- | --- | --- | --- | --- | --- | --- | --- | --- | --- | --- | --- | --- | --- | --- | --- | --- | --- | --- | --- | --- | --- | --- | --- |
| 158 | 83.2 | **CN aspects of IMS Media Plane Security** | 131d? | 2009-09-18 A | 2010-03-19 | 3% | 127.4d? | 2009-09-18 | 2010-03-19 | 131d? | 390d |  | C1,C4,C3 | 2131.2h | 58.61h | MEDIASEC_CORE | PCG-23 | Vodafone | peter.dawes@vodafone.com | Rel-9 | CP-45 | Frederic | CP-090877 |  |  |
| 159 | 83.2.1 | CT1 aspects - MEDIASEC | 33d? | 2009-09-18 A | 2010-03-19 | 20% | 26.4d? | 2009-09-18 | 2010-03-19 | 33d? | 390d | finish no earlier than 2010-03-19 | C1 | 264h | 52.8h | MEDIASEC_CORE | PCG-23 | Vodafone | peter.dawes@vodafone.com | Rel-9 | CP-45 | Frederic | CP-090877 |  |  |
| 160 | 83.2.2 | CT4 aspects - MEDIASEC | 131d? | 2009-09-18 | 2010-03-19 |  |  | 2009-09-18 | 2010-03-19 | 131d? | 390d | finish no earlier than 2010-03-19 | C4 | 1048h |  | MEDIASEC_CORE | PCG-23 | Vodafone | peter.dawes@vodafone.com | Rel-9 | CP-45 | Kimmo | CP-090809 |  |  |
| 161 | 83.2.3 | CT3 aspects - MEDIASEC | 76d? | 2009-12-04 | 2010-03-19 |  |  | 2009-12-04 | 2010-03-19 | 76d? | 390d | finish no earlier than 2010-03-19 | C3 | 608h |  | MEDIASEC_CORE | PCG-24 | Vodafone | peter.dawes@vodafone.com | Rel-9 | CP-46 |  | CP-091022 |  |  |
| 162 | 84 | **GBAPush enhancements (Generic push layer)** | 533d? | 2008-03-12 A | 2010-03-25 | 85% | 79.95d? | 2008-03-12 | 2010-03-25 | 533d? | 386d |  | S3 | 8528h | 7248.8h | eGBAPush | PCG-23 | Ericsson | Rolf Blom | Rel-9 | SP-44 | Dionisio |  |  |  |
| 163 | 84.1 | SA3 part of eGBAPush (Generic push layer) | 533d? | 2008-03-12 A | 2010-03-25 | 85% | 79.95d? | 2008-03-12 | 2010-03-25 | 533d? | 386d | finish no earlier than 2010-03-25 | S3 | 4264h | 3624.4h | eGBAPush | PCG-21 | Ericsson | Rolf Blom | Rel-9 | SP-39 | Dionisio |  |  |  |
| 164 | 85 | Extended Identity Management | 136d? | 2009-06-04 A | 2009-12-10 A | 100% |  | 2009-06-04 | 2009-12-10 | 136d? |  | finish no earlier than 2009-12-10 | S3 | 1088h | 1088h | GBA-IdM | PCG-23 | Nokia | Silke.Holtmanns at nokia.com | Rel-9 | SP-44 | Dionisio |  |  |  |
| 165 | 86 | **Network Domain Security (NDS) enhancements to support backhaul security** | 211d? | 2009-06-04 A | 2010-03-25 | 57% | 90.86d? | 2009-06-04 | 2010-03-25 | 211d? | 386d |  | S3,C4 | 4432h | 2523.53h | NDS_Backhaul | PCG-23 | Vodafone | Peter Howard | Rel-9 | SP-44 | Dionisio |  |  |  |
| 166 | 86.1 | SA3 part of NDS_Backhaul | 211d? | 2009-06-04 A | 2010-03-25 | 30% | 147.7d? | 2009-06-04 | 2010-03-25 | 211d? | 386d | finish no earlier than 2010-03-25 | S3 | 1688h | 506.4h | NDS_Backhaul | PCG-23 | Vodafone | Peter Howard | Rel-9 | SP-44 | Dionisio | SP-090834 |  |  |
| 167 | 86.2 | CT4 part of NDS_Backhaul | 132d? | 2009-06-04 A | 2009-12-04 A | 100% |  | 2009-06-04 | 2009-12-04 | 132d? |  | finish no earlier than 2009-12-04 | C4 | 1056h | 1056h | NDS_Backhaul | PCG-23 | Vodafone | Peter Howard | Rel-9 | SP-44 | Kimmo |  |  |  |
| 168 | 87 | **128 bit encryption for GSM and GPRS** | 136d? | 2009-06-04 A | 2009-12-10 A | 100% |  | 2009-06-04 | 2009-12-10 | 136d? |  |  | S3,C1,C4,G2,G3new | 6040h | 6040h | A5/4-GEA4 | PCG-23 | Ericsson | Karl Norrman | Rel-9 | SP-44 | Dionisio |  |  |  |
| 169 | 87.1 | SA3 part of A5/4-GEA4 | 136d? | 2009-06-04 A | 2009-12-10 A | 100% |  | 2009-06-04 | 2009-12-10 | 136d? |  | finish no earlier than 2010-01-06 | S3 | 1088h | 1088h | A5/4-GEA4 | PCG-23 | Ericsson | Karl Norrman | Rel-9 | SP-44 | Dionisio |  |  |  |
| 170 | 87.2 | CT1 part of A5/4-GEA4 | 77d? | 2009-06-04 A | 2009-09-18 A | 100% |  | 2009-06-04 | 2009-09-18 | 77d? |  | start no earlier than 2009-06-04 | C1 | 616h | 616h | A5/4-GEA4 | PCG-23 | Ericsson | Karl Norrman | Rel-9 | SP-44 | Frederic |  |  |  |
| 171 | 87.3 | CT4 part of A5/4-GEA4 | 136d? | 2009-06-04 A | 2009-12-10 A | 100% |  | 2009-06-04 | 2009-12-10 | 136d? |  | start no earlier than 2009-06-04 | C4 | 1088h | 1088h | A5/4-GEA4 | PCG-23 | Ericsson | Karl Norrman | Rel-9 | SP-44 | Kimmo |  |  |  |
| 172 | 87.4 | GERAN2 part of A5/4-GEA4 | 67d? | 2009-06-04 A | 2009-09-04 A | 100% |  | 2009-06-04 | 2009-09-04 | 67d? |  | finish no earlier than 2009-09-04 | G2 | 536h | 536h | A5/4-GEA4 | PCG-23 | Ericsson | Karl Norrman | Rel-9 | SP-44 | Gert |  |  |  |
| 173 | 87.5 | GERAN3new (testing) part of A5/4-GEA4 | 122d? | 2009-06-04 A | 2009-11-20 A | 100% |  | 2009-06-04 | 2009-11-20 | 122d? |  | finish no earlier than 2009-11-20 | G3new | 976h | 976h | A5/4-GEA4 | PCG-23 | Ericsson | Karl Norrman | Rel-9 | SP-44 | Ingbert |  |  |  |
| 174 | 87.6 | Deleted - SA2 part of A5/4-GEA4 | 81d? | 2009-06-04 A | 2009-09-24 A | 100% |  | 2009-06-04 | 2009-09-24 | 81d? |  | finish no earlier than 2009-09-24 | S2 | 648h | 648h | A5/4-GEA4 | PCG-23 | Ericsson | Karl Norrman | Rel-9 | SP-44 | Maurice |  | PCG-23 | SP-45 |
| 175 | 88 | Lawful Interception in the 3GPP Rel-9 | 211d? | 2009-06-04 A | 2010-03-25 | 30% | 147.7d? | 2009-06-04 | 2010-03-25 | 211d? | 386d | finish no earlier than 2010-03-25 | S3 | 1688h | 506.4h | LI9 | PCG-23 | PIDS, Nortel | Koen Jaspers, Ronald Ryan | Rel-9 | SP-44 | Dionisio | SP-090833 |  |  |
| 176 | 89 | Timed Graphics | 337d? | 2008-12-11 A | 2010-03-25 A | 100% |  | 2008-12-11 | 2010-03-25 | 337d? |  | finish no earlier than 2010-03-25 | S4 | 2696h | 2696h | TG | PCG-22 | Ericsson | clinton.priddle@ericsson.com | Rel-9 | SP-42 | Paolo |  |  |  |
| 177 | 90 | Managing MTSI Media Adaptation | 272d? | 2009-03-12 A | 2010-03-25 A | 100% |  | 2009-03-12 | 2010-03-25 | 272d? |  | finish no earlier than 2009-12-10 | S4 | 1568h | 1568h | M3A | PCG-22 | Samsung | kyunghun.jung@samsung.com | Rel-9 | SP-43 | Paolo |  |  |  |
| 178 | 91 | **PSS and MBMS Aspects** | 272d? | 2009-03-12 A | 2010-03-25 A | 100% |  | 2009-03-12 | 2010-03-25 | 272d? |  |  | S4 | 6512h | 6512h | PMA | PCG-23 | Ericsson, Nokia | Clinton.Priddle@ericsson.com, imed.bouazizi@nokia.com | Rel-9 | SP-44 | Paolo |  |  |  |
| 179 | 91.1 | PSS and MBMS extensions | 271d? | 2009-03-12 A | 2010-03-25 A | 100% |  | 2009-03-12 | 2010-03-25 | 271d? |  | finish no earlier than 2010-03-25 | S4 | 2168h | 2168h | PMA-MBS_Ext | PCG-22 | Ericsson | Clinton.Priddle@ericsson.com | Rel-9 | SP-43 | Paolo |  |  |  |
| 180 | 91.2 | Improved Video Support for PSS and MBMS | 271d? | 2009-03-12 A | 2010-03-25 A | 100% |  | 2009-03-12 | 2010-03-25 | 271d? |  | finish no earlier than 2010-03-25 | S4 | 2168h | 2168h | PMA-IVS | PCG-22 | Nokia | imed.bouazizi@nokia.com | Rel-9 | SP-43 | Paolo |  |  |  |
| 181 | 92 | IMS based PSS and MBMS User Service extensions | 197d? | 2009-03-12 A | 2009-12-10 A | 100% |  | 2009-03-12 | 2009-12-10 | 197d? |  | finish no earlier than 2009-12-10 | S4 | 1576h | 1576h | IMS_PSS_MBMS_US_EXT | PCG-22 | Ericsson | Markus Kampmann | Rel-9 | SP-43 | Paolo |  |  |  |
| 182 | 93 | Syndicated Feed Reception within 3GPP environments | 136d? | 2009-06-04 A | 2009-12-10 A | 100% |  | 2009-06-04 | 2009-12-10 | 136d? |  | start no earlier than 2009-06-04 | S4 | 1088h | 1088h | SFR | PCG-23 | Ericsson | Thorsten.Lohmar@ericsson.com | Rel-9 | SP-44 | Paolo |  |  |  |
| 183 | 94 | Distortion Measurement Test Methods and Requirements | 131d? | 2009-09-24 A | 2010-03-25 A | 100% |  | 2009-09-24 | 2010-03-25 | 131d? |  | finish no earlier than 2010-03-25 | S4 | 1048h | 1048h | DTMR | PCG-23 | Motorola | Stephen Kendall (wcsk01@motorola.com) | Rel-9 | SP-45 | Paolo |  |  |  |

Notes:
- 158: CP#46 exception to 03/10. WID updated CP-090740=>CP-090884
- 159: CP#46 exception to 03/10 in CP-090877 / Text3: 23.218, 24.229
- 160: CP#46 exception to 03/10 in CP-090809 / Text3: 29.238, 23.334, 29.334
- 161: CP#46 exception to 03/10 in CP-091022 / Text3: 29.162
- 162: SP#43 Umbrella Feature created to host 33.224, moved from Rel-8 to Rel-9 (Develop a generic push layer using GAA protection)
- 163: SP#46 completion 12/09=>03/10. SP#45 TS 33.224 for Approval / Text3: 33.224
- 164: SP#46 completed. TR 33.924 (Stage 2) for Approval. Stage 1 not identified: GBA Liberty Interworking has been outlined and GBAOpenID interworking is analogous / Text3: new 33.924, CP#45 CT4 completed (Added service code in 29.109)
- 165: SP#46 further Stage 2 exception to 03/10 (was 12/09). Continuation of Rel-8 UID_390044 SAE security architecture. Covers gaps in backhaul security in SAE (also applicable to UTRAN and GERAN backhaul)
- 166: SP#46 further Stage 2 exception to 03/10 (was 12/09) in SP-090834. [Identity Management and 3GPP Security Interworking (Interworking of GAA and OpenID)] / Text3: 33.102, 33.210, 33.310, 33.401, 33.402
- 167: CP#46 completed. No impact on CT4 specs
- 168: Allow 128 as an alternative to 64 bit keys (Stage 2/3 + Test spec)
- 169: SP#46 completed. SP#45 TS 55.226v100 for Information+Approval / Text3: 33.102,43.020, new 55.226
- 170: CP#45 completed / Text3: 24.008,44.064
- 171: CP#46 completed. Kc128 enhancements are carried as UMTS keys => no CT4 impact / Text3: 29.002, 29.060
- 172: GP#43 WID approved + completed / Text3: 44.018,48.008,48.018,48.058
- 173: GP#44 completed. GP#43 WID approved / Text3: 51.010
- 174: SP#45 work stopped/abandoned / Text3: 23.060
- 175: SP#46 further Stage 2 exception to 03/10 (was 12/09) in SP-090833. WID updated SP-090532=>SP-090831 / Text3: 33.106 (LI requirements), 33.107 (LI architecture and functions), 33.108 (Handover interface for LI)
- 176: SP#47 completed. Provide graphics in parallel to a video stream (without requiring an umbrella scene descriptor such as 3GPP DIMS in TS 26.142) / Text3: 26.114, 26.140, 26.234, 26.244, 26.245, 26.346, new 26.430
- 177: SP#46 completed. Work extending Rel-8 UID_34041 MTSI Video - Dynamic Rate Adaptation/Signalling of Image Size. Update speech/video adaptation algorithms used by network to control MTSI client terminal in congestion or poor transmission conditions. / Text3: 26.114
- 178: Umbrella WI. SP#47 completed
- 179: SP#47 completed. Extends Rel-8 UID_34043 (PSS_MBMS_OMTV) & ensures compatibility with UID_34046 (IMS_PSS_MBMS_US) / Text3: 26.234, 26.346
- 180: SP#47 completed / Text3: 26.234, 26.244, 26.346, new 26.903
- 181: SP#46 completed. Work extending Rel-8 UID_34046 (IMS_PSS_MBMS_US), SA2 UID_410034 IMSSCC-SPI (IMS Service Continuity Enhancements: Service, Policy and Interactions) / Text3: 26.237
- 182: SP#46 completed. TS 26.150v100 for Approval. RSS optimized for mobile use. Reuse/reference OMA's enabler DCD. / Text3: 26.150
- 183: SP#47 completed / Text3: 26.131, 26.132

| ID | WBS | Task | Duration | Start | Finish | Complete | Remaining | Baseline start | Baseline finish | Baseline duration | Total slack | Constraint | Resources | Work | Actual work | Text1 | Text2 | Text6 | Text7 | Text8 | Text4 | Text11 | Text9 | Text12 |
| --- | --- | --- | --- | --- | --- | --- | --- | --- | --- | --- | --- | --- | --- | --- | --- | --- | --- | --- | --- | --- | --- | --- | --- | --- |
| 184 | 95 | **OAM&P 9** | 546d? | 2008-02-22 A | 2010-03-25 | 60% | 216.47d? | 2008-02-22 | 2010-03-25 | 546d? | 386d |  | S5 | 33810.4h | 20486h | OAM9 | PCG-22 | Rel-9 | SP-42 | Dionisio |  |  |  |  |
| 185 | 95.1 | **Network Infrastructure Management** | 337d? | 2008-12-11 A | 2010-03-25 | 44% | 187.44d? | 2008-12-11 | 2010-03-25 | 337d? | 386d |  | S5 | 8760h | 3887.68h | OAM9-NIM | PCG-22 | Rel-9 | SP-42 | Dionisio |  |  |  |  |
| 186 | 95.1.1 | Software Management for Network Elements | 336d? | 2008-12-11 A | 2010-03-25 | 75% | 84d? | 2008-12-11 | 2010-03-25 | 336d? | 386d | finish no earlier than 2010-03-25 | S5 | 2688h | 2016h | OAM9-NE_SWM | PCG-22 | Rel-9 | SP-42 | Dionisio | Huawei, Nokia Siemens Networks | SP-090742 |  |  |
| 187 | 95.1.2 | Service Oriented Architecture (SOA) for IRP | 211d? | 2009-06-04 A | 2010-03-25 | 20% | 168.8d? | 2009-06-04 | 2010-03-25 | 211d? | 386d | finish no earlier than 2010-03-25 | S5 | 1688h | 337.6h | OAM9 | PCG-23 | Rel-9 | SP-44 | Dionisio | Ericsson, Nokia Siemens Networks | SP-090749 |  |  |
| 188 | 95.1.3 | IRP SOAP Solution Sets continuation from Rel-8 | 211d? | 2009-06-04 A | 2010-03-25 | 20% | 168.8d? | 2009-06-04 | 2010-03-25 | 211d? | 386d | finish no earlier than 2010-03-25 | S5 | 1688h | 337.6h | OAM9 | PCG-23 | Rel-9 | SP-44 | Dionisio | Ericsson | SP-090750 |  |  |
| 189 | 95.2 | **Performance Management** | 272d? | 2009-03-12 A | 2010-03-25 | 69% | 85.6d? | 2009-03-12 | 2010-03-25 | 272d? | 386d |  | S5 | 7010.41h | 4802.4h | OAM9-PM | PCG-22 | Rel-9 | SP-42 | Dionisio |  |  |  |  |
| 190 | 95.2.1 | Enhancement of E-UTRAN Performance Measurements | 272d? | 2009-03-12 A | 2010-03-25 | 30% | 190.4d? | 2009-03-12 | 2010-03-25 | 272d? | 386d | finish no earlier than 2010-03-25 | S5 | 2176h | 652.8h | OAM9 | PCG-22 | Rel-9 | SP-43 | Dionisio | Motorola, Huawei | SP-090745 |  |  |
| 191 | 95.2.2 | Enhancement of EPC Performance Measurements | 197d? | 2009-03-12 A | 2009-12-10 A | 100% |  | 2009-03-12 | 2009-12-10 | 197d? |  | finish no earlier than 2010-03-25 | S5 | 1570.41h | 1570.41h | OAM9 | PCG-22 | Rel-9 | SP-43 | Dionisio | China Mobile |  |  |  |
| 192 | 95.2.3 | Enhancement of UTRAN Performance Measurements | 136d? | 2009-06-04 A | 2009-12-10 A | 100% |  | 2009-06-04 | 2009-12-10 | 136d? |  | start no earlier than 2009-06-04 | S5 | 1088h | 1088h | OAM9 | PCG-23 | Rel-9 | SP-44 | Dionisio | China Mobile |  |  |  |
| 193 | 95.3 | Deleted - Trace | 196d? | 2009-03-13 A | 2009-12-10 A | 100% |  | 2009-03-13 | 2009-12-10 | 196d? |  | finish no earlier than 2009-12-10 | S5 | 1568h | 1568h | OAM9-Trace | PCG-22 | Rel-9 | SP-42 | Dionisio |  |  | PCG-24 | SP-46 |
| 194 | 95.4 | **Self-Organizing Networks (SON) - OAM aspects** | 546d? | 2008-02-22 A | 2010-03-25 | 68% | 174.6d? | 2008-02-22 | 2010-03-25 | 546d? | 386d |  | S5 | 10416h | 7085.22h | OAM9-SON | PCG-22 | Rel-9 | SP-43 | Dionisio |  |  |  |  |
| 195 | 95.4.1 | SON self-optimization management | 545d? | 2008-02-22 A | 2010-03-25 | 75% | 136.25d? | 2008-02-22 | 2010-03-25 | 545d? | 386d | finish no earlier than 2010-03-25 | S5 | 4360h | 3270h | LTE_SON-OAM | PCG-21 | Rel-9 | SP-39 | Dionisio | Huawei | SP-090741 |  |  |
| 196 | 95.4.2 | Automatic Radio Network Configuration Data Preparation | 211d? | 2009-06-04 A | 2010-03-25 | 50% | 105.5d? | 2009-06-04 | 2010-03-25 | 211d? | 386d | finish no earlier than 2010-03-25 | S5 | 1688h | 844h | OAM9 | PCG-23 | Rel-9 | SP-44 | Dionisio | Nokia Siemens Networks | SP-090752 |  |  |
| 197 | 95.5 | Subscription Management (SuM) evolution | 211d? | 2009-06-04 A | 2010-03-25 | 30% | 147.7d? | 2009-06-04 | 2010-03-25 | 211d? | 386d | finish no earlier than 2010-03-25 | S5 | 1688h | 506.4h | OAM9-SuM | PCG-23 | Rel-9 | SP-44 | Dionisio | Ericsson | SP-090746 |  |  |
| 198 | 96 | **Charging Management small Enhancements** | 211d? | 2009-06-04 A | 2010-03-25 | 25% | 158.25d? | 2009-06-04 | 2010-03-25 | 211d? | 386d |  | S5 | 3376h | 844h | CH9 | PCG-23 | Rel-9 | SP-44 | Dionisio |  |  |  |  |
| 199 | 96.1 | IWLAN mobility charging | 211d? | 2009-06-04 A | 2010-03-25 | 25% | 158.25d? | 2009-06-04 | 2010-03-25 | 211d? | 386d | finish no earlier than 2010-03-25 | S5 | 1688h | 422h | eIWLAN_Mob | PCG-23 | Rel-9 | SP-44 | Dionisio | Orange | SP-090755 |  |  |
| 200 | 97 | **CS-IBCF and CS-TrGW definition in 3GPP specifications** | 397d? | 2008-05-30 A | 2009-12-04 A | 100% |  | 2008-05-30 | 2009-12-04 | 397d? |  |  | C3,C4 | 9513.27h | 9513.27h | CS-IBCF | PCG-21 | Rel-9 | CP-40 | Gwiho | Telecom Italia |  |  |  |
| 201 | 97.1 | CT3 aspects of CS-IBCF | 397d? | 2008-05-30 A | 2009-12-04 A | 100% |  | 2008-05-30 | 2009-12-04 | 397d? |  | finish no earlier than 2009-12-04 | C3 | 3169.27h | 3169.27h | CS-IBCF | PCG-21 | Rel-9 | CP-40 | Gwiho | Telecom Italia |  |  |  |
| 202 | 97.2 | CT4 aspects of CS-IBCF | 396d? | 2008-05-30 A | 2009-12-04 A | 100% |  | 2008-05-30 | 2009-12-04 | 396d? |  | finish no earlier than 2009-12-04 | C4 | 3168h | 3168h | CS-IBCF | PCG-21 | Rel-9 | CP-40 | Kimmo | Telecom Italia |  |  |  |
| 203 | 98 | **IMS – Interconnection Border Control Function (IBCF) – Transition Gateway (TrGW); Ix Interface; Stage 3** | 322d? | 2008-09-12 A | 2009-12-04 A | 100% |  | 2008-09-12 | 2009-12-04 | 322d? |  |  | C4,C3 | 6858.4h | 6858.4h | IMS_IBCF | PCG-21 | Rel-9 | CP-41 | Kimmo | Alcatel-Lucent |  |  |  |
| 204 | 98.1 | CT4 part of IMS_IBCF | 321d? | 2008-09-12 A | 2009-12-04 A | 100% |  | 2008-09-12 | 2009-12-04 | 321d? |  | finish no earlier than 2009-12-04 | C4 | 2568h | 2568h | IMS_IBCF | PCG-21 | Rel-9 | CP-41 | Kimmo | Alcatel-Lucent |  |  |  |
| 205 | 98.2 | CT3 part of IMS_IBCF | 295.8d? | 2008-09-12 A | 2009-12-04 A | 100% |  | 2008-09-12 | 2009-12-04 | 295.8d? |  | finish no earlier than 2010-03-19 | C3 | 2366.4h | 2366.4h | IMS_IBCF | PCG-21 | Rel-9 | CP-41 | Gwiho | Alcatel-Lucent |  |  |  |
| 206 | 99 | IMS Application Level Gateway Control Function (ALGCF) – IMS Access Media Gateway (IMA-MGW); Iq Interface; Stage 2 and Stage 3 | 321d? | 2008-09-12 A | 2009-12-04 A | 100% |  | 2008-09-12 | 2009-12-04 | 321d? |  | finish no earlier than 2009-12-04 | C4 | 2568h | 2568h | IMS_AGCF | PCG-21 | Rel-9 | CP-41 | Kimmo | Alcatel-Lucent |  |  |  |
| 207 | 100 | **Enhancements of IMS Customized Alerting Tone (CAT) Service** | 337d? | 2008-12-05 A | 2010-03-19 | 95% | 16.85d? | 2008-12-05 | 2010-03-19 | 337d? | 390d |  | C1 | 4966.4h | 4718.08h | eCAT | PCG-22 | Rel-9 | CP-42 | Frederic | China Mobile |  |  |  |
| 208 | 100.1 | Stage 3 Enhancements of IMS CAT Supplementary Service | 336d? | 2008-12-05 A | 2010-03-19 | 95% | 16.8d? | 2008-12-05 | 2010-03-19 | 336d? | 390d | finish no earlier than 2010-03-19 | C1 | 2688h | 2553.6h | eCAT-SS | PCG-22 | Rel-9 | CP-42 | Frederic | China Mobile | CP-090870 |  |  |

Notes:
- 184: SP#42 umbrella Feature created to host OAM WIs
- 185: SP#42 umbrella BB created to host OAM WIs
- 186: SP#46 exception to 03/10 in SP-090742 / Text3: 32.531, 32.532, 32.533, 32.537 / Text5: Bidipta Das (bidipta@huawei.com), Clemens Suerbaum (clemens.suerbaum@nsn.com)
- 187: SP#46 exception to 03/10 in SP-090749. Triggered by UID_400029 Study on Service Oriented Architecture (SOA) for IRP (TR 32.824) / Text3: 32.101, 32.102, 32.150 / Text5: Edwin Tse (Ericsson), Joerg Schmidt (NSN)
- 188: SP#46 exception to 03/10 in SP-090750. Continuation of Rel-8 UID_400030 IRP SOAP Solution Sets / Text3: 32.127, 32.327, 32.337, 32.357, 32.387, 32.397, 32.447, 32.121, 32.122, 32.123, 32.321, 32.322, 32.323, 32.325, 32.331, 32.332, 32.333, 32.335, 32.351, 32.352, 32.353, 32.381, 32.382, 32.383, 32.385, 32.391, 32.392, 32.393, 32.395, 32.441, 32.442, 32.443 / Text5: John Power
- 189: SP#42 umbrella BB created to host OAM WIs
- 190: SP#46 exception to 03/10 in SP-090745 / Text3: 32.425 / Text5: Yizhi Yao (yzyao@motorola.com),Lan Zou (zlan@huawei.com)
- 191: SP#46 completed / Text3: 32.426 / Text5: Li Jian (lijian@chinamobile.com), Liang Shuangchun (liangshuangchun@cmdi.chinamobile.com)
- 192: SP#46 completed / Text3: 32.405 / Text5: Liang Shuangchun, Li Jian, Bao Haitao
- 193: SP#46 stopped (no work in Rel-9)
- 194: SP#43 umbrella BB created to host OAM WIs
- 195: SP#46 exception to 03/10 in SP-090741. WID updated SP-090054=>SP-090762 (removed Self-Healing handling which becomes a Rel-10 dedicated WI SP-090757) / Text3: 32.425, new 32.521, 32.522, 32.523 / Text5: Lan Zou (zlan@huawei.com)
- 196: SP#46 exception to 03/10 in SP-090752. WID updated SP-090317=>SP-090869 / Text3: 32.501, 32.502, 32.503 / Text5: clemens.suerbaum@nsn.com
- 197: SP#46 exception to 03/10 in SP-090746 / Text3: 32.140, 32.141, 32.152, 32.172, 32.175 / Text5: frode.nergard@ericsson.com
- 198: -
- 199: SP#46 exception to 03/10 in SP-090755. RAT differentiation for charging. Completes Rel-8 Feature IWLAN_Mob UID_370049 Mobility between 3GPP-WLAN Interworking and 3GPP Systems / Text3: 32.240, 32.252, 32.298, 32.299 / Text5: Jean-Luc Garcia
- 200: CP#46 completed. Rel-8 UID_380061 (Ipinterc) covers Stage 1 in SA1 22.101, 22.228 / Text5: mauro.ficaccio@telecomitalia.it
- 201: CP#46 completed / Text3: 29.235 / Text5: mauro.ficaccio@telecomitalia.it
- 202: CP#46 completed / Text3: 23.231, 29.232, new 29.238 / Text5: mauro.ficaccio@telecomitalia.it
- 203: CP#46 completed / Text5: Bruno.Landais@alcatel-lucent.fr
- 204: CP#46 completed / Text3: new 29.238 / Text5: Bruno.Landais@alcatel-lucent.fr
- 205: CP#46 completed / Text3: 29.162, 29.235 / Text5: Bruno.Landais@alcatel-lucent.fr
- 206: CP#46 completed / Text3: new (23.334, 29.334) / Text5: bruno.landais@alcatel-lucent.fr
- 207: CP#46 completion 12/09=>03/10. CP#42 umbrella Feature created to host CT1 CAT WI (Stage 1 in 22.182) / Text5: Jiang Yi
- 208: CP#46 exception to 03/10 in CP-090870 / Text3: 24.182 / Text5: Jiang Yi

| ID | WBS | Task | Duration | Start | Finish | Complete | Remaining | Baseline start | Baseline finish | Baseline duration | Total slack | Constraint | Resources | Work | Actual work | Text1 | Text2 | Text4 | Text5 | Text6 | Text7 | Text8 | Text11 |
| --- | --- | --- | --- | --- | --- | --- | --- | --- | --- | --- | --- | --- | --- | --- | --- | --- | --- | --- | --- | --- | --- | --- | --- |
| 209 | 101 | **Completion of IMS Restoration Procedures** | 212d? | 2009-05-29 A | 2010-03-19 | 33% | 141.33d? | 2009-05-29 | 2010-03-19 | 212d? | 390d |  | C3, C4,C1 | 6784h | 1696h | eIMS_RP | PCG-23 | Ericsson | Emiliano Merino (emiliano.merino@ericsson.com) | Rel-9 | CP-44 | Kimmo |  |
| 210 | 101.1 | CT4 aspects of eIMS_RP | 212d? | 2009-05-29 A | 2010-03-19 | 60% | 84.8d? | 2009-05-29 | 2010-03-19 | 212d? | 390d | finish no earlier than 2010-03-19 | C4 | 1696h | 1017.6h | eIMS_RP | PCG-23 | Ericsson | Emiliano Merino (emiliano.merino@ericsson.com) | Rel-9 | CP-44 | Kimmo | CP-090806 |
| 211 | 101.2 | CT1 aspects of eIMS_RP | 212d? | 2009-05-29 | 2010-03-19 |  |  | 2009-05-29 | 2010-03-19 | 212d? | 390d | finish no earlier than 2010-03-19 | C1 | 1696h |  | eIMS_RP | PCG-23 | Ericsson | Emiliano Merino (emiliano.merino@ericsson.com) | Rel-9 | CP-44 | Kimmo | CP-090871 |
| 212 | 101.3 | CT3 aspects of eIMS_RP | 212d? | 2009-05-29 A | 2010-03-19 | 40% | 127.2d? | 2009-05-29 | 2010-03-19 | 212d? | 390d | finish no earlier than 2010-03-19 | C3 | 1696h | 678.4h | eIMS_RP | PCG-24 | Ericsson | Emiliano Merino (emiliano.merino@ericsson.com) | Rel-9 | CP-46 | Kimmo | CP-090863 |
| 213 | 102 | IMS Stage 3 - IETF Protocol Alignment | 212d? | 2009-05-29 A | 2010-03-19 | 95% | 10.6d? | 2009-05-29 | 2010-03-19 | 212d? | 390d | finish no earlier than 2010-03-19 | C1 | 1696h | 1611.2h | IMSProtoc3 | PCG-23 | Alcatel-Lucent | Keith Drage (drage@alcatel-lucent.com) | Rel-9 | CP-44 | Frederic |  |
| 214 | 103 | Operational description of the Inter-IMS Network to Network Interface (II-NNI) | 212d? | 2009-05-29 A | 2010-03-19 | 80% | 42.4d? | 2009-05-29 | 2010-03-19 | 212d? | 390d | finish no earlier than 2010-03-19 | C3 | 1696h | 1356.8h | II-NNI | PCG-23 | Orange | sebastien.daudet@orange-ftgroup.com | Rel-9 | CP-44 | Gwiho | CP-090862 |
| 215 | 104 | Definition of Ml interface for Control Plane LCS (Stage 3) | 131d? | 2009-09-18 A | 2010-03-19 | 75% | 32.75d? | 2009-09-18 | 2010-03-19 | 131d? | 390d | finish no earlier than 2010-03-19 | C1 | 1048h | 786h | EMC2 | PCG-23 | Alcatel-Lucent | Keith Drage (drage@alcatel-lucent.com) | Rel-9 | CP-45 | Frederic | CP-090872 |
| 216 | 105 | PCC enhancements | 56d? | 2009-09-18 A | 2009-12-04 A | 100% |  | 2009-09-18 | 2009-12-04 | 56d? |  | finish no earlier than 2009-12-04 | C3 | 448h | 448h | PCC-Enh | PCG-23 | Huawei | Wei Weihua (weiwh@huawei.com) | Rel-9 | CP-45 | Gwiho |  |
| 217 | 106 | 3GPP IMS Conferencing Management Object (MO) | 2d? | 2009-12-03 A | 2009-12-04 A | 100% |  | 2009-12-03 | 2009-12-04 | 2d? |  | start no earlier than 2009-12-03 | C1 | 16h | 16h | IMS_ConfMO | PCG-24 |  |  | Rel-9 | CP-46 |  |  |
| 218 | 107 | **Rel-9 Improvements of the Radio Interface** | 397d? | 2008-09-12 A | 2010-03-19 | 93% | 26.74d? | 2008-09-12 | 2010-03-19 | 397d? | 390d |  | RP,GP | 19147.6h | 18004.2h | RInImp9 | PCG-21 |  |  | Rel-9 | RP-41 | Issam |  |
| 219 | 107.1 | LCR TDD UE OTA Performance Requirements | 186d? | 2008-09-12 A | 2009-05-29 A | 100% |  | 2008-09-12 | 2009-05-29 | 186d? |  | finish no earlier than 2009-05-29 | R4 | 1488h | 1488h | RInImp9-RFLCROTA | PCG-21 | RITT | Wu Xiang (wuxiang@chinattl.com) | Rel-9 | RP-41 | Issam | RP-090389 |
| 220 | 107.2 | **RF requirements for Multicarrier and Multi-RAT BS** | 347d? | 2008-11-21 A | 2010-03-19 | 99% | 3.91d? | 2008-11-21 | 2010-03-19 | 347d? | 390d |  | R4,G1 | 7403.6h | 7320.15h | RInImp9-RFmulti | PCG-21 | Ericsson | Johan.skold@ericsson.com | Rel-9 | RP-41 | Issam | RP-091033 |
| 221 | 107.2.1 | RAN4 part of RF requirements for Multicarrier and Multi RAT BS | 337d? | 2008-12-05 A | 2010-03-19 | 98% | 6.74d? | 2008-12-05 | 2010-03-19 | 337d? | 390d | finish no earlier than 2010-03-19 | R4 | 2696h | 2642.08h | RInImp9-RFmulti | PCG-22 | Ericsson | Johan.skold@ericsson.com | Rel-9 | RP-42 | Issam | RP-091299 |
| 222 | 107.2.2 | GERAN part of RF requirements for Multicarrier and Multi RAT BS | 261d? | 2008-11-21 A | 2009-11-20 A | 100% |  | 2008-11-21 | 2009-11-20 | 261d? |  | finish no earlier than 2009-11-20 | G1 | 2088h | 2088h | RInImp9-RFmulti-GERAN | PCG-22 | Ericsson | mats.y.samuelsson@ericsson.com | Rel-9 | GP-40 | Paolo |  |
| 223 | 107.3 | Extended UMTS/LTE 800 MHz | 207d? | 2008-12-05 A | 2009-09-18 A | 100% |  | 2008-12-05 | 2009-09-18 | 207d? |  |  | R4,R2,R3 | 1648h | 1648h | RInImp9-UMTSLTE800 | PCG-22 | NTT DoCoMo | Shingo Suwa (suwas@nttdocomo.co.jp) | Rel-9 | RP-42 | Issam | RP-090687 |
| 224 | 107.4 | UMTS/LTE 800 MHz for Europe | 272d? | 2009-03-06 A | 2010-03-19 | 65% | 95.2d? | 2009-03-06 | 2010-03-19 | 272d? | 390d | finish no earlier than 2010-03-19 | R4,R2,R3 | 2176h | 1414.4h | RInImp9-UMTSLTE800EU | PCG-22 | Ericsson | olav.queseth@ericsson.com | Rel-9 | RP-43 | Issam | RP-091034 |
| 225 | 107.5 | Performance requirement for LCR TDD with UE speeds up to 350 km/h | 196d? | 2009-03-06 A | 2009-12-04 A | 100% |  | 2009-03-06 | 2009-12-04 | 196d? |  | finish no earlier than 2009-12-04 | R4 | 1568h | 1568h | RInImp9-LCRTDD350 | PCG-22 | CATT | Yuexia Song (songyuexia@datangmobile.cn) | Rel-9 | RP-43 | Issam | RP-091035 |
| 226 | 107.6 | Extended UMTS/LTE 1500 MHz | 211d? | 2009-05-30 A | 2010-03-19 | 95% | 10.55d? | 2009-05-30 | 2010-03-19 | 211d? | 390d | finish no earlier than 2010-03-19 | R4,R2,R3 | 1688h | 1603.6h | UMTSLTE1500 | PCG-23 | NTT DoCoMo | Shingo Suwa (suwas@nttdocomo.co.jp) | Rel-9 | RP-44 | Issam | RP-091365 |
| 227 | 108 | **Rel-9 Improvements of the Radio Interface - UE Conformance Testing** | 220d? | 2009-05-19 A | 2010-03-19 | 21% | 172.81d? | 2009-05-19 | 2010-03-19 | 220d? | 390d |  | R5 | 5176h | 1110.36h | RInImp-UEConTest | PCG-23 |  |  | Rel-9 | RP-44 | Ingbert |  |
| 228 | 108.1 | Conformance Test Aspects – UMTS/LTE in 800 MHz for Europe | 220d? | 2009-05-19 A | 2010-03-19 | 2% | 215.7d? | 2009-05-19 | 2010-03-19 | 220d? | 390d | finish no earlier than 2010-03-19 | R5 | 1760h | 34.4h | RInImp-UEConTest-UMTSLTE800EU | PCG-23 | Ericsson | fredrik.sundstrom@ericsson.com | Rel-9 | RP-44 | Ingbert | RP-091069 |
| 229 | 108.2 | Conformance Test Aspects – Extended UMTS/LTE 1500 MHz | 126d? | 2009-09-18 A | 2010-03-12 | 5% | 119.7d? | 2009-09-18 | 2010-03-12 | 126d? | 395d | finish no earlier than 2010-03-12 | R5 | 1008h | 50.4h | UMTSLTE1500_UEConTest | PCG-23 | NTT DoCoMo | Nguyen Dung Dao (dao@nttdocomo.co.jp) | Rel-9 | RP-45 | Ingbert | RP-091073 |
| 230 | 108.3 | TDD UE Over The Air (Antenna) conformance testing methodology | 81d? | 2009-05-30 A | 2009-09-18 A | 100% |  | 2009-05-30 | 2009-09-18 | 81d? |  | finish no earlier than 2009-09-18 | R5 | 648h | 648h | UEAnt_TDDTest | PCG-23 | CATR | Qu Yan (quyan@emcite.com) | Rel-9 | RP-44 | Ingbert | RP-090727 |
| 231 | 109 | Conformance Test Aspects – SMS over IMS in E-UTRAN | 196d? | 2009-09-18 A | 2010-06-18 | 5% | 186.2d? | 2009-09-18 | 2010-06-18 | 196d? | 325d | finish no earlier than 2010-06-18 | R5 | 1568h | 78.4h | SMSoverIMS_UEConTest | PCG-23 | Alcatel-Lucent | Nidal Khrais (khrais@alcatel-lucent.com) | Rel-9 | RP-45 | Ingbert | RP-091074 |
| 232 | 110 | **Rel-9 RAN improvements** | 272d? | 2009-03-06 A | 2010-03-19 | 99% | 3.7d? | 2009-03-06 | 2010-03-19 | 272d? | 390d |  | RP | 9536h | 9397.58h | RANimp | PCG-22 |  |  | Rel-9 | RP-43 | Issam |  |
| 233 | 110.1 | Dual-Cell HSUPA | 272d? | 2009-03-06 A | 2010-03-19 | 95% | 13.6d? | 2009-03-06 | 2010-03-19 | 272d? | 390d | finish no earlier than 2010-03-19 | R1,R2,R3,R4 | 1568h | 1459.2h | RANimp-DC_HSUPA | PCG-22 | Nokia Siemens Networks | Karri Ranta-aho (karri.ranta-aho@nsn.com) | Rel-9 | RP-43 | Patrick | RP-091037 |
| 234 | 110.2 | Support for different bands for Dual-Cell HSDPA | 197d? | 2009-03-06 A | 2009-12-04 A | 100% |  | 2009-03-06 | 2009-12-04 | 197d? |  |  | R4,R2,R3 | 1568h | 1568h | RANimp-MultiBand_DC_HSDPA | PCG-22 | Nokia Siemens Networks | Tuomo Säynäjäkangas (tuomo.saynajakangas@nsn.com) | Rel-9 | RP-43 | Issam | RP-091038 |
| 235 | 110.3 | Combination of DC-HSDPA with MIMO | 197d? | 2009-03-06 A | 2009-12-04 A | 100% |  | 2009-03-06 | 2009-12-04 | 197d? |  |  | R1,R2,R3,R4 | 1568h | 1568h | RANimp-DC_MIMO | PCG-22 | Ericsson | johan.bergman@ericsson.com | Rel-9 | RP-43 | Patrick | RP-091039 |
| 236 | 110.4 | Transmit Antenna Array (TxAA) extension for non-MIMO UEs | 197d? | 2009-03-06 A | 2009-12-04 A | 100% |  | 2009-03-06 | 2009-12-04 | 197d? |  |  | R1,R2,R3,R4 | 1568h | 1568h | RANimp-TxAA_nonMIMO | PCG-22 | Nokia | Arto Lehti (arto.lehti@nokia.com) | Rel-9 | RP-43 | Patrick | RP-091040 |
| 237 | 110.5 | Cell Portion for 1.28 Mcps TDD | 136d? | 2009-05-30 A | 2009-12-04 A | 100% |  | 2009-05-30 | 2009-12-04 | 136d? |  |  | R3,R1,R4 | 1088h | 1088h | CP_LCRTDD | PCG-23 | CATT | Ying Zhang (zhangying2@datangmobile.cn) | Rel-9 | RP-44 | Juha | RP-091041 |

Notes:
- 209: CP#46 exception to 03/10. WID updated CP-090316=>CP-091050 (added CT3 part). Continuation of Rel-8 Feature UID_400012 IMS Restoration Procedures
- 210: CP#46 exception to 03/10 in CP-090806 / Text3: 23.380, 23.820
- 211: CP#46 exception to 03/10 in CP-090871 / Text3: 24.229
- 212: CP#46 exception to 03/10 in CP-090863 / Text3: 29.061, 29.212, 29.213, 29.214, 29.215
- 213: CP#46 completion 12/09=>03/10 / Text3: 23.218, 24.229, 24.930
- 214: CP#46 exception to 03/10 in CP-090862 / Text3: 29.165
- 215: CP#46 exception to 03/10 in CP-090872. Stage 3 for Rel-7 Emergency Calls (EMC1). Related to Rel-9 UID_400038 LCS Control Plane Solution for EPS. Stage 2 in Rel-9 UID_400038 (23.271), UID_410037 (23.167) / Text3: 24.229
- 216: CP#46 completed / Text3: 29.212, 29.213, 29.215
- 217: CP#46 TS 24.166 v10x approved in CP-091044. Linked to Rel-6 UID_11051 (IMS Management objects) under the Feature UID_32021 (IMS Phase 2). MO compatible with OMA DM v1.2 & upwards and defined using OMA DM Device Description Framework (OMA-ERELD _DM-V1_2) / Text3: new 24.166
- 218: RP#41 umbrella Feature created to host Rel-9 WIs
- 219: RP#44 completed (Technical work completed, RAN4 internal TR abandoned. / Text3: Produced no TR 25.8xy (LCR TDD UE OTA performance requirements)
- 220: RF requirements specification applicable to Multi-Standard Radio (MSR) Base Station with multiple carriers and/or multiple 3GPP Radio Access Technologies (RAT)
- 221: RP#46 exception to 03/10 in RP-091382. WID updated RP-081098=>RP-091381 / Text3: 25.104, 25.105, 36.104, new 37.104, 37.113, 37.141, 37.900
- 222: GP#44 Core spec completed (ongoing BS conformance spec). GP#40 WID approved / Text3: 45.005, 51.021
- 223: RP#45 completed / Text3: 25.101, 25.104, 25.113, 25.133, 34.124, 36.101, 36.104, 36.113, 36.124, 36.133, 36.141, 25.306, 25.307, 25.331, 36.331, 25.461, 25.466, new 36.800
- 224: RP#46 exception to 03/10 in RP-091383. TR 36.810 v100 for Information / Text3: 25.101, 25.104, 25.113, 25.133, 25.141, 34.124, 36.101, 36.104, 36.113, 36.124, 36.133, 36.141, new 36.810, 25.306, 25.307, 25.331, 36.331, 25.461, 25.466
- 225: RP#46 completed / Text3: 25.102, 25.105, 25.142
- 226: RP#46 exception to 03/10 in RP-091367. For potential deployment in Japan / Text3: 25.101, 25.104, 25.113, 25.133, 25.141, 25.306, 25.307, 25.331, 25.461, 25.466, 34.124, 36.101, 36.104, 36.113, 36.124, 36.133, 36.141, 36.331, new 36.821
- 227: -
- 228: Testing for UID_430009 UMTS/LTE 800 MHz for Europe / Text3: 34.108, 34.121-1, 34.121-2, 36.508, 36.521-1, 36.521-2, 36.521-3
- 229: RP#46 updated WID RP-090748=>RP-091366 / Text3: 34.108, 34.121-1, 34.121-2, 34.123-1, 34.123-2, 34.123-3, 36.508, 36.521-1, 36.521-2, 36.521-3, 36.523-1, 36.523-2, 36.523-3
- 230: RP#45 completed. Finalize TDD UE test methodology based on R4 TR 25.914 (UE and MS antenna performance evaluation method) and TS 25.144 Over the Air (Antenna) minimum performance requirements for the speech mode (terminal close to head) / Text3: 34.114
- 231: - / Text3: 34.229-1, 34.229-2, 34.229-3
- 232: -
- 233: RP#46 exception to 03/10 in RP-091388 / Text3: 25.101, 25.104, 25.133, 25.211, 25.212, 25.213, 25.214, 25.215, 25.319, 25.306, 25.321, 25.331, 25.423, 25.433
- 234: RP#46 completed / Text3: 25.101, 25.104, 25.133, 25.306, 25.308, 25.331, 25.423, 25.433, new 25.317 (Requirements on Ues supporting a release-independent frequency band combination)
- 235: RP#46 completed / Text3: 25.101, 25.104, 25.133, 25.211, 25.212, 25.213, 25.214, 25.215, 25.308, 25.321, 25.331, 26.306, 25.423, 25.433
- 236: RP#46 completed / Text3: 25.101, 25.104, 25.211, 25.212, 25.213, 25.214, 25.215, 25.308, 25.306, 25.321, 25.331, 25.423, 25.433
- 237: RP#46 completed / Text3: 25.102, 25.105, 25.123, 25.225, 25.423, 25.433

| ID | WBS | Task | Duration | Start | Finish | Complete | Remaining | Baseline start | Baseline finish | Baseline duration | Total slack | Constraint | Resources | Work | Actual work | Text1 | Text2 | Text6 | Text7 | Text8 | Text4 | Text5 | Text11 |
| --- | --- | --- | --- | --- | --- | --- | --- | --- | --- | --- | --- | --- | --- | --- | --- | --- | --- | --- | --- | --- | --- | --- | --- |
| 238 | 111 | **LTE improvements** | 272d? | 2009-03-06 A | 2010-03-19 | 88% | 31.62d? | 2009-03-06 | 2010-03-19 | 272d? | 390d |  | RP | 5920h | 5231.86h | LTEimp | PCG-22 | Rel-9 | RP-42 | Issam |  |  |  |
| 239 | 111.1 | LTE Pico NodeB RF Requirements | 196d? | 2009-03-06 A | 2009-12-04 A | 100% |  | 2009-03-06 | 2009-12-04 | 196d? |  | finish no earlier than 2010-03-05 | R4 | 1568h | 1568h | LTEimp-Pico_eNB-RF | PCG-22 | Rel-9 | RP-43 | Issam | Huawei | Liyan Yin (yinliyan@huawei.com) | RP-091045 |
| 240 | 111.2 | Enhanced Dual-Layer transmission for LTE | 272d? | 2009-03-06 A | 2010-03-19 | 80% | 54.4d? | 2009-03-06 | 2010-03-19 | 272d? | 390d | finish no earlier than 2010-03-19 | R1,R2,R4 | 2176h | 1740.8h | LTEimp-eDL | PCG-22 | Rel-9 | RP-43 | Patrick | China Mobile | Xu Xiaodong (xuxiaodong@chinamobile.com) | RP-091046 |
| 241 | 112 | **System aspects of vocoder rate adaptation for LTE** | 140d? | 2009-05-30 A | 2009-12-10 A | 100% |  | 2009-05-30 | 2009-12-10 | 140d? |  |  | S2,S4,R2 | 3504h | 3504h | LTEimp-Vocoder | PCG-23 | Rel-9 | SP-45 | Maurice | Qualcomm Europe | AC Mahendran (ac@qualcomm.com) |  |
| 242 | 112.1 | SA2 system aspects of vocoder rate adaptation for LTE | 81d? | 2009-06-04 A | 2009-09-24 A | 100% |  | 2009-06-04 | 2009-09-24 | 81d? |  | start no earlier than 2009-06-04 | S2 | 648h | 648h | LTEimp-Vocoder | PCG-23 | Rel-9 | SP-45 | Maurice | Qualcomm Europe | AC Mahendran (ac@qualcomm.com) |  |
| 243 | 112.2 | SA4 system aspects of vocoder rate adaptation for LTE | 136d? | 2009-06-04 A | 2009-12-10 A | 100% |  | 2009-06-04 | 2009-12-10 | 136d? |  | finish no earlier than 2009-12-07 | S4 | 1088h | 1088h | LTEimp-Vocoder | PCG-23 | Rel-9 | SP-45 | Paolo | Qualcomm Europe | Nikolai Leung |  |
| 244 | 112.3 | Vocoder rate adaptation for LTE | 81d? | 2009-05-30 A | 2009-09-18 A | 100% |  | 2009-05-30 | 2009-09-18 | 81d? |  | finish no earlier than 2009-09-18 | R2 | 648h | 648h | LTEimp-Vocoder | PCG-23 | Rel-9 | RP-44 | Joern | Alcatel-Lucent | Sudeep Palat (spalat@alcatel-lucent.com) | RP-090704 |
| 245 | 113 | Self-Organizing Networks (SON) | 272d? | 2009-03-06 A | 2010-03-19 | 91% | 24.48d? | 2009-03-06 | 2010-03-19 | 272d? | 390d | finish no earlier than 2010-03-19 | R3,R2 | 2176h | 1980.16h | SON | PCG-22 | Rel-9 | SP-42 | Juha | Nokia Siemens Networks | Krzysztof Kordybach | RP-091051 |
| 246 | 114 | **A-GNSS Performances and Testing Procedures** | 527d? | 2008-05-16 A | 2010-05-21 | 50% | 261.21d? | 2008-05-16 | 2010-05-21 | 527d? | 345d |  | GP | 12208h | 4348.4h | AGNSSPTP |  | Rel-9 |  | Paolo | Thales | Michel.monnerat@thalesaleniaspace.com | GP-092344 |
| 247 | 114.1 | A-GNSS Minimum Performances | 472d? | 2008-05-16 A | 2010-03-05 | 90% | 47.2d? | 2008-05-16 | 2010-03-05 | 472d? | 400d | finish no earlier than 2010-03-05 | G1 | 3776h | 3398.4h | AGNSSPTP- Perfreq |  | Rel-9 |  | Paolo | Thales | Michel.monnerat@thalesaleniaspace.com | GP-092344 |
| 248 | 114.2 | A-GNSS Testing Procedures | 527d? | 2008-05-16 A | 2010-05-21 | 15% | 447.95d? | 2008-05-16 | 2010-05-21 | 527d? | 345d | finish no earlier than 2010-05-21 | G3new | 4216h | 632.4h | AGNSSPTP-MStest |  | Rel-9 |  | Ingbert | Thales | Michel.monnerat@thalesaleniaspace.com | GP-092344 |
| 249 | 115 | **Voice services over Adaptive Multi-user channels on One Slot** | 392d? | 2008-11-21 A | 2010-05-21 | 63% | 143.64d? | 2008-11-21 | 2010-05-21 | 392d? | 345d |  | GP | 12520.7h | 7929.92h | VAMOS | PCG-22 | Rel-9 | SP-42 | Paolo | Nokia Siemens Networks, China Mobile | juergen.hofmann@nsn.com, liuxiaoyu@chinamobile.com | GP-092470 |
| 250 | 115.1 | VAMOS Stage 2 | 392d? | 2008-11-21 A | 2010-05-21 | 90% | 39.2d? | 2008-11-21 | 2010-05-21 | 392d? | 345d | finish no earlier than 2010-05-21 | GP | 3128.68h | 2815.08h | VAMOS | PCG-22 | Rel-9 | GP-40 | Paolo | Nokia Siemens Networks, China Mobile | juergen.hofmann@nsn.com, liuxiaoyu@chinamobile.com | GP-092470 |
| 251 | 115.2 | VAMOS Stage 3 | 391d? | 2008-11-21 A | 2010-05-21 | 60% | 156.4d? | 2008-11-21 | 2010-05-21 | 391d? | 345d | finish no earlier than 2010-05-21 | GP | 3128h | 1876.8h | VAMOS | PCG-22 | Rel-9 | GP-40 | Paolo | Nokia Siemens Networks, China Mobile | juergen.hofmann@nsn.com, liuxiaoyu@chinamobile.com | GP-092470 |
| 252 | 115.3 | VAMOS Radio Performance Requirements | 391d? | 2008-11-24 A | 2010-05-21 | 40% | 234.6d? | 2008-11-24 | 2010-05-21 | 391d? | 345d | finish no earlier than 2010-05-21 | GP | 3128h | 1251.2h | VAMOS | PCG-22 | Rel-9 | GP-40 | Paolo | Nokia Siemens Networks, China Mobile | juergen.hofmann@nsn.com, liuxiaoyu@chinamobile.com | GP-092470 |
| 253 | 116 | **Local Call Local Switch** | 327d? | 2009-02-20 A | 2010-05-21 | 34% | 217.27d? | 2009-02-20 | 2010-05-21 | 327d? | 345d |  | GP,C4,C3,C1 | 12008h | 3460.2h | LCLS | PCG-22 | Rel-9 | GP-41 | Paolo | Huawei | Xing Zhu |  |
| 254 | 116.1 | Local Call Local Switch | 326d? | 2009-02-20 A | 2010-05-21 | 60% | 130.4d? | 2009-02-20 | 2010-05-21 | 326d? | 345d | finish no earlier than 2010-05-21 | GP | 2608h | 1564.8h | LCLS | PCG-22 | Rel-9 | GP-41 | Paolo | Huawei | Xing Zhu | GP-092473 |
| 255 | 116.2 | **CN aspects of Local Call Local Switch** | 212d? | 2009-05-29 A | 2010-03-19 | 20% | 169.6d? | 2009-05-29 | 2010-03-19 | 212d? | 390d |  | C4 | 6784h | 1017.6h | LCLS-CN | PCG-23 | Rel-9 | CP-44 | Kimmo | Vodafone | David Hutton |  |
| 256 | 116.2.1 | CT4 aspects of LCLS | 212d? | 2009-05-29 A | 2010-03-19 | 60% | 84.8d? | 2009-05-29 | 2010-03-19 | 212d? | 390d | finish no earlier than 2010-03-19 | C4 | 1696h | 1017.6h | LCLS-CN | PCG-23 | Rel-9 | CP-44 | Kimmo | Vodafone | David Hutton | CP-090807 |
| 257 | 116.2.2 | CT3 aspects of LCLS | 212d? | 2009-05-29 | 2010-03-19 |  |  | 2009-05-29 | 2010-03-19 | 212d? | 390d | finish no earlier than 2010-03-19 | C3 | 1696h |  | LCLS-CN | PCG-23 | Rel-9 | CP-44 | Gwiho | Vodafone | David Hutton |  |
| 258 | 116.2.3 | CT1 aspects of LCLS | 212d? | 2009-05-29 | 2010-03-19 |  |  | 2009-05-29 | 2010-03-19 | 212d? | 390d | finish no earlier than 2010-03-19 | C1 | 1696h |  | LCLS-CN | PCG-23 | Rel-9 | CP-44 | Frederic | Vodafone | David Hutton |  |
| 259 | 117 | **Cell Broadcast protocol Base Station Controller – Cell Broadcast Centre (BSC-CBC)** | 222d? | 2009-05-15 A | 2010-03-19 | 39% | 135.25d? | 2009-05-15 | 2010-03-19 | 222d? | 390d |  | GP,C1 | 5248h | 2050.83h | CEBRO | PCG-23 | Rel-9 | GP-42 | Paolo | Ericsson | Claes-Göran Persson |  |
| 260 | 117.1 | Cell Broadcast protocol Base Station Controller – Cell Broadcast Centre (BSC-CBC) | 212d? | 2009-05-15 A | 2010-03-05 | 80% | 42.4d? | 2009-05-15 | 2010-03-05 | 212d? | 400d | finish no earlier than 2010-03-05 | GP | 1696h | 1356.8h | CEBRO | PCG-23 | Rel-9 | GP-42 | Paolo | Ericsson | Claes-Göran Persson | GP-092475 |
| 261 | 117.2 | Cell Broadcast protocol Base Station Controller – Cell Broadcast Centre (BSC-CBC) | 222d? | 2009-05-15 | 2010-03-19 |  |  | 2009-05-15 | 2010-03-19 | 222d? | 390d | finish no earlier than 2010-03-19 | C1 | 1776h |  | CEBRO | PCG-23 | Rel-9 | GP-42 | Frederic | Ericsson | Claes-Göran Persson | CP-090867 |
| 262 | 118 | Hybrid Location | 136d? | 2009-05-18 A | 2009-11-20 A | 100% |  | 2009-05-18 | 2009-11-20 | 136d? |  | finish no earlier than 2009-11-20 | GP | 1088h | 1088h | HILT | PCG-23 | Rel-9 | GP-42 | Paolo | TruePosition | Matt Ward (mward@trueposition.com) |  |
| 263 | 119 | (Small) Technical Enhancements and Improvements for Rel-9 | 325d? | 2008-09-15 A | 2009-12-10 A | 100% |  | 2008-09-15 | 2009-12-10 | 325d? |  | finish no earlier than 2009-12-10 | All | 2600h | 2600h | TEI9 | PCG-22 | Rel-9 | SP-42 |  |  |  |  |
| 264 | 120 | Test - (Small) Technical Enhancements and Improvements for Rel-8 | 286d? | 2009-11-20 | 2010-12-24 |  |  | 2009-11-20 | 2010-12-24 | 286d? | 190d | finish no earlier than 2010-12-24 | R5,G3new | 2288h |  | TEI9_Test | PCG-24 | Rel-9 | GP-44 |  |  |  |  |

Notes:
- 238: -
- 239: RP#46 completed. WID updated RP-090096=>RP-091155 / Text3: 36.104, 36.141, new 36.931
- 240: RP#46 exception to 03/10 in RP-091147. WID updated RP-090783=>RP-091385 / Text3: 36.101, 36.211, 36.212, 36.213, 36.331
- 241: SP#46 completed. Triggered by RAN2 UID_440013 Vocoder rate adaptation for LTE
- 242: SP#45 completed (CR adding support for Explicit Congestion Notification) / Text3: 23.401 CR#1103r3
- 243: SP#46 completed / Text3: 26.114
- 244: RP#45 completed / Text3: 36.300 CR#0114
- 245: RP#46 exception to 03/10 in RP-091395 / Text3: 25.413, 36.300, 36.413, 36.423, 36.902, 48.018
- 246: GP#44 moved to Rel-9. Rel-9 exception to 03/10 in GP-092344. Linked to Rel-10 RAN4 UID_450027 (A-GNSS Minimum Performance for UTRAN)
- 247: GP#44 moved to Rel-9. Rel-9 exception to 03/10 in GP-092344 / Text3: 45.005
- 248: GP#44 moved to Rel-9. Rel-9 exception to 03/10 in GP-092344 / Text3: 51.010-1
- 249: GP#44 exception to 05/10 in GP-092470. GP#40 WID approved. Triggered by UID_50590 (MUROS) Study on Multi-User Reusing-One-Slot
- 250: GP#44 exception to 05/10 in GP-092470 / Text3: 45.001 (Overview of VAMOS solution)
- 251: GP#44 exception to 05/10 in GP-092470 / Text3: 24.008, 44.018, 45.002, 45.003, 45.004, 45.008, 48.008, 48.058
- 252: GP#44 exception to 05/10 in GP-092470 / Text3: 45.005 (Test Scenarios for VAMOS Performance requirements)
- 253: GP#44 exception to 05/10 in GP-092473. GP#41 WID approved. CP#46 WID (CP-090519) revised to Study item (CP-090812).
- 254: GP#44 exception to 05/10 in GP-092473. GP#41 WID approved / Text3: 48.008 (MSC-BSS interface; Layer 3 specification)
- 255: CP#46 WID (CP-090519) revised to Study item (CP-090812). Normative work can be done in Rel-9 but then a complete set of CRs and WID must be provided for approval at CP#47 03/10.
- 256: CP#46 exception to 03/10 in CP-090807 to finish TR 23.889. Normative work target: 23.205, 23.153, 23.231, 29.232 / Text3: new 23.889
- 257: - / Text3: 29.007
- 258: - / Text3: 23.009
- 259: GP#42 WID approved
- 260: GP#44 exception to 03/10 in GP-092475. GP#42 WID approved / Text3: new 48.049
- 261: CP#46 exception to 03/10 in CP-090867 / Text3: 23.041
- 262: GP#44 completed. GP#42 WID approved (Hybrid Integrated Location Technology=HILT) / Text3: 43.059, 48.071
- 263: SP#46 completed
- 264: GP#44 created

| ID | WBS | Task | Type | Duration | Start | Finish | Complete | Remaining | Baseline start | Baseline finish | Baseline duration | Total slack | Constraint | Resources | Work | Actual work | Text1 | Text2 | Text4 | Text6 | Text7 | Text8 | Text9 | Text12 | Text5 | Text11 |
| --- | --- | --- | --- | --- | --- | --- | --- | --- | --- | --- | --- | --- | --- | --- | --- | --- | --- | --- | --- | --- | --- | --- | --- | --- | --- | --- |
| 265 | 121 | **Deleted - SAES Enhancements (non RAN aspects)** |  | 381d? | 2007-06-25 A | 2008-12-08 A | 100% |  | 2007-06-25 | 2008-12-08 | 381d? |  |  | S2 | 11664h | 11664h | SAES_Ph2 | PCG-21 | Nokia Siemens Networks | Rel-9 | SP-39 | Maurice | PCG-21 | SP-39 |  |  |
| 266 | 121.1 | Deleted - Functions and procedures for SAE to support LTE MBMS |  | 381d? | 2007-06-25 A | 2008-12-08 A | 100% |  | 2007-06-25 | 2008-12-08 | 381d? |  | finish no earlier than 2008-12-08 | S2 | 3048h | 3048h | SAES_Ph2 |  |  | Rel-9 | SP-35 | Maurice | PCG-21 | SP-39 |  |  |
| 267 | 121.2 | Deleted - CS over EPS |  | 194d? | 2008-03-12 A | 2008-12-08 A | 100% |  | 2008-03-12 | 2008-12-08 | 194d? |  | finish no earlier than 2008-12-08 | S2 | 1552h | 1552h | SAES_Ph2 | PCG-21 |  | Rel-9 | SP-39 | Maurice | PCG-21 | SP-39 |  |  |
| 268 | 121.3 | **Deleted - SAE for generic support for non-3GPP accesses** |  | 251d? | 2007-06-25 A | 2008-06-09 A | 100% |  | 2007-06-25 | 2008-06-09 | 251d? |  |  | S2 | 4016h | 4016h | SAES_Ph2 | PCG-21 |  | Rel-9 | SP-39 | Maurice | PCG-21 | SP-39 |  |  |
| 269 | 121.3.1 | Deleted - Single Radio Aspects of SAE for Optimized Handover with WiMAX |  | 251d? | 2007-06-25 A | 2008-06-09 A | 100% |  | 2007-06-25 | 2008-06-09 | 251d? |  | finish no earlier than 2008-06-09 | S2 | 2008h | 2008h | SAES_Ph2 | PCG-21 |  | Rel-9 | SP-39 | Maurice | PCG-21 | SP-39 |  |  |
| 270 | 122 | Deleted - Harmonization of Gq'/Rx for Common IMS |  | 304d? | 2008-01-14 A | 2009-03-12 A | 100% |  | 2008-01-14 | 2009-03-12 | 304d? |  | finish no earlier than 2009-03-12 | S2 | 2432h | 2432h | IMS_Comm_GqRx_Harm | PCG-21 | Alcatel-Lucent | Rel-9 | SP-38 | Maurice | PCG-22 | SP-43 | geoffrey.cristallo@alcatel-lucent.be |  |
| 271 | 123 | Deleted - Support of WiMAX - LTE Mobility |  | 407d? | 2008-06-06 A | 2009-12-25 A | 100% |  | 2008-06-06 | 2009-12-25 | 407d? |  | start no earlier than 2008-06-06 | R2 | 3248h | 3248h | WiMAX_LTE_Mobility | PCG-21 | Samsung | Rel-9 | RP-38 | Joern | PCG-21 | SP-39 |  |  |
| 272 | 124 | Deleted - Support of WiMAX - UMTS Mobility |  | 407d? | 2008-06-06 A | 2009-12-25 A | 100% |  | 2008-06-06 | 2009-12-25 | 407d? |  | start no earlier than 2008-06-06 | R2 | 3248h | 3248h | WiMAX_UMTS_Mobility | PCG-21 | Intel | Rel-9 | RP-38 | Joern | PCG-21 | SP-39 |  |  |
| 273 | 125 | Release 9 Studies | milestone | 0d? | 2000-01-01 | 2000-01-01 |  |  | 2000-01-01 | 2000-01-01 | 0d? | 3057d |  | CP,RP,SP |  |  |  |  |  | Rel-9 |  |  |  |  |  |  |
| 274 | 126 | Study on CS Domain Services over EPS access |  | 492d? | 2007-04-25 A | 2009-03-12 A | 100% |  | 2007-04-25 | 2009-03-12 | 492d? |  | finish no earlier than 2009-03-12 | S2 | 3936h | 3936h | FS_CSoPS |  | T-Mobile | Rel-9 | SP-35 | Maurice |  |  | Karl-Heinz.Nenner@T-Mobile.net |  |
| 275 | 127 | Study on Extended Support of IMS Emergency Calls |  | 319d? | 2007-09-24 A | 2008-12-11 A | 100% |  | 2007-09-24 | 2008-12-11 | 319d? |  | finish no earlier than 2009-06-18 | S2 | 2552h | 2552h | FS_IMS-eCall |  | Qualcomm Europe | Rel-9 | SP-37 | Maurice |  |  | Stephen Edge |  |
| 276 | 128 | Study on Service Continuity for Emergency Voice Calls |  | 721d? | 2006-06-08 A | 2009-03-12 A | 100% |  | 2006-06-08 | 2009-03-12 | 721d? |  | finish no earlier than 2009-03-12 | S2 | 5768h | 5768h | FS_VCCEm |  | Nortel | Rel-9 | SP-32 | Maurice |  |  | Ricky Kaura (rkaura@nortel.com) |  |
| 277 | 129 | Study on Security Aspects of Remote Provisioning and Change of Subscription for M2M Equipment |  | 582d? | 2004-04-06 A | 2009-12-10 A | 100% |  | 2004-04-06 | 2009-12-10 | 582d? |  | finish no earlier than 2009-12-10 | S3,C6 | 4656h | 4656h | FS_UM2M |  | Ericsson | Rel-9 | SP-37 | Dionisio |  |  | vesa.lehtovirta@ericsson.com |  |
| 278 | 130 | Study on System Maintenance over Itf-N |  | 602d? | 2007-06-07 A | 2009-09-24 A | 100% |  | 2007-06-07 | 2009-09-24 | 602d? |  | finish no earlier than 2009-09-24 | S5 | 4808h | 4808h | FS_OAM-Maint-Itf-N |  | ZTE | Rel-9 | SP-36 | Dionisio |  |  | HUANG, Shuqiang |  |
| 279 | 131 | Study on Self-Organizing Networks (SON) related OAM interfaces for Home NodeB |  | 522d? | 2007-06-07 A | 2009-06-04 A | 100% |  | 2007-06-07 | 2009-06-04 | 522d? |  | finish no earlier than 2009-12-10 | S5 | 4168h | 4168h | FS_OAM-SON-HNB |  | Huawei | Rel-9 | SP-36 | Dionisio |  |  | Zou Lan (zlan@huawei.com) |  |
| 280 | 132 | Study on Self-healing of Self-Organizing Networks (SON) |  | 416d? | 2008-02-22 A | 2009-09-24 A | 100% |  | 2008-02-22 | 2009-09-24 | 416d? |  | finish no earlier than 2009-09-24 | S5 | 3320.15h | 3320.15h | FS_OAM-SON-SH | PCG-21 | ZTE | Rel-9 | SP-39 | Dionisio |  |  | zhu.weihong@zte.com.cn |  |
| 281 | 133 | Study on Service Oriented Architecture (SOA) for IRP |  | 262d? | 2008-06-05 A | 2009-06-04 A | 100% |  | 2008-06-05 | 2009-06-04 | 262d? |  | finish no earlier than 2009-05-20 | S5 | 2088h | 2088h | FS_OAM_SOA_IRP | PCG-21 | Ericsson | Rel-9 | SP-40 | Dionisio |  |  | edwin.tse@ericsson.com |  |
| 282 | 134 | Study on Interworking Proxy between GTP based and PMIP based interfaces |  | 131d? | 2009-09-18 A | 2010-03-19 | 60% | 52.4d? | 2009-09-18 | 2010-03-19 | 131d? | 390d | finish no earlier than 2010-03-19 | C4 | 1048h | 628.8h | FS_GTP-MIP-IW | PCG-23 | NTT DoCoMo | Rel-9 | CP-45 | Kimmo |  |  | takaaki.matsuura.sp@s1.nttdocomo.com | CP-090810 |
| 283 | 135 | Study on Evaluation of the inclusion of Path Loss Based Technology in the UTRAN |  | 516d? | 2007-12-17 A | 2009-12-04 A | 100% |  | 2007-12-17 | 2009-12-04 | 516d? |  | finish no earlier than 2009-09-18 | R4 | 4120h | 4120h | FS_RAN-Pathloss | PCG-21 | Polaris Wireless | Rel-9 | RP-38 | Issam |  |  | Norman Shaw (nshaw@polariswireless.com) | RP-091080 |
| 284 | 136 | Study on LTE-Advanced |  | 461d? | 2007-03-23 A | 2010-03-19 | 80% | 92.8d? | 2007-03-23 | 2010-03-19 | 461d? | 390d | finish no earlier than 2010-03-19 | R1,R2,R3,R4 | 3688h | 2945.6h | FS_RAN_LTEA | PCG-21 | NTT DoCoMo | Rel-9 | RP-39 | Patrick |  |  | Tetsushi Abe | RP-091082 |
| 285 | 137 | Study on 1.28 Mcps TDD Home NodeB |  | 387d? | 2008-02-20 A | 2009-12-04 A | 100% |  | 2008-02-20 | 2009-12-04 | 387d? |  | finish no earlier than 2009-12-04 | R4 | 3096h | 3096h | FS_RAN-HNBLCRTDD | PCG-21 | TD Tech | Rel-9 | RP-41 | Issam |  |  | Li Rong (lirong@td-tech.com) | RP-091081 |
| 286 | 138 | Study on E-UTRAN Mobility Evaluation and Enhancement |  | 126d? | 2008-12-05 A | 2009-05-29 A | 100% |  | 2008-12-05 | 2009-05-29 | 126d? |  | finish no earlier than 2009-05-29 | R1 | 1008h | 1008h | FS_EUTRAN_mob | PCG-22 | Qualcomm Europe | Rel-9 | RP-42 | Patrick |  |  | Rajat Prakash (rprakash@qualcomm.com) | RP-090426 |
| 287 | 139 | Study on Minimization of drive-tests in Next Generation Networks |  | 196d? | 2009-03-06 A | 2009-12-04 A | 100% |  | 2009-03-06 | 2009-12-04 | 196d? |  | finish no earlier than 2009-12-04 | R2 | 1568h | 1568h | FS_NGN_min_drive-tests | PCG-22 | Qualcomm Europe | Rel-9 | RP-43 | Joern |  |  | Masato Kitazoe (mkitazoe@qualcomm.com) | RP-091084 |
| 288 | 140 | Study on Enhanced Interference Management for HNBs |  | 61d? | 2009-03-06 A | 2009-05-29 A | 100% |  | 2009-03-06 | 2009-05-29 | 61d? |  | start no earlier than 2009-03-06 | R4 | 488h | 488h | FS_eInterfMgmt_HNB | PCG-22 | Qualcomm Europe | Rel-9 | RP-43 | Issam |  |  | Farhad Meshkati (fmeshkat@qualcomm.com) | RP-090429 |
| 289 | 141 | Study on Enhanced Interference Management Mechanisms for HNBs |  | 81d? | 2009-05-30 A | 2009-09-18 A | 100% |  | 2009-05-30 | 2009-09-18 | 81d? |  | finish no earlier than 2009-09-18 | R3 | 648h | 648h | FS_eInterfMgmtMchsm_HNB | PCG-23 | Qualcomm Europe | Rel-9 | RP-44 | Juha |  |  | Farhad Meshkati (fmeshkat@qualcomm.com) | RP-090733 |
| 290 | 142 | Deleted - Study on Protection against SMS and MMS spam |  | 862d? | 2006-06-08 A | 2009-09-24 A | 100% |  | 2006-06-08 | 2009-09-24 | 862d? |  | finish no earlier than 2009-09-24 | S3 | 6896h | 6896h | FS_CPSMal |  | Orange | Rel-9 | SP-32 | Dionisio | PCG-23 | SP-45 | eric.gauthier@orange.ch |  |
| 291 | 143 | Release 8 Features | milestone | 0d? | 2000-01-03 | 2000-01-03 |  |  | 2000-01-03 | 2000-01-03 | 0d? | 3056d | start no earlier than 2000-01-03 | CP,GP,RP,SP |  |  |  |  |  | Rel-8 |  |  |  |  |  |  |
| 292 | 144 | Conformance Test Aspects – Mobility management based on DSMIPv6 (Dual-Stack Mobile IPv6) |  | 196d? | 2009-09-18 A | 2010-06-18 | 20% | 156.8d? | 2009-09-18 | 2010-06-18 | 196d? | 325d | finish no earlier than 2010-06-18 | R5 | 1568h | 313.6h | DSMIPv6_UEConTest | PCG-23 | Qualcomm Europe | Rel-8 | RP-45 | Ingbert |  |  | Lena Chaponniere (lchaponn@qualcomm.com) | RP-091075 |

Notes:
- 265: SP#39 created to host Rel-9 Wis. BUT no agreed WID
- 266: SP#39 SAE functionality moved to Rel-9. WID returned to SA2 for re-consideration & remove MBMS for EPS from Rel 8
- 267: SP#39 SAE functionality moved to Rel-9. BUT no agreed WID
- 268: SP#39 SAE functionality moved to Rel-9. BUT no agreed WID
- 269: SP#39 SAE functionality moved to Rel-9. BUT no agreed WID
- 270: SP#43 stopped. LS_out to TISPAN informs about stopping this activity / Text3: 23.822, 23.203
- 271: RP#39: No agreed WID / Text3: 36.306, 36.331, 36.413, 36.300, 36.214, 36.133, 36.304
- 272: RP#39: No agreed WID / Text3: 25.306, 25.331, 25.413
- 273: -
- 274: SP#43 completed / Text3: 23.879
- 275: SP#42 completed / Text3: 23.868
- 276: SP#43 completed / Text3: 23.826
- 277: SP#46 completed. Triggered by SA1 Study UID_7027 (FS_M2M) TR 22.868 / Text3: 33.812
- 278: SP#45 completed / Text3: 32.822
- 279: SP#44 completed / Text3: 32.821
- 280: SP#45 completed / Text3: 32.823
- 281: SP#44 completed. Spin-off implementation WI UID_440064 Service Oriented Architecture (SOA) for IRP / Text3: 32.824
- 282: CP#46 exception to 03/10 in CP-090810 / Text3: 29.875
- 283: RP#46 completed / Text3: 25.907
- 284: RP#46 updated WID RP-090735=>RP-091360 / Text3: 36.913 , new 36.814, 36.912, R2 36.806 (Relay architectures for E-UTRA), R4 36.815 (LTE-Advanced feasibility studies in RAN4)
- 285: RP#46 completed / Text3: 25.866
- 286: RP#44 completed (RP-090452 R1 LS to RAN on Conclusions for LTE Mobility Study Item - no further Rel-9 action/TR needed
- 287: RP#46 completed / Text3: 36.805
- 288: RP#44 completed. Spin-off RAN3 UID_440015 Study on Enhanced Interference Management Mechanisms for HNBs / Text3: 25.967
- 289: Triggered by RAN4 UID_430027 Study on Enhanced Interference Management for HNBs. RP#45 completed / Text3: 25.967
- 290: SP#45 work stopped/abandoned / Text3: 33.9xx
- 291: -
- 292: Testing for CT1's UID_360022 (24.303) under Rel-8 Feature SAES / Text3: 36.508, 36.523-1, 36.523-2, 36.523-3

| ID | WBS | Task | Duration | Start | Finish | Complete | Baseline start | Baseline finish | Baseline duration | Constraint | Resources | Work | Actual work | Text1 | Text4 | Text5 | Text6 | Text8 | Text3 | Text2 | Text7 |
| --- | --- | --- | --- | --- | --- | --- | --- | --- | --- | --- | --- | --- | --- | --- | --- | --- | --- | --- | --- | --- | --- |
| 293 | 145 | **IMS Enhancements for support of Packet Cable access** | 388d? | 2006-12-06 A | 2008-05-30 A | 100% | 2006-12-06 | 2008-05-30 | 388d? |  | S2,S3,C1,C3,C4 | 27448h | 27448h | PktCbl | Cablelabs | Bernie McKibben | Rel-8 | Maurice |  |  |  |
| 294 | 145.1 | **IMS Enhancements for Cable Client Types and Deployment Models** | 345d? | 2007-02-05 A | 2008-05-30 A | 100% | 2007-02-05 | 2008-05-30 | 345d? |  | S2,C1 | 6992h | 6992h | PktCbl-Deploy | Cablelabs | Bernie McKibben | Rel-8 | Maurice |  |  |  |
| 295 | 145.1.1 | Architecture aspects of PktCbl-Deploy | 219d? | 2007-02-05 A | 2007-12-06 A | 100% | 2007-02-05 | 2007-12-06 | 219d? | finish no earlier than 2007-12-03 | S2 | 1752h | 1752h | PktCbl-Deploy | Cablelabs | Bernie McKibben | Rel-8 | Maurice | 23.228 |  |  |
| 296 | 145.1.2 | CT1 aspects of PktCbl-Deploy | 310d? | 2007-03-26 A | 2008-05-30 A | 100% | 2007-03-26 | 2008-05-30 | 310d? | finish no earlier than 2008-06-15 | C1 | 2480h | 2480h | PktCbl-Deploy | Cablelabs | D.Hancock@ CableLabs.com | Rel-8 | Frederic |  |  |  |
| 297 | 145.2 | **IMS Inter-working aspects in Support of Cable Regulatory requirements** | 290d? | 2007-02-05 A | 2008-03-14 A | 100% | 2007-02-05 | 2008-03-14 | 290d? |  | S2,C1,C3 | 5640h | 5640h | PktCbl-Intw | Cablelabs | B.McKibben@CableLabs.com | Rel-8 | Maurice |  |  |  |
| 298 | 145.2.1 | Architecture PktCbl-Interwork | 160d? | 2007-02-05 A | 2007-09-14 A | 100% | 2007-02-05 | 2007-09-14 | 160d? | start no earlier than 2007-02-05 | S2 | 1280h | 1280h | PktCbl-Intw | Cablelabs | B.McKibben@CableLabs.com | Rel-8 | Maurice | 23.228 |  |  |
| 299 | 145.2.2 | CT1,CT3 PktCbl-Interwork | 255d? | 2007-03-26 A | 2008-03-14 A | 100% | 2007-03-26 | 2008-03-14 | 255d? | finish no earlier than 2008-03-15 | C1,C3 | 2040h | 2040h | PktCbl-Intw | Cablelabs | D.Hancock@ CableLabs.com | Rel-8 | Frederic | 24.229 |  |  |
| 300 | 145.3 | **IMS Enhancements for Security Requirements in Support of Cable Deployments** | 388d? | 2006-12-06 A | 2008-05-30 A | 100% | 2006-12-06 | 2008-05-30 | 388d? |  | S3,C1,C3,C4 | 11712h | 11712h | PktCbl-Sec | Cablelabs | s.dotson@cablelabs.com | Rel-8 | Dionisio |  |  |  |
| 301 | 145.3.1 | SA3 Aspects of PktCbl-Sec | 331d? | 2006-12-06 A | 2008-03-12 A | 100% | 2006-12-06 | 2008-03-12 | 331d? | finish no earlier than 2007-12-20 | S3 | 2648h | 2648h | PktCbl-Sec | Cablelabs | s.dotson@cablelabs.com | Rel-8 | Dionisio | 33.203, 33.210, 33.220 |  |  |
| 302 | 145.3.2 | CT1 Aspects of PktCbl-Sec | 310d? | 2007-03-26 A | 2008-05-30 A | 100% | 2007-03-26 | 2008-05-30 | 310d? | finish no earlier than 2008-06-06 | C1 | 2480h | 2480h | PktCbl-Sec | Cablelabs | D.Hancock@ CableLabs.com | Rel-8 | Frederic | 24.229 |  |  |
| 303 | 145.3.3 | CT3 Aspects of PktCbl-Sec | 180d? | 2007-03-26 A | 2007-11-30 A | 100% | 2007-03-26 | 2007-11-30 | 180d? | finish no earlier than 2008-03-15 | C3 | 1440h | 1440h | PktCbl-Intw | Cablelabs | D.Hancock@ CableLabs.com | Rel-8 | Gwiho | 29.163 | PCG-21 | CP-38 |
| 304 | 145.3.4 | CT4 Aspects of PktCbl-Sec | 255d? | 2007-03-26 A | 2008-03-14 A | 100% | 2007-03-26 | 2008-03-14 | 255d? | finish no earlier than 2008-03-14 | C4 | 2040h | 2040h | PktCbl-Sec | Cablelabs | D.Hancock@ CableLabs.com | Rel-8 | Kimmo | 29.228, 29.229, 23.008 |  |  |
| 305 | 146 | **Security Enhancements for IMS** | 643.3d? | 2006-09-19 A | 2009-03-06 A | 100% | 2006-09-19 | 2009-03-06 | 643.3d? |  | S3,C1,C4 | 18624h | 18624h | IMS-Sec | Ericsson | Bengt.Sahlin@ericsson.com | Rel-8 | Dionisio |  |  | SP-37 |
| 306 | 146.1 | Stage 2 for IMS-Sec | 466d? | 2007-03-01 A | 2008-12-11 A | 100% | 2007-03-01 | 2008-12-11 | 466d? | finish no earlier than 2008-12-11 | S3 | 3728h | 3728h | IMS-Sec | Ericsson | Bengt.Sahlin@ericsson.com | Rel-8 | Dionisio | 33.203, 33.141, 33.803 |  |  |
| 307 | 146.2 | CT1 part of Stage 3 for IMS-Sec | 392d? | 2006-09-19 A | 2008-12-05 A | 100% | 2006-09-19 | 2008-12-05 | 392d? | finish no earlier than 2008-12-05 | C1 | 3136h | 3136h | IMS-Sec | Ericsson |  | Rel-8 | Frederic |  | PCG-21 | CP-39 |
| 308 | 146.3 | CT4 part of Stage 3 for IMS-Sec | 457d? | 2007-06-07 A | 2009-03-06 A | 100% | 2007-06-07 | 2009-03-06 | 457d? | finish no earlier than 2009-03-06 | C4 | 3656h | 3656h | IMS-Sec | Ericsson |  | Rel-8 | Kimmo |  | PCG-21 | CP-39 |
| 309 | 146.4 | CT1 part of NASS Bundled Authentication | 343d? | 2007-11-14 A | 2009-03-06 A | 100% | 2007-11-14 | 2009-03-06 | 343d? | finish no earlier than 2009-03-06 | C1 | 2744h | 2744h | NBA | Alcatel-Lucent | Keith Drage (drage@alcatel-lucent.com) | Rel-8 | Frederic | 24.229 | PCG-21 | CP-39 |
| 310 | 146.5 | CT4 part of NASS Bundled Authentication | 143d? | 2007-11-14 A | 2008-05-30 A | 100% | 2007-11-14 | 2008-05-30 | 143d? | start no earlier than 2007-11-14 | C4 | 1144h | 1144h | NBA-CT4 | Alcatel-Lucent |  | Rel-8 | Kimmo | 29.229, 29.228, 23.008 | PCG-21 | CP-39 |
| 311 | 147 | IMS initiated and controlled PSS and MBMS User Service | 262d? | 2008-03-12 A | 2009-03-12 A | 100% | 2008-03-12 | 2009-03-12 | 262d? | finish no earlier than 2009-03-12 | S4,S3 | 1003.2h | 1003.2h | IMS_PSS_MBMS_US | FT, Ericsson | olle.franceschi@ericsson.com | Rel-8 | Paolo | 26.237, 26.234, 26.346, 33.246 |  |  |
| 312 | 148 | **Multimedia interworking between IMS and CS networks** | 836d? | 2005-09-23 A | 2008-12-05 A | 100% | 2005-09-23 | 2008-12-05 | 836d? |  | C3,C4 | 16112h | 16112h | MIW-IMS | Vodafone | nico.gabriele@vodafone.com | Rel-8 | Gwiho |  |  |  |
| 313 | 148.1 | Note: Stages 1 and 2 defined in earlier Release | 49d? | 2005-09-23 A | 2005-11-30 A | 100% | 2005-09-23 | 2005-11-30 | 49d? | start no earlier than 2005-09-23 | S2 | 392h | 392h | MIW-IMS | Vodafone | nico.gabriele@vodafone.com | Rel-8 | Maurice |  |  |  |
| 314 | 148.2 | Stage 3 of MW-IMS | 571d? | 2005-09-23 A | 2007-11-30 A | 100% | 2005-09-23 | 2007-11-30 | 571d? | finish no earlier than 2007-09-14 | C3 | 4568h | 4568h | MIW-IMS-St3 | Vodafone | nico.gabriele@vodafone.com | Rel-8 | Gwiho | 29.863, 29.163 |  |  |
| 315 | 148.3 | Stage 3 for MW-IMS, MONA extension | 285d? | 2007-11-05 A | 2008-12-05 A | 100% | 2007-11-05 | 2008-12-05 | 285d? | finish no earlier than 2008-12-05 | C3 | 2280h | 2280h | MIW-IMS | Vodafone | Christer.Holmberg@ericsson.com | Rel-8 | Gwiho | 29.863, 29.163 | PCG-21 | CP-38 |
| 316 | 148.4 | Mn interface (MGCF – IM MGW) | 273d? | 2007-11-21 A | 2008-12-05 A | 100% | 2007-11-21 | 2008-12-05 | 273d? | finish no earlier than 2008-12-19 | C4 | 2184h | 2184h | MIW-IMS | Vodafone | Christer.Holmberg@ericsson.com | Rel-8 | Kimmo | 29.332 | PCG-21 | CP-38 |
| 317 | 149 | IMS Stage 3 IETF Protocol Alignment | 446d? | 2007-06-22 A | 2009-03-06 A | 100% | 2007-06-22 | 2009-03-06 | 446d? | finish no earlier than 2009-03-06 | C1 | 3568h | 3568h | IMSProtoc2 | Alcatel-Lucent | Keith Drage (drage@alcatel-lucent.com) | Rel-8 | Frederic | 23.218, 24.229, 24.930 |  |  |

Notes:
- 293: CP#40 completed
- 294: CP#40 completed
- 295: SP#38 completed
- 296: CP#40 completed
- 297: CP#39 completed
- 298: SP#37 completed
- 299: CP#39 completed
- 300: CP#40 completed
- 301: SP#39 completed
- 302: CP#40 completed
- 303: CP#38 completed
- 304: CP#39 completed
- 305: CP#43 completed. SP#36 WID approved
- 306: SP#42 completed. SP#46 withdrawn draft 33.178-100 and 33.978 from Rel-8 onwards
- 307: CP#42 completed
- 308: CP#43 completed
- 309: CP#43 completed
- 310: CP#40 completed
- 311: SP#43 completed. SP#39 WID approved
- 312: CP#42 completed
- 313: SP#31 Moved from FS section Feb 2006
- 314: Moved from R7 WP because it is part of Feature UID_713024. This feature was extended to R8 by the inclusion (at Nov 2007 CT3 meeting) of Stage 3 covering MONA (WI 380021)
- 315: CP#42 completed
- 316: CP#42 completed
- 317: CP#43 completed

| ID | WBS | Task | Duration | Start | Finish | Complete | Remaining | Baseline start | Baseline finish | Baseline duration | Total slack | Constraint | Resources | Work | Actual work | Text1 | Text2 | Text4 | Text5 | Text6 | Text7 | Text8 | Text11 |
| --- | --- | --- | --- | --- | --- | --- | --- | --- | --- | --- | --- | --- | --- | --- | --- | --- | --- | --- | --- | --- | --- | --- | --- |
| 318 | 150 | **Interworking between User-to-User Signalling (UUS) and SIP** | 335d? | 2007-11-30 A | 2009-03-12 A | 100% |  | 2007-11-30 | 2009-03-12 | 335d? |  |  | C1,C3 | 7488h | 7488h | UUSIW | PCG-21 | Huawei | Lili Yang (kadyyang@huawei.com) | Rel-8 | CP-38 | Kimmo |  |
| 319 | 150.1 | Stage 3 MGCF UUSIW | 266d? | 2007-11-30 A | 2008-12-05 A | 100% |  | 2007-11-30 | 2008-12-05 | 266d? |  | finish no earlier than 2008-12-05 | C1 | 2128h | 2128h | UUSIW | PCG-21 | Huawei | Lili Yang (kadyyang@huawei.com) | Rel-8 | CP-38 | Frederic |  |
| 320 | 150.2 | Stage 3 MGCF UUSIW | 335d? | 2007-11-30 A | 2009-03-12 A | 100% |  | 2007-11-30 | 2009-03-12 | 335d? |  | finish no earlier than 2009-03-12 | C3 | 2680h | 2680h | UUSIW | PCG-21 | Huawei | Lili Yang (kadyyang@huawei.com) | Rel-8 | CP-38 | Gwiho |  |
| 321 | 151 | **Support of Overlap signalling** | 331d? | 2007-11-30 A | 2009-03-06 A | 100% |  | 2007-11-30 | 2009-03-06 | 331d? |  |  | C3,C1,C4 | 10008.2h | 10008.2h | Overlap | PCG-21 | Deutsche Telekom | r.jesske@telekom.de | Rel-8 | CP-38 | Gwiho |  |
| 322 | 151.1 | Stage 3 Overlap (CT1) | 331d? | 2007-11-30 A | 2009-03-06 A | 100% |  | 2007-11-30 | 2009-03-06 | 331d? |  | finish no earlier than 2009-03-06 | C1 | 2648h | 2648h | Overlap | PCG-21 | Deutsche Telekom | r.jesske@telekom.de | Rel-8 | CP-38 | Frederic |  |
| 323 | 151.2 | Stage 3 Overlap (CT3) | 331d? | 2007-11-30 A | 2009-03-06 A | 100% |  | 2007-11-30 | 2009-03-06 | 331d? |  | finish no earlier than 2009-03-06 | C3 | 2648h | 2648h | Overlap | PCG-21 | Deutsche Telekom | r.jesske@telekom.de | Rel-8 | CP-38 | Gwiho |  |
| 324 | 151.3 | Stage 3 Overlap (CT4) | 258.02d? | 2007-11-30 A | 2008-12-05 A | 100% |  | 2007-11-30 | 2008-12-05 | 258.02d? |  | start no earlier than 2007-11-30 | C4 | 2064.16h | 2064.16h | Overlap | PCG-21 | Deutsche Telekom | r.jesske@telekom.de | Rel-8 | CP-38 | Kimmo |  |
| 325 | 152 | AS/MRFC Stage 2 and 3 | 278d? | 2007-11-14 A | 2008-12-05 A | 100% |  | 2007-11-14 | 2008-12-05 | 278d? |  | finish no earlier than 2008-12-05 | C1 | 2224h | 2224h | MRFC_TS | PCG-21 | HP | mark.syrett@hp.com | Rel-8 | CP-38 | Frederic |  |
| 326 | 153 | **IMS Restoration Procedures** | 201d? | 2008-05-30 A | 2009-03-06 A | 100% |  | 2008-05-30 | 2009-03-06 | 201d? |  |  | C4,C1 | 4824h | 4824h | IMS_RP | PCG-21 | Ericsson | german.blanco@ericsson.com | Rel-8 | SP-40 | Kimmo |  |
| 327 | 153.1 | IMS Restoration Procedures | 201d? | 2008-05-30 A | 2009-03-06 A | 100% |  | 2008-05-30 | 2009-03-06 | 201d? |  | finish no earlier than 2009-03-06 | C4 | 1608h | 1608h | IMS_RP | PCG-21 | Ericsson | german.blanco@ericsson.com | Rel-8 | SP-40 | Kimmo |  |
| 328 | 153.2 | IMS Restoration Procedures | 201d? | 2008-05-30 A | 2009-03-06 A | 100% |  | 2008-05-30 | 2009-03-06 | 201d? |  | finish no earlier than 2009-03-06 | C1 | 1608h | 1608h | IMS_RP | PCG-21 | Ericsson | german.blanco@ericsson.com | Rel-8 | SP-40 | Frederic |  |
| 329 | 154 | IMS Application Server Service Data Descriptions for AS interoperability | 125d? | 2008-09-12 A | 2009-03-06 A | 100% |  | 2008-09-12 | 2009-03-06 | 125d? |  | finish no earlier than 2009-03-06 | C4 | 1000h | 1000h | IMS_ASIO | PCG-21 | Alcatel-Lucent | nhberry@alcatel-lucent.com | Rel-8 | CP-41 | Kimmo |  |
| 330 | 155 | **Mobility between 3GPP-WLAN Interworking and 3GPP Systems** | 386d? | 2007-09-14 A | 2009-03-06 A | 100% |  | 2007-09-14 | 2009-03-06 | 386d? |  |  | S2,C1 | 6216h | 6216h | IWLAN_Mob |  | Orange | xiaobao.chen@orange-ftgroup.com | Rel-8 | SP-37 | Maurice |  |
| 331 | 155.1 | Stage 2: I-WLAN Mobility | 190d? | 2007-09-14 A | 2008-06-05 A | 100% |  | 2007-09-14 | 2008-06-05 | 190d? |  | finish no earlier than 2008-09-08 | S2 | 1520h | 1520h | IWLAN_Mob | PCG-21 | Orange | xiaobao.chen@orange-ftgroup.com | Rel-8 | SP-38 | Maurice |  |
| 332 | 155.2 | CT1 aspects of I-WLAN Mobility | 201d? | 2008-05-30 A | 2009-03-06 A | 100% |  | 2008-05-30 | 2009-03-06 | 201d? |  | finish no earlier than 2009-03-06 | C1 | 1608h | 1608h | IWLAN_Mob | PCG-21 | Orange | reina.nader@orange-ftgroup.com | Rel-8 | CP-40 | Frederic |  |
| 333 | 156 | Conformance Test Aspects – Mobility between 3GPP WLAN Interworking and 3GPP Systems | 131d? | 2009-12-04 | 2010-06-04 |  |  | 2009-12-04 | 2010-06-04 | 131d? | 335d | finish no earlier than 2010-06-04 | R5 | 1048h |  | IWLAN_Mob_UEConfTest | PCG-24 | Qualcomm Europe | Patrick Stupar (pstupar@qualcomm.com) | Rel-8 | RP-46 |  |  |
| 334 | 157 | eCall data transfer Phase 2: Comparison of alternative in-band modem solutions and standardization of one in-band modem solution | 472d? | 2007-12-06 A | 2009-09-24 A | 100% |  | 2007-12-06 | 2009-09-24 | 472d? |  | finish no earlier than 2009-09-24 | S4 | 3768.09h | 3768.09h | eCall_Phase2 |  | Airbiquity | lhong@airbiquity.com & rrobinson@airbiquity.com | Rel-8 |  | Paolo |  |
| 335 | 158 | eCall Conformance Testing | 181d? | 2009-09-04 A | 2010-05-14 | 45% | 99.55d? | 2009-09-04 | 2010-05-14 | 181d? | 350d | finish no earlier than 2010-05-14 | G3new | 1448h | 651.6h | eCall_MSTest | PCG-23 | Ericsson, Qualcomm Europe | Vikrant Jain (vikrantj@qualcomm.com) | Rel-8 | GP-45 | Ingbert |  |
| 336 | 159 | Conformance Test Aspects – non-modem procedures of eCall sessions in UTRA | 126d? | 2009-09-18 A | 2010-03-12 | 15% | 107.1d? | 2009-09-18 | 2010-03-12 | 126d? | 395d | finish no earlier than 2010-03-12 | R5 | 1008h | 151.2h | UMTS_eCall_UEConTest | PCG-23 | Ericsson, Qualcomm Europe | Shubhang Vora (svora@qualcomm.com) | Rel-8 | RP-45 | Ingbert | RP-091076 |
| 337 | 160 | Conformance Test Aspects – UMTS Earthquake and Tsunami Warning System (ETWS) FDD | 207d? | 2009-05-29 A | 2010-03-12 | 8% | 190.44d? | 2009-05-29 | 2010-03-12 | 207d? | 395d | finish no earlier than 2010-03-12 | R5 | 1656h | 132.48h | ETWS_UMTS_UEConTestFDD | PCG-23 | NTT DoCoMo | Makoto Ito (itohm@nttdocomo.co.jp) | Rel-8 | RP-44 | Ingo | RP-091070 |
| 338 | 161 | **UTRA HNB** | 326d? | 2008-03-07 A | 2009-06-04 A | 100% |  | 2008-03-07 | 2009-06-04 | 326d? |  |  | RP,S5 | 6832h | 6832h | HNB | PCG-21 |  |  | Rel-8 | SP-39 | Issam |  |
| 339 | 161.1 | Support of UTRA HNB | 201d? | 2008-05-30 A | 2009-03-06 A | 100% |  | 2008-05-30 | 2009-03-06 | 201d? |  | finish no earlier than 2009-03-06 | R2 | 1608h | 1608h | HNB-supp | PCG-21 | Huawei | Yang Xudong (yangxudong@huawei.com) | Rel-8 | SP-40 | Joern | RP-090040 |
| 340 | 161.2 | FDD Home NodeB RF requirements | 261d? | 2008-03-07 A | 2009-03-06 A | 100% |  | 2008-03-07 | 2009-03-06 | 261d? |  | finish no earlier than 2009-03-06 | R4 | 2088h | 2088h | HNB-RF | PCG-21 | Motorola | Ying Cai (yingcai@motorola.com) | Rel-8 | SP-39 | Issam | RP-090041 |
| 341 | 161.3 | UTRAN Architecture for 3G HNB | 136d? | 2008-05-30 A | 2008-12-05 A | 100% |  | 2008-05-30 | 2008-12-05 | 136d? |  | finish no earlier than 2008-12-05 | R3 | 1088h | 1088h | HNB-arch | PCG-21 | Alcatel-Lucent | Martin Warner (mw15@alcatel-lucent.com) | Rel-8 | SP-40 | Juha | RP-090042 |
| 342 | 161.4 | 3G Home NodeB OAM&P Type 1 Management Interface | 127d? | 2008-12-11 A | 2009-06-04 A | 100% |  | 2008-12-11 | 2009-06-04 | 127d? |  | finish no earlier than 2009-06-04 | S5 | 1008h | 1008h | HNB-3G_OAM | PCG-22 | Huawei | Zou Lan (zlan@huawei.com) | Rel-8 | SP-42 | Dionisio |  |

Notes:
- 318: CP#43 completed
- 319: CP#42 completed / Text3: 24.279, 24.229
- 320: Depending on IETF draft. CP#43 completed / Text3: 29.163
- 321: CP#43 completed
- 322: CP#43 completed / Text3: 24.229
- 323: CP#43 completed / Text3: 29.163
- 324: CP#42 completed / Text3: 29.228, 29.229
- 325: CP#42 completed. Triggered by Study UID_7048 (MRFC) / Text3: 23.218, 24.229, 24.147, 24.247
- 326: CP#43 completed. CP#41 WID updated CP-080281=>CP-080447. Triggered by Study TR 23.820 (FS_IMS_RP) UID_350018
- 327: CP#43 completed / Text3: 23.380, 29.228, 29.229, 29.230, 23.008
- 328: CP#43 completed / Text3: 24.229
- 329: CP#43 completed. Triggered by UID_360030 (FS_IMS_ASIO) / Text3: 29.328, 29.329, 29.364
- 330: CP#43 completed. SP#40 Stage 2 completed
- 331: SP#40 completed / Text3: 23.327
- 332: CP#43 completed / Text3: 24.327, 24.303
- 333: Testing for Rel-8 UID_400013 CT1 aspects of mobility between 3GPP WLAN Interworking and 3GPP Systems (24.327) / Text3: 34.108, 34.123-1, 34.123-2, 34.123-3
- 334: SP#45 completed. TR 26.969 for Approval. Triggered by Study UID_360015 (eCALLIBMS). Linked to SA1 Feature UID_330005 (EData) / Text3: 26.267, 26.268, 26.269, 26.967, 26.969
- 335: GP#43 WID approved. Testing for Rel-8 eCall_Phase2 (UID_34042) and EData (UID_330005) / Text3: 51.010-1, 51.010-2
- 336: RP#45 testing for Rel-8 eCall_Phase2 (UID_34042) and Edata (UID_330005) / Text3: 34.108, 34.123-1, 34.123-2, 34.123-3
- 337: Testing for Rel-8 ETWS UID_370051 / Text3: 34.108, 34.123-1, 34.123-2, 34.123-3
- 338: RP#43 completed. SP#44 completed
- 339: RP#43 completed. RP#41 WID updated RP-080483=>RP-080752. / Text3: 25.304, 25.306, 25.331, 25.367
- 340: RP#43 completed / Text3: 25.104, 25.141, 25.967
- 341: RP#42 completed / Text3: 25.401, 25.410, 25.412, 25.413, 25.414, 25.415, 25.467, 25.468, 25.469
- 342: SP#44 completed. Complements work in BroadBand Forum / Text3: 32.581, 32.582, 32.583, 32.584

| ID | WBS | Task | Duration | Start | Finish | Complete | Remaining | Baseline start | Baseline finish | Baseline duration | Total slack | Constraint | Resources | Work | Actual work | Text1 | Text2 | Text6 | Text7 | Text8 | Text4 | Text11 | Text9 | Text12 |
| --- | --- | --- | --- | --- | --- | --- | --- | --- | --- | --- | --- | --- | --- | --- | --- | --- | --- | --- | --- | --- | --- | --- | --- | --- |
| 343 | 162 | **UTRA HNB – UE Conformance Testing** | 327d? | 2009-03-06 A | 2010-06-04 | 60% | 130.8d? | 2009-03-06 | 2010-06-04 | 327d? | 335d |  | R5 | 5224h | 3134.4h | HNB-UEConTest | PCG-22 | Rel-8 | RP-43 | Ingbert |  |  |  |  |
| 344 | 162.1 | Conformance Test Aspects – UTRA HNB (FDD) | 326d? | 2009-03-06 A | 2010-06-04 | 60% | 130.4d? | 2009-03-06 | 2010-06-04 | 326d? | 335d | finish no earlier than 2010-06-04 | R5 | 2608h | 1564.8h | HNB-UEConTestFDD | PCG-22 | Rel-8 | RP-43 | Ingbert | Huawei | RP-091065 |  |  |
| 345 | 163 | Lawful Interception in the 3GPP Rel-8 | 524d? | 2007-03-12 A | 2009-03-12 A | 100% |  | 2007-03-12 | 2009-03-12 | 524d? |  | finish no earlier than 2009-03-12 | S3 | 4192h | 4192h | LI8 |  | Rel-8 |  | Dionisio | BMWI, Verizon |  |  |  |
| 346 | 164 | **Generic Bootstrapping Architecture Push Function** | 258d? | 2008-03-12 A | 2009-03-06 A | 100% |  | 2008-03-12 | 2009-03-06 | 258d? |  |  | S3,C1,C4 | 6468.8h | 6468.8h | GBAPush | PCG-21 | Rel-8 | SP-39 | Dionisio | Ericsson |  |  |  |
| 347 | 164.1 | SA3 part of GBAPush (33.223) | 193d? | 2008-03-12 A | 2008-12-05 A | 100% |  | 2008-03-12 | 2008-12-05 | 193d? |  | finish no earlier than 2008-12-05 | S3 | 1544h | 1544h | GBAPush | PCG-21 | Rel-8 | SP-39 | Dionisio | Ericsson |  |  |  |
| 348 | 164.2 | CT1 part of GBAPush | 178.8d? | 2008-03-12 A | 2009-03-06 A | 100% |  | 2008-03-12 | 2009-03-06 | 178.8d? |  | finish no earlier than 2009-03-06 | C1 | 1430.4h | 1430.4h | GBAPush | PCG-21 | Rel-8 | SP-39 | Frederic | Ericsson |  |  |  |
| 349 | 164.3 | CT4 part of GBAPush | 178.8d? | 2008-03-12 A | 2009-03-06 A | 100% |  | 2008-03-12 | 2009-03-06 | 178.8d? |  | finish no earlier than 2009-03-06 | C4 | 1430.4h | 1430.4h | GBAPush | PCG-21 | Rel-8 | SP-39 | Kimmo | Ericsson |  |  |  |
| 350 | 165 | Requirements and Test methods for Wideband Terminals | 197d? | 2008-03-12 A | 2008-12-11 A | 100% |  | 2008-03-12 | 2008-12-11 | 197d? |  | start no earlier than 2008-03-12 | S4 | 1576h | 1576h | RETEM_WB_T |  | Rel-8 |  | Paolo | FT, Ericsson |  |  |  |
| 351 | 166 | Extending PSS and MBMS User Services for optimized Mobile TV | 266d? | 2007-12-06 A | 2008-12-11 A | 100% |  | 2007-12-06 | 2008-12-11 | 266d? |  | finish no earlier than 2008-12-11 | S4 | 2128h | 2128h | PSS_MBMS_OMTV |  | Rel-8 |  | Paolo | Ericsson |  |  |  |
| 352 | 167 | **Encoding formats, transport formats and media description signalling for interworking, QoE, and other enhancements to MTSI-MHI** | 331d? | 2007-12-06 A | 2009-03-12 A | 100% |  | 2007-12-06 | 2009-03-12 | 331d? |  |  | S4,C3,C1,C4 | 9640h | 9640h | MTSI_eMHI | PCG-21 | Rel-8 | SP-40 | Paolo | Ericsson, Qualcomm Europe |  |  |  |
| 353 | 167.1 | MTSI Video - Dynamic Rate Adaptation/Signalling of Image Size | 331d? | 2007-12-06 A | 2009-03-12 A | 100% |  | 2007-12-06 | 2009-03-12 | 331d? |  | finish no earlier than 2009-03-12 | S4 | 2648h | 2648h | MTSI_eMHI-DRASIS |  | Rel-8 |  | Paolo | Qualcomm Europe, Samsung |  |  |  |
| 354 | 167.2 | CT3 part of Enhancement of interworking between MTSI and CS networks | 201d? | 2008-05-30 A | 2009-03-06 A | 100% |  | 2008-05-30 | 2009-03-06 | 201d? |  | finish no earlier than 2009-03-06 | C3 | 1608h | 1608h | MTSI_eMHI | PCG-21 | Rel-8 | CP-40 | Gwiho | Huawei |  |  |  |
| 355 | 167.3 | CT1 part of Enhancement of interworking between MTSI and CS networks | 141d? | 2008-05-30 A | 2008-12-12 A | 100% |  | 2008-05-30 | 2008-12-12 | 141d? |  | start no earlier than 2008-05-30 | C1 | 1128h | 1128h | MTSI_eMHI | PCG-21 | Rel-8 | CP-40 | Frederic | Huawei |  |  |  |
| 356 | 167.4 | CT4 part of Enhancement of interworking between MTSI and CS networks | 201d? | 2008-05-30 A | 2009-03-06 A | 100% |  | 2008-05-30 | 2009-03-06 | 201d? |  | finish no earlier than 2009-03-06 | C4 | 1608h | 1608h | MTSI_eMHI | PCG-21 | Rel-8 | CP-40 | Kimmo | Huawei |  |  |  |
| 357 | 168 | **OAM&P 8** | 653d? | 2007-06-07 A | 2009-12-04 A | 100% |  | 2007-06-07 | 2009-12-04 | 653d? |  |  | S5,C1 | 43227.2h | 43227.2h | OAM8 |  | Rel-8 |  | Dionisio |  |  |  |  |
| 358 | 168.1 | **Network Infrastructure Management** | 653d? | 2007-06-07 A | 2009-12-04 A | 100% |  | 2007-06-07 | 2009-12-04 | 653d? |  |  | S5 | 19464h | 19464h | OAM8-NIM |  | Rel-8 |  | Dionisio |  |  |  |  |
| 359 | 168.1.1 | Telecom Management Methodology | 461d? | 2007-06-07 A | 2009-03-12 A | 100% |  | 2007-06-07 | 2009-03-12 | 461d? |  | finish no earlier than 2009-03-12 | S5 | 3688h | 3688h | OAM8 |  | Rel-8 |  | Dionisio | Ericsson |  |  |  |
| 360 | 168.1.2 | Advanced Alarming on Itf-N | 266d? | 2007-06-07 A | 2008-06-12 A | 100% |  | 2007-06-07 | 2008-06-12 | 266d? |  | finish no earlier than 2008-12-11 | S5 | 2128h | 2128h | OAM8 |  | Rel-8 |  | Dionisio | Nokia Siemens Networks |  |  |  |
| 361 | 168.1.3 | CN CS Bearer Transport Network (BTN) relative NRM | 266d? | 2007-06-07 A | 2008-06-12 A | 100% |  | 2007-06-07 | 2008-06-12 | 266d? |  | finish no earlier than 2008-12-11 | S5 | 2128h | 2128h | OAM8 |  | Rel-8 |  | Dionisio | China Mobile |  |  |  |
| 362 | 168.1.4 | Alignment with eTOM and M.3060 architectural concepts | 210d? | 2008-02-22 A | 2008-12-11 A | 100% |  | 2008-02-22 | 2008-12-11 | 210d? |  | start no earlier than 2008-02-22 | S5 | 1680h | 1680h | OAM8 | PCG-21 | Rel-8 | SP-39 | Dionisio | TeliaSonera |  |  |  |
| 363 | 168.1.5 | IRP SOAP Solution Sets | 201d? | 2008-06-05 A | 2009-03-12 A | 100% |  | 2008-06-05 | 2009-03-12 | 201d? |  | finish no earlier than 2009-03-12 | S5 | 1608h | 1608h | OAM8 | PCG-21 | Rel-8 | SP-40 | Dionisio | Ericsson |  |  |  |
| 364 | 168.1.6 | Create missing specifications for IRP XML definitions | 52d? | 2009-09-24 A | 2009-12-04 A | 100% |  | 2009-09-24 | 2009-12-04 | 52d? |  | finish no earlier than 2010-03-12 | S5 | 416h | 416h | OAM8 | PCG-23 | Rel-8 | SP-45 | Dionisio | ZTE |  |  |  |
| 365 | 168.1.7 | Deleted - End point modelling for reference point | 324d? | 2007-09-17 A | 2008-12-11 A | 100% |  | 2007-09-17 | 2008-12-11 | 324d? |  | finish no earlier than 2008-12-11 | S5 | 2592h | 2592h | OAM8 |  | Rel-8 | SP-37 | Dionisio | Motorola |  | PCG-21 | SP-41 |
| 366 | 168.2 | **Performance Management** | 461d? | 2007-06-07 A | 2009-03-12 A | 100% |  | 2007-06-07 | 2009-03-12 | 461d? |  |  | S5 | 13712h | 13712h | OAM8-PM |  | Rel-8 |  | Dionisio |  |  |  |  |
| 367 | 168.2.1 | IP bearer network Performance measurement definitions | 396d? | 2007-06-07 A | 2008-12-11 A | 100% |  | 2007-06-07 | 2008-12-11 | 396d? |  | finish no earlier than 2008-12-11 | S5 | 3168h | 3168h | OAM8 |  | Rel-8 |  | Dionisio | China Mobile |  |  |  |
| 368 | 168.2.2 | HSUPA performance measurements | 396d? | 2007-06-07 A | 2008-12-11 A | 100% |  | 2007-06-07 | 2008-12-11 | 396d? |  | finish no earlier than 2008-12-11 | S5 | 3168h | 3168h | OAM8 |  | Rel-8 |  | Dionisio | China Mobile |  |  |  |
| 369 | 168.2.3 | Key Performance Indicators (KPIs) for UMTS and GSM | 461d? | 2007-06-07 A | 2009-03-12 A | 100% |  | 2007-06-07 | 2009-03-12 | 461d? |  | finish no earlier than 2009-03-12 | S5 | 3688h | 3688h | OAM8 |  | Rel-8 |  | Dionisio | China Mobile |  |  |  |

Notes:
- 343: Testing for Feature UID_390033 UTRA HNB
- 344: RP#46 completion 12/09=>06/10 / Text3: 34.108, 34.123-1, 34.123-2, 34.123-3 / Text5: Trica Li (trica_li@huawei.com)
- 345: SP#43 completed / Text3: 33.106, 33.107, 33.108 / Text5: berthold.wilhelm@bnetza.de, ron_ryan@verizon.net
- 346: CP#43 completed / Text5: Rolf Blom
- 347: SP#42 completed 33.223 as Rel-8. TS 33.224 moved to Rel-9 under new UID_420039 / Text3: 33.223 / Text5: Rolf Blom
- 348: CP#43 completed / Text3: 24.109 / Text5: Rolf Blom
- 349: CP#43 completed / Text3: 29.109 / Text5: Rolf Blom
- 350: SP#42 completed. SP#39 WID approved. / Text3: 26.131, 26.132 / Text5: stephane.ragot@orange-ftgroup.com, wanqing.shi@sonyericsson.com
- 351: SP#42 completed. SP#38 WID approved. / Text3: 26.234, 26.346, 26.946 / Text5: thorsten.lohmar@ericsson.com
- 352: TSG#43 completed / Text5: olle.franceschi@ericsson.com, nleung@qualcomm.com
- 353: SP#43 completed. SP#40 WID updated SP-070755=>SP-080246. [Feature=>BB under new Feature UID_400028 (MTSI)] / Text3: 26.114 / Text5: nleung@qualcomm.com & kyunghun.jung@samsung.com
- 354: CP#43 completed / Text3: 29.163 / Text5: Tingfang Tang (tagna_online@huawei.com)
- 355: CP#42 completed (No CT1-impact). WID updated CP-080422=>CP-080774 / Text5: Tingfang Tang (tagna_online@huawei.com)
- 356: CP#43 completed / Text3: 29.332 / Text5: Tingfang Tang (tagna_online@huawei.com)
- 357: -
- 358: -
- 359: SP#43 completed / Text3: 32.155, 32.153 / Text5: thomas.tovinger@ericsson.com
- 360: SP#40 completed / Text3: 32.121, 32.122, 32.123 / Text5: SUERBAUM, Clemens
- 361: SP#40 completed / Text3: 32.632/3/5 / Text5: LI, Jian
- 362: SP#42 completed / Text3: 32.101/2, 32-series / Text5: Berggren, Tommy
- 363: SP#43 completed. WID updated SP-080276=>SP-090148 (removed the planned but not delivered new TSs 32.127, 32.327, 32.337, 32.357, 32.387, 32.397, 32.447) / Text3: 32.111-7, 32.617, 32.417, 32.367, 32.347, 32.111-1, 32.111-2, 32.111-3, 32.111-5, 32.307, 32.317, 32.341, 32.342, 32.343, 32.345, 32.361, 32.362, 32.363, 32.365, 32.411, 32.412, 32.413, 32.415, 32.611, 32.612, 32.613, 32.615, 32.625 / Text5: edwin.tse@ericsson.com
- 364: SP#46 completed. Create missing XML definitions specs for IRPs (Advanced Alarm Management, Communication Surveillance, Self-Configuration of Network Elements, Software Management) needed for implementation of Rel-8 Notification Log IRP (TS 32.33x) / Text3: new TS (32.125, 32.355, 32.505, 32.535), 32.150, 32.153, 32.335 / Text5: Shuqiang Huang (huangsq@zte.com.cn)
- 365: SP#41 Work stopped. Contributions related to E-UTRAN/EPC to be submitted to UID_380036 E-UTRAN NRM IRP/ UID_380037 EPC NRM IRP / Text3: 32.152, 32.62/3/4x, 32.73x / Text5: YAO, Yizhi
- 366: -
- 367: SP#42 completed. SP#36 WID updated SP-050319=>SP-070301 / Text3: 32.321/2/3/5 / Text5: lilianyuan@chinamobile.com
- 368: SP#42 completed / Text3: 32.405 / Text5: LI, Jian
- 369: SP#43 completed / Text3: 32.410 / Text5: Liang Shuangchun

| ID | WBS | Task | Type | Duration | Start | Finish | Complete | Baseline start | Baseline finish | Baseline duration | Total slack | Constraint | Resources | Work | Actual work | Text1 | Text6 | Text8 | Text4 | Text5 | Text2 | Text7 | Text9 | Text12 | Text11 |
| --- | --- | --- | --- | --- | --- | --- | --- | --- | --- | --- | --- | --- | --- | --- | --- | --- | --- | --- | --- | --- | --- | --- | --- | --- | --- |
| 370 | 168.3 | **Trace Management** |  | 196d? | 2008-03-07 A | 2008-12-05 A | 100% | 2008-03-07 | 2008-12-05 | 196d? |  |  | S5,C1,C3,C4 | 5777.6h | 5777.6h | OAM8-Trace | Rel-8 | Dionisio |  |  |  |  |  |  |  |
| 371 | 168.3.1 | Service Level Tracing in IMS |  | 196d? | 2008-03-07 A | 2008-12-05 A | 100% | 2008-03-07 | 2008-12-05 | 196d? |  | finish no earlier than 2008-12-05 | C1 | 1568h | 1568h | OAM8-Trace | Rel-8 | Frederic | Vodafone | peter.dawes@vodafone.com |  |  |  |  |  |
| 372 | 168.3.2 | Service Level Tracing in IMS |  | 175.4d? | 2008-03-07 A | 2008-12-05 A | 100% | 2008-03-07 | 2008-12-05 | 175.4d? |  | finish no earlier than 2008-12-05 | C3 | 1403.2h | 1403.2h | OAM8-Trace | Rel-8 | Gwiho | Vodafone | peter.dawes@vodafone.com | PCG-21 | CP-40 |  |  |  |
| 373 | 168.3.3 | Service Level Tracing in IMS |  | 175.4d? | 2008-03-07 A | 2008-12-05 A | 100% | 2008-03-07 | 2008-12-05 | 175.4d? |  | finish no earlier than 2008-12-05 | C4 | 1403.2h | 1403.2h | OAM8-Trace | Rel-8 | Frederic | Vodafone | peter.dawes@vodafone.com | PCG-21 | CP-40 |  |  |  |
| 374 | 169 | **Charging Management small Enhancements** |  | 716d? | 2006-03-16 A | 2008-12-11 A | 100% | 2006-03-16 | 2008-12-11 | 716d? |  |  | S5 | 12544h | 12544h | CH8 | Rel-8 | Dionisio |  |  |  |  |  |  |  |
| 375 | 169.1 | Online charging correlation |  | 457d? | 2006-03-16 A | 2007-12-14 A | 100% | 2006-03-16 | 2007-12-14 | 457d? |  | start no earlier than 2006-03-16 | S5 | 3656h | 3656h | CH8 | Rel-8 | Dionisio | Orange | Chahine, Rony |  |  |  |  |  |
| 376 | 169.2 | SMS online charging |  | 137d? | 2007-06-07 A | 2007-12-14 A | 100% | 2007-06-07 | 2007-12-14 | 137d? |  | finish no earlier than 2007-12-14 | S5 | 1096h | 1096h | CH8 | Rel-8 | Dionisio | Vodafone | WONG, Gavin |  |  |  |  |  |
| 377 | 169.3 | Introduce Online Charging from SMS-SC into the SMS Charging Specifications |  | 61d? | 2008-09-18 A | 2008-12-11 A | 100% | 2008-09-18 | 2008-12-11 | 61d? |  | finish no earlier than 2008-12-11 | S5 | 488h | 488h | CH8 | Rel-8 | Dionisio | Acision | Gebler, Erik - Acision [erik.gebler (at) acision.com] | PCG-21 | SP-41 |  |  |  |
| 378 | 169.4 | Deleted - WLAN Offline Charging |  | 244d? | 2008-01-07 A | 2008-12-11 A | 100% | 2008-01-07 | 2008-12-11 | 244d? |  | finish no earlier than 2008-12-11 | S5 | 1952h | 1952h | CH8 | Rel-8 | Dionisio | Alcatel-Lucent | GARDELLA, Maryse | PCG-21 | SP-38 | PCG-22 | SP-42 |  |
| 379 | 170 | **Conferencing enhancements for Mp interface** |  | 266d? | 2007-11-30 A | 2008-12-05 A | 100% | 2007-11-30 | 2008-12-05 | 266d? |  |  | C4 | 6384h | 6384h | eMp | Rel-8 | Kimmo | Huawei | Chencheng@huawei.com | PCG-21 |  |  |  |  |
| 380 | 170.1 | Stage 2 for eMp |  | 266d? | 2007-11-30 A | 2008-12-05 A | 100% | 2007-11-30 | 2008-12-05 | 266d? |  | finish no earlier than 2008-12-11 | C4 | 2128h | 2128h | eMp | Rel-8 | Kimmo | Huawei | Chencheng@huawei.com | PCG-21 | CP-38 |  |  |  |
| 381 | 170.2 | Stage 3 for eMp |  | 266d? | 2007-11-30 A | 2008-12-05 A | 100% | 2007-11-30 | 2008-12-05 | 266d? |  | finish no earlier than 2008-12-05 | C4 | 2128h | 2128h | eMp | Rel-8 | Kimmo | Huawei | Chencheng@huawei.com | PCG-21 | CP-38 |  |  |  |
| 382 | 171 | **Contact Manager for 3GPP UICC applications** |  | 642d? | 2006-06-22 A | 2008-12-05 A | 100% | 2006-06-22 | 2008-12-05 | 642d? |  |  | C6 | 13352h | 13352h | eUPHBOOK | Rel-8 | Xavier | Gemalto | Jacques.seif@gemalto.com |  |  |  |  |  |
| 383 | 171.1 | Requirements for Contact Manager |  | 392d? | 2006-06-22 A | 2007-12-21 A | 100% | 2006-06-22 | 2007-12-21 | 392d? |  | finish no earlier than 2007-12-21 | C6 | 3136h | 3136h | eUPHBOOK-St1 | Rel-8 | Xavier | Gemalto | Jacques.seif@gemalto.com |  |  |  |  |  |
| 384 | 171.2 | External interface for eUPHBOOK |  | 220d? | 2007-05-07 A | 2008-03-07 A | 100% | 2007-05-07 | 2008-03-07 | 220d? |  | finish no earlier than 2008-03-07 | C6 | 1760h | 1760h | eUPHBOOK-Ext_Spec | Rel-8 | Xavier | Gemalto | Jacques.seif@gemalto.com |  |  |  |  |  |
| 385 | 171.3 | Internal interface for eUPHBOOK |  | 415d? | 2007-05-07 A | 2008-12-05 A | 100% | 2007-05-07 | 2008-12-05 | 415d? |  | finish no earlier than 2008-12-05 | C6 | 3320h | 3320h | eUPHBOOK-Int_Spec | Rel-8 | Xavier | Gemalto | Jacques.seif@gemalto.com |  | CP-37 |  |  |  |
| 386 | 171.4 | Deleted - Implementation of eUPHBOOK | milestone | 0d? | 2007-06-21 A | 2007-06-21 A | 100% | 2007-06-21 | 2007-06-21 | 0d? |  | start no earlier than 2007-06-21 | C6 |  |  | eUPHBOOK-St23 | Rel-8 | Xavier | Giesecke & Devrient | Claus Dietze |  |  |  | SP-33 |  |
| 387 | 172 | **Contact Manager Conformance Test specifications** |  | 471d? | 2008-06-02 | 2010-03-19 |  | 2008-06-02 | 2010-03-19 | 471d? | 390d |  | C6 | 11304h |  | eUPHBOOK-Test | Rel-8 | Xavier | Comprion, Gemalto | Udo Willenbrink, Jacques Seif | PCG-21 | CP-40 |  |  |  |
| 388 | 172.1 | Contact Manager for 3GPP UICC applications test specifications |  | 471d? | 2008-06-02 | 2010-03-19 |  | 2008-06-02 | 2010-03-19 | 471d? | 390d | finish no earlier than 2010-03-19 | C6 | 3768h |  | eUPHBOOK-Test | Rel-8 | Xavier | Comprion | Udo Willenbrink | PCG-21 | CP-40 |  |  |  |
| 389 | 172.2 | Contact Manager API for Java™ Card test specification |  | 471d? | 2008-06-02 | 2010-03-19 |  | 2008-06-02 | 2010-03-19 | 471d? | 390d | finish no earlier than 2010-03-19 | C6 | 3768h |  | eUPHBOOK-Test | Rel-8 | Xavier | Gemalto | jacques.seif@gemalto.com | PCG-21 | CP-40 |  |  |  |
| 390 | 173 | **Rel-8 LTE – 3G Long Term Evolution - Evolved Packet System RAN part** |  | 644d? | 2006-09-25 A | 2009-03-12 A | 100% | 2006-09-25 | 2009-03-12 | 644d? |  |  | RP,S5 | 44896h | 44896h | LTE | Rel-8 |  | NTT DoCoMo | Takehiro Nakamura (nakamurata@nttdocomo.co.jp) |  |  |  |  | RP-080741 |
| 391 | 173.1 | LTE – Physical Layer |  | 380d? | 2006-09-25 A | 2008-03-07 A | 100% | 2006-09-25 | 2008-03-07 | 380d? |  | finish no earlier than 2007-09-14 | R1 | 3040h | 3040h | LTE-Phys | Rel-8 | Patrick | NTT DoCoMo | Sadayuki Abeta |  |  |  |  | RP-080741 |
| 392 | 173.2 | LTE – Radio Interface Layer 2 and 3 Protocol Aspect |  | 575d? | 2006-09-25 A | 2008-12-05 A | 100% | 2006-09-25 | 2008-12-05 | 575d? |  | finish no earlier than 2008-12-11 | R2 | 4600h | 4600h | LTE-L23 | Rel-8 | Joern | Nokia Siemens Networks | benoist.sebire@nokia.com |  |  |  |  | RP-080741 |
| 393 | 173.3 | LTE – eUTRAN Interfaces |  | 575d? | 2006-09-25 A | 2008-12-05 A | 100% | 2006-09-25 | 2008-12-05 | 575d? |  | finish no earlier than 2008-12-11 | R3 | 4600h | 4600h | LTE-interfaces | Rel-8 | Juha | Ericsson | Martin Israelsson |  |  |  |  | RP-080741 |
| 394 | 173.4 | LTE – Evolved UTRA and UTRAN RF Radio Transmission/Reception, System Performance Requirements and Conformance Testing |  | 575d? | 2006-09-25 A | 2008-12-05 A | 100% | 2006-09-25 | 2008-12-05 | 575d? |  | finish no earlier than 2008-12-11 | R4 | 4600h | 4600h | LTE-RF | Rel-8 | Issam | Nokia Siemens Networks | Tuomo Saynajakangas |  |  |  |  | RP-080741 |
| 395 | 173.5 | LTE – FDD repeaters |  | 386d? | 2007-09-14 A | 2009-03-06 A | 100% | 2007-09-14 | 2009-03-06 | 386d? |  | finish no earlier than 2009-03-06 | R4 | 3088h | 3088h | LTE-Repeaters | Rel-8 | Issam | Powerwave Technologies, Andrew Wireless | ralf.michanikl@andrew.com, Alf.Ahlstrom@pwav.com |  | RP-37 |  |  | RP-090037 |

Notes:
- 370: -
- 371: CP#42 completed. CP#40 WID updated CP-060521=>CP-080315. / Text3: 24.323, 24.229
- 372: CP#42 completed (No CT3-impact). CP#40 WID updated CP-060521=>CP-080315
- 373: CP#42 completed. CP#40 WID updated CP-060521=>CP-080315. / Text3: 29.228, 29.229
- 374: SP#42 completed.
- 375: SP#38 completed / Text3: 32.296
- 376: SP#38 completed / Text3: 32.274, 32.240/299
- 377: SP#42 completed. Linked to SA2 UID 32081 (Support of SMS over IP networks) and CT4 UID 340016 (Routeing of MT-SMS via the HPLMN). / Text3: 32.274, 32.299
- 378: SP#42 stopped / Text3: 32.252, 32.298, 32.299
- 379: CP#42 completed. WID updated CP-070868=>CP-080725
- 380: CP#42 completed. WID updated CP-070868=>CP-080725 / Text3: 23.333
- 381: CP#42 completed. WID updated CP-070868=>CP-080725 / Text3: 29.333
- 382: CP#42 completed. CP#40: WID updated CP-070622=>CP-080382. aka Enhanced USIM phonebook
- 383: CP#38 completed / Text3: 21.111
- 384: CP#39 completed / Text3: 31.220
- 385: CP#42 completed / Text3: 31.221
- 386: SP#33 stopped / Text3: 31.102
- 387: CP#46 work not started
- 388: CP#46 work not started / Text3: 31.320 (external interface for communication with the ME)
- 389: CP#46 work not started / Text3: 31.321 (internal interface (API))
- 390: RP#43 completed. Role model for SAE/LTE system wide project management by SA2 in SP-060166 / Text3: 36.300, 36.938
- 391: RP#39 completed / Text3: 36.201, 36.211, 36.212, 36.213, 36.214, 25.215, 25.225
- 392: RP#42 completed / Text3: 36.302, 36.304, 36.306, 36.314, 36.321, 36.322, 36.323, 36.331, 25.302, 25.304, 25.331
- 393: RP#42 completed / Text3: 36.401, 36.410, 36.411, 36.412, 36.413, 36.414, 36.420, 36.421, 36.422, 36.423, 36.424, 25.413
- 394: RP#42 completed / Text3: 36.101, 36.104, 36.113, 36.124, 36.133, 36.141, 36.942, 25.123, 25.133
- 395: RP#43 completed / Text3: 36.106, 36.143, 25.113

| ID | WBS | Task | Duration | Start | Finish | Complete | Baseline start | Baseline finish | Baseline duration | Constraint | Resources | Work | Actual work | Text1 | Text2 | Text6 | Text7 | Text8 | Text4 | Text5 | Text11 | Text9 | Text12 |
| --- | --- | --- | --- | --- | --- | --- | --- | --- | --- | --- | --- | --- | --- | --- | --- | --- | --- | --- | --- | --- | --- | --- | --- |
| 396 | 173.6 | **E-UTRAN Data Definitions** | 389d? | 2007-09-17 A | 2009-03-12 A | 100% | 2007-09-17 | 2009-03-12 | 389d? |  | S5 | 13096h | 13096h | E-UTRAN-OAM | PCG-21 | Rel-8 | SP-39 | Dionisio |  |  |  |  |  |
| 397 | 173.6.1 | Subscriber and Equipment Trace for E-UTRAN and EPC | 389d? | 2007-09-17 A | 2009-03-12 A | 100% | 2007-09-17 | 2009-03-12 | 389d? | finish no earlier than 2009-03-12 | S5 | 3112h | 3112h | E-UTRAN-OAM |  | Rel-8 | SP-37 | Dionisio | Ericsson | PETERSEN, Robert |  |  |  |
| 398 | 173.6.2 | E-UTRAN Network Resource Model (NRM) Integration Reference Point (IRP) | 309d? | 2008-01-07 A | 2009-03-12 A | 100% | 2008-01-07 | 2009-03-12 | 309d? | finish no earlier than 2009-03-12 | S5 | 2472h | 2472h | E-UTRAN-OAM | PCG-21 | Rel-8 | SP-38 | Dionisio | Ericsson | ELMDAHL, Per |  |  |  |
| 399 | 173.6.3 | Performance measurements for E-UTRAN | 275d? | 2008-02-22 A | 2009-03-12 A | 100% | 2008-02-22 | 2009-03-12 | 275d? | finish no earlier than 2009-03-12 | S5 | 2200h | 2200h | E-UTRAN-OAM | PCG-21 | Rel-8 | SP-39 | Dionisio | Motorola, Huawei | YAO, Yizhi |  |  |  |
| 400 | 173.6.4 | Key Performance Indicators (KPIs) for E-UTRAN | 275d? | 2008-02-22 A | 2009-03-12 A | 100% | 2008-02-22 | 2009-03-12 | 275d? | finish no earlier than 2009-03-12 | S5 | 2200h | 2200h | E-UTRAN-OAM | PCG-21 | Rel-8 | SP-39 | Dionisio | Ericsson | HÜBINETTE, Ulf |  |  |  |
| 401 | 173.7 | **Self-Organizing Networks (SON)** | 210d? | 2008-02-22 A | 2008-12-11 A | 100% | 2008-02-22 | 2008-12-11 | 210d? |  | S5 | 6720h | 6720h | LTE_SON-OAM | PCG-21 | Rel-8 | SP-39 | Dionisio | Vodafone | GOMPAKIS, Panagiotis |  |  |  |
| 402 | 173.7.1 | SON Concepts and requirements | 210d? | 2008-02-22 A | 2008-12-11 A | 100% | 2008-02-22 | 2008-12-11 | 210d? |  | S5 | 1680h | 1680h | LTE_SON-OAM | PCG-21 | Rel-8 | SP-39 | Dionisio | Vodafone | GOMPAKIS, Panagiotis |  |  |  |
| 403 | 173.7.2 | Self-Establishment of eNBs, including automated Software Management | 210d? | 2008-02-22 A | 2008-12-11 A | 100% | 2008-02-22 | 2008-12-11 | 210d? | start no earlier than 2008-02-22 | S5 | 1680h | 1680h | LTE_SON-OAM | PCG-21 | Rel-8 | SP-39 | Dionisio | Nokia Siemens Networks | SUERBAUM, Clemens |  |  |  |
| 404 | 173.7.3 | SON Automatic Neighbour Relations (ANR) List Management | 210d? | 2008-02-22 A | 2008-12-11 A | 100% | 2008-02-22 | 2008-12-11 | 210d? | finish no earlier than 2008-12-11 | S5 | 1680h | 1680h | LTE_SON-OAM | PCG-21 | Rel-8 | SP-39 | Dionisio | Ericsson | edwin.tse@ericsson.com |  |  |  |
| 405 | 174 | **Rel-8 LTE – Terminal Conformance Test Specification** | 657d? | 2007-06-01 A | 2009-12-04 A | 100% | 2007-06-01 | 2009-12-04 | 657d? |  | R5 | 14336h | 14336h | LTE-UEConTest |  | Rel-8 |  | Ingbert |  |  |  |  |  |
| 406 | 174.1 | 3G LTE – Terminal Protocol Conformance Test Specifications | 657d? | 2007-06-01 A | 2009-12-04 A | 100% | 2007-06-01 | 2009-12-04 | 657d? | finish no earlier than 2009-12-04 | R5 | 5256h | 5256h | LTE-UEConTest_SIG |  | Rel-8 |  | Ingbert | NEC, Motorola | david.lecompte@nectech.fr, Jacob.John@motorola.com | RP-091060 |  |  |
| 407 | 174.2 | LTE – Terminal Radio Transmission and Reception Conformance Test Specifications | 657d? | 2007-06-01 A | 2009-12-04 A | 100% | 2007-06-01 | 2009-12-04 | 657d? |  | R5 | 5256h | 5256h | LTE-UEConTest_RF |  | Rel-8 |  | Ingbert | Agilent | andrea_leonardi@agilent.com | RP-091059 |  |  |
| 408 | 175 | **Rel-8 Improvements of the Radio Interface** | 525d? | 2007-03-05 A | 2009-03-06 A | 100% | 2007-03-05 | 2009-03-06 | 525d? |  | RP | 18152h | 18152h | RInImp8 |  | Rel-8 |  | Issam |  |  |  |  |  |
| 409 | 175.1 | UMTS 1500 MHz | 140d? | 2007-03-05 A | 2007-09-14 A | 100% | 2007-03-05 | 2007-09-14 | 140d? | finish no earlier than 2007-09-14 | R4 | 1120h | 1120h | RInImp8-UMTS1500 |  | Rel-8 |  | Issam | NTT DoCoMo | Takehiro Nakamura (nakamurata@nttdocomo.co.jp) | RP-070526 |  |  |
| 410 | 175.2 | UMTS 700 MHz FDD | 325d? | 2007-03-05 A | 2008-05-30 A | 100% | 2007-03-05 | 2008-05-30 | 325d? | finish no earlier than 2008-06-12 | R4 | 2600h | 2600h | RInImp8-UMTS700 |  | Rel-8 |  | Issam | Nokia | Tuomo Saynajakangas | RP-080260 |  |  |
| 411 | 175.3 | UMTS 2300 MHz TDD LCR | 195d? | 2007-12-17 A | 2008-09-12 A | 100% | 2007-12-17 | 2008-09-12 | 195d? | finish no earlier than 2008-09-12 | R4 | 1560h | 1560h | RInImp8-UMTS2300TDD | PCG-21 | Rel-8 | RP-38 | Issam | CATT | songyuexia@datangmobile.cn | RP-080517 |  |  |
| 412 | 175.4 | Further Improved Minimum Performance Requirements for HSDPA UE (FDD) - Two-Branch Interference Cancellation | 265d? | 2007-03-05 A | 2008-03-07 A | 100% | 2007-03-05 | 2008-03-07 | 265d? | finish no earlier than 2008-03-12 | R4 | 2120h | 2120h | RInImp8-2BIC |  | Rel-8 |  | Issam | AT&T | Marc Grant | RP-080041 |  |  |
| 413 | 175.5 | CS Voice Service over HSPA | 167d? | 2007-07-19 A | 2008-03-07 A | 100% | 2007-07-19 | 2008-03-07 | 167d? |  | R2 | 1336h | 1336h | RInImp8-CsHspa |  | Rel-8 | RP-37 | Joern | Nokia Siemens Networks | woonhee.hwang@nsn.com | RP-080042 |  |  |
| 414 | 175.6 | Performance requirements for 15 code reception with 16QAM/QPSK (FDD) | 126d? | 2007-06-11 A | 2008-03-07 A | 100% | 2007-06-11 | 2008-03-07 | 126d? | finish no earlier than 2008-06-12 | R4 | 1008h | 1008h | RInImp8-Hsdpa15codes |  | Rel-8 | RP-37 | Issam | Vodafone | tim.frost@vodafone.com | RP-080043 |  |  |
| 415 | 175.7 | UMTS 1880 MHz TDD | 126d? | 2008-09-12 A | 2009-03-06 A | 100% | 2008-09-12 | 2009-03-06 | 126d? | finish no earlier than 2009-03-09 | R4 | 1008h | 1008h | RInImp9-UMTS1880TDD | PCG-21 | Rel-8 | RP-41 | Issam | CATT | Yuexia Song (songyuexia@datangmobile.cn) | RP-090044 |  |  |
| 416 | 175.8 | Deleted - UMTS 2300 MHz FDD/TDD | 400d? | 2007-03-05 A | 2008-09-12 A | 100% | 2007-03-05 | 2008-09-12 | 400d? | finish no earlier than 2008-12-11 | R4 | 3200h | 3200h | RInImp8-UMTS2300 |  | Rel-8 |  | Issam | AT&T | Marc Grant | RP-080515 | PCG-21 | RP-41 |
| 417 | 176 | **Rel-8 Improvements of the Radio Interface - UE Conformance Testing** | 396d? | 2007-06-01 A | 2008-12-05 A | 100% | 2007-06-01 | 2008-12-05 | 396d? |  | R5 | 6256h | 6256h | RInImp-UEConTest |  | Rel-8 |  | Ingbert |  |  |  |  |  |
| 418 | 176.1 | Conformance Test Aspects – CS Voice Service over HSPA | 336d? | 2007-06-01 A | 2008-09-12 A | 100% | 2007-06-01 | 2008-09-12 | 336d? | finish no earlier than 2008-09-12 | R5 | 2688h | 2688h | RInImp8-CsHspa_UEConTest |  | Rel-8 |  | Ingbert | Huawei | baoyi@huawei.com | RP-080542 |  |  |
| 419 | 176.2 | Conformance Test Aspects – Performance requirements for 15 code reception with 16QAM/QPSK (FDD) | 195d? | 2008-03-07 A | 2008-12-05 A | 100% | 2008-03-07 | 2008-12-05 | 195d? | finish no earlier than 2008-12-05 | R5 | 1560h | 1560h | RInImp8-UEConTest_ Hsdpa15codes | PCG-21 | Rel-8 | RP-40 | Ingbert | Ericsson | Mikael.Ziren@Ericsson.com | RP-080818 |  |  |

Notes:
- 396: SP#43 completed
- 397: SP#43 completed / Text3: 32.42x, 32.44x
- 398: SP#43 completed / Text3: 32.761, 32.762, 32.763, 32.765
- 399: SP#43 completed / Text3: 32.425
- 400: SP#43 completed / Text3: 32.450, 32.451
- 401: SP#42 completed (WT UID_390007 moved to Rel-9). SP#40 updated WID SP-080064=>SP-080275.
- 402: SP#42 completed. SP#40 updated WID SP-080064=>SP-080275. SP#41 UID_390004 split to monitor 32.500 progress. / Text3: 32.500
- 403: SP#42 completed. WID updated SP-080065=>SP-080849 / Text3: 32.501, 32.502, 32.531, 32.532, 32.533
- 404: SP#42 completed / Text3: 32.511, 32.761, 32.762, 32.763, 32.765
- 405: Testing for Feature UID_20068 (LTE)
- 406: RP#46 completed / Text3: 36.521-1, 36.521-2, 36.508, 36.509, 36.523-1, 36.523-2, 36.523-3
- 407: RP#46 completed / Text3: 36.521-1, 36.521-2, 36.521-3
- 408: -
- 409: SR in RP-070526. Introduction of Band XI / Text3: 25.101, 25.104, 25.133, 25.141, 25.331, 25.942, 25.306, 25.307, 34.121
- 410: SR in RP-080260. Introduction of UMTS 700 MHz (Bands XII XIV) in 25.307 / Text3: 25.101, 25.104, 25.133, 25.141, 25.331, 25.942, 25.306, 25.307, 34.121
- 411: SR in RP-080517. RP#41 completed / Text3: 25.102, 25.105, 25.113, 25.123, 25.142, 34.124, 25.306, 25.331, 34.122
- 412: SR in RP-080041.
- 413: SR in RP-080042. / Text3: 25.323, 25.331, 25.322
- 414: SR in RP-080043. / Text3: 25.101
- 415: RP#43 completed as Rel-8 / Text3: 25.102, 25.105, 25.113, 25.123, 25.142, 34.124, 25.307
- 416: SR in RP-080515. RP#41 stopped / Text3: 25.101, 25.104, 25.133, 25.141, 25.331, 25.942, 25.306, 25.307, 34.121
- 417: 05/08: Linked to Feature UID_20028 (RInImp)
- 418: SR in RP-080542. RP#41 completed. / Text3: 34.108, 34.123-1, 34.123-2, 34.123-3
- 419: RP#42 completed. SR in RP-080818. Linked to UID_370033. / Text3: 34.121-1, 34.121-2

| ID | WBS | Task | Duration | Start | Finish | Complete | Remaining | Baseline start | Baseline finish | Baseline duration | Total slack | Constraint | Resources | Work | Actual work | Text1 | Text6 | Text4 | Text5 | Text8 | Text11 | Text7 | Text2 |
| --- | --- | --- | --- | --- | --- | --- | --- | --- | --- | --- | --- | --- | --- | --- | --- | --- | --- | --- | --- | --- | --- | --- | --- |
| 420 | 177 | **Rel-8 RAN improvements** | 520d? | 2007-06-04 A | 2009-05-29 A | 100% |  | 2007-06-04 | 2009-05-29 | 520d? |  |  | RP | 29776h | 29776h | RANimp | Rel-8 |  |  |  |  |  |  |
| 421 | 177.1 | Combination of 64QAM and MIMO for HSDPA (FDD) | 205d? | 2007-06-04 A | 2008-09-12 A | 100% |  | 2007-06-04 | 2008-09-12 | 205d? |  | finish no earlier than 2008-09-12 | R1 | 1640h | 1640h | RANimp-64QamMimoHsdpa | Rel-8 | Ericsson | Johan.Bergman@ericsson.com | Patrick | RP-080518 |  |  |
| 422 | 177.2 | Improved L2 for uplink | 186d? | 2007-09-14 A | 2008-05-30 A | 100% |  | 2007-09-14 | 2008-05-30 | 186d? |  | finish no earlier than 2008-05-30 | R2 | 1488h | 1488h | RANimp-UplinkL2dataRates | Rel-8 | Ericsson | Janne.Peisa@ericsson.com | Joern | RP-080265 | RP-37 |  |
| 423 | 177.3 | Enhanced Uplink for CELL_FACH State in FDD | 321d? | 2007-09-14 A | 2008-12-05 A | 100% |  | 2007-09-14 | 2008-12-05 | 321d? |  | finish no earlier than 2008-12-12 | R2 | 2568h | 2568h | RANimp-UplinkEnhState | Rel-8 | Nokia Siemens Networks | markus.wimmer@nsn.com | Joern | RP-080804 | RP-37 |  |
| 424 | 177.4 | Enhanced UE DRX for FDD | 261d? | 2007-09-14 A | 2008-09-12 A | 100% |  | 2007-09-14 | 2008-09-12 | 261d? |  | finish no earlier than 2008-09-12 | R2 | 2088h | 2088h | RANimp-DRX | Rel-8 | Nokia | luis.barreto@nokia.com | Joern | RP-080520 | RP-37 |  |
| 425 | 177.5 | Enhancements for SRNS Relocation Procedure | 261d? | 2007-09-14 A | 2008-09-12 A | 100% |  | 2007-09-14 | 2008-09-12 | 261d? |  | finish no earlier than 2008-09-12 | R3 | 2088h | 2088h | RANimp-SrnsReloc | Rel-8 | Nokia Siemens Networks | masatoshi.nakamata@nsn.com | Juha | RP-080521 | RP-37 |  |
| 426 | 177.6 | Enhancements for FDD HSPA Evolution | 321d? | 2007-09-14 A | 2008-12-05 A | 100% |  | 2007-09-14 | 2008-12-05 | 321d? |  | finish no earlier than 2008-12-05 | R3,R2 | 2568h | 2568h | RANimp-HSPAEvo | Rel-8 | Nokia Siemens Networks | masatoshi.nakamata@nsn.com | Juha | RP-080805 | RP-37 |  |
| 427 | 177.7 | 64QAM for 1.28 Mcps TDD HSDPA | 264d? | 2007-12-04 A | 2008-12-05 A | 100% |  | 2007-12-04 | 2008-12-05 | 264d? |  | finish no earlier than 2008-12-05 | R1 | 2112h | 2112h | RANimp-64Qam1.28TDD | Rel-8 | ZTE | zfmail@zte.com.cn | Patrick | RP-080806 | RP-38 | PCG-21 |
| 428 | 177.8 | Enhanced CELL_FACH state in 1.28 Mcps TDD | 264d? | 2007-12-04 A | 2008-12-05 A | 100% |  | 2007-12-04 | 2008-12-05 | 264d? |  | finish no earlier than 2008-12-12 | R2 | 2112h | 2112h | RANimp-EnhState1.28TDD | Rel-8 | ZTE | zhang.yincheng@zte.com.cn | Joern | RP-080807 | RP-38 | PCG-21 |
| 429 | 177.9 | Continuous Connectivity for packet data users for 1.28 Mcps TDD | 321d? | 2008-03-07 A | 2009-05-29 A | 100% |  | 2008-03-07 | 2009-05-29 | 321d? |  | finish no earlier than 2009-05-29 | R1 | 2568h | 2568h | RANimp-LCRCPC | Rel-8 | TD Tech | chenying@td-tech.com | Patrick | RP-090394 | RP-39 | PCG-21 |
| 430 | 177.10 | HSPA VoIP to WCDMA/GSM CS continuity | 261d? | 2008-03-07 A | 2009-03-06 A | 100% |  | 2008-03-07 | 2009-03-06 | 261d? |  | finish no earlier than 2009-03-06 | R2 | 2088h | 2088h | RANimp-HSPAVoIP | Rel-8 | Nokia | Simone.Provvedi@nokia.com | Joern | RP-090050 | RP-39 | PCG-21 |
| 431 | 177.11 | HS-DSCH Serving Cell Change Enhancements | 196d? | 2008-03-07 A | 2008-12-05 A | 100% |  | 2008-03-07 | 2008-12-05 | 196d? |  | finish no earlier than 2008-12-12 | R2 | 1568h | 1568h | RANimp-HSDSCH | Rel-8 | Ericsson | henrik.enbuske@ericsson.com | Joern | RP-080811 | RP-39 | PCG-21 |
| 432 | 177.12 | MIMO for 1.28 Mcps TDD | 201d? | 2007-11-01 A | 2009-03-06 A | 100% |  | 2007-11-01 | 2009-03-06 | 201d? |  | finish no earlier than 2009-05-29 | R1,R4 | 1608h | 1608h | RANimp-MIMOLCR | Rel-8 | CATT | wangke@datangmobile.cn | Patrick | RP-090313 | RP-40 | PCG-21 |
| 433 | 177.13 | Dual-Cell HSDPA operation on adjacent carriers | 140d? | 2008-05-30 A | 2008-12-11 A | 100% |  | 2008-05-30 | 2008-12-11 | 140d? |  | finish no earlier than 2009-05-29 | R1,R4 | 1120h | 1120h | RANimp-DCHSDPA | Rel-8 | Ericsson | johan.bergman@ericsson.com | Patrick | RP-080814 | RP-40 | PCG-21 |
| 434 | 178 | **Rel-8 RAN improvements - UE Conformance Testing** | 602d? | 2008-05-30 A | 2010-09-17 | 57% | 255.96d? | 2008-05-30 | 2010-09-17 | 602d? | 260d |  | R5 | 28391.2h | 13671.6h | RANimp-UEConTest | Rel-8 |  |  | Ingbert |  |  |  |
| 435 | 178.1 | Conformance Test Aspects – Combination of 64QAM and MIMO for HSDPA (FDD) | 322d? | 2008-09-12 A | 2009-12-04 A | 100% |  | 2008-09-12 | 2009-12-04 | 322d? |  | finish no earlier than 2009-12-04 | R5 | 2576h | 2576h | RANimp-UEConTest_64QamMimoHsdpa | Rel-8 | Ericsson | leif.mattisson@ericsson.com | Ingbert | RP-091058 | RP-41 | PCG-21 |
| 436 | 178.2 | Conformance Test Aspects – Improved L2 for uplink | 341d? | 2008-05-30 A | 2009-09-18 A | 100% |  | 2008-05-30 | 2009-09-18 | 341d? |  | finish no earlier than 2009-09-18 | R5 | 2728h | 2728h | RANimp-UEConTest_UplinkL2dataRates | Rel-8 | Ericsson | leif.mattisson@ericsson.com | Ingbert | RP-090712 | RP-40 | PCG-21 |
| 437 | 178.3 | Conformance Test Aspects – 64QAM for 1.28 Mcps TDD HSDPA | 261d? | 2008-05-30 A | 2009-05-29 A | 100% |  | 2008-05-30 | 2009-05-29 | 261d? |  | finish no earlier than 2009-05-29 | R5 | 2088h | 2088h | RANimp-UEConTest_64Qam1.28TDD | Rel-8 | ZTE | ma.zijiang@zte.com.cn | Ingbert | RP-090415 | RP-40 | PCG-21 |
| 438 | 178.4 | Conformance Test Aspects – Dual-Cell HSDPA operation on adjacent carriers | 336d? | 2008-12-05 A | 2010-03-19 | 80% | 67.2d? | 2008-12-05 | 2010-03-19 | 336d? | 390d | finish no earlier than 2010-03-19 | R5 | 2688h | 2150.4h | RANimp-UEConTest_DCHSDPA | Rel-8 | Qualcomm Europe | Shubhang Vora (svora@qualcomm.com) | Ingbert | RP-091062 | RP-42 | PCG-22 |
| 439 | 178.5 | Conformance Test Aspects – Enhanced Uplink for CELL_FACH State in FDD | 266d? | 2009-03-06 A | 2010-03-12 | 40% | 159.6d? | 2009-03-06 | 2010-03-12 | 266d? | 395d | finish no earlier than 2010-03-12 | R5 | 2128h | 851.2h | RANimp-UEConTest_EnhancedRACHCellFACHState | Rel-8 | Nokia | jarkko.hellsten@nokia.com | Ingbert | RP-091067 | RP-43 | PCG-22 |
| 440 | 178.6 | Conformance Test Aspects – Receiver Type3i | 196d? | 2009-03-06 A | 2009-12-04 A | 100% |  | 2009-03-06 | 2009-12-04 | 196d? |  | finish no earlier than 2009-12-04 | R5 | 1568h | 1568h | RANimp-UEConTest_ReceiverType3i | Rel-8 | Qualcomm Europe | Ashok Kumar Narayanaswamy (anarayan@qualcomm.com) | Ingbert | RP-091066 | RP-43 | PCG-22 |
| 441 | 178.7 | Conformance Test Aspects – Enhanced CELL_FACH State in LCR TDD | 341d? | 2009-05-30 A | 2010-09-17 | 25% | 257d? | 2009-05-30 | 2010-09-17 | 341d? | 260d | finish no earlier than 2010-09-17 | R5 | 2728h | 672h | RANimp-UEConTest_EnhancedCellFACHStateLCRTDD | Rel-8 | CATT | Xiaozhong Chen (chenxiaozhong@datangmobile.cn) | Ingbert | RP-091068 | RP-44 | PCG-23 |
| 442 | 178.8 | Conformance Test Aspects – 1.28 Mcps TDD Improved L2 support for high data rates | 337d? | 2009-05-29 A | 2010-09-10 | 30% | 235.9d? | 2009-05-29 | 2010-09-10 | 337d? | 265d | finish no earlier than 2010-09-10 | R5 | 2696h | 808.8h | RANimp-UEConTest_ImprovedL2LCRTDD | Rel-8 | CATT | Xiaozhong Chen (chenxiaozhong@datangmobile.cn) | Ingbert | RP-091071 | RP-44 | PCG-23 |
| 443 | 178.9 | Conformance Test Aspects – Continuous Connectivity for packet data users for 1.28 Mcps TDD | 261d? | 2009-09-18 A | 2010-09-17 | 5% | 247.95d? | 2009-09-18 | 2010-09-17 | 261d? | 260d | finish no earlier than 2010-09-17 | R5 | 2088h | 104.4h | RANimp-UEConTest_CPCLCRTDD | Rel-8 | ZTE | He Huang (huang.he4@zte.com.cn) | Ingbert | RP-091077 | RP-45 | PCG-23 |
| 444 | 178.10 | Conformance Test Aspects – MIMO for 1.28 Mcps TDD | 186d? | 2009-09-18 A | 2010-06-04 | 5% | 176.7d? | 2009-09-18 | 2010-06-04 | 186d? | 335d | finish no earlier than 2010-06-04 | R5 | 1488h | 74.4h | RANimp-UEConTest_MIMOLCRTDD | Rel-8 | ZTE | He Huang (huang.he4@zte.com.cn) | Ingbert | RP-091078 | RP-45 | PCG-23 |
| 445 | 178.11 | Conformance Test Aspects – HS-DSCH Serving Cell Change Enhancements | 126d? | 2009-09-18 A | 2010-03-12 | 5% | 119.7d? | 2009-09-18 | 2010-03-12 | 126d? | 395d | finish no earlier than 2010-03-12 | R5 | 1008h | 50.4h | HSDSCH_UEConTest | Rel-8 | Qualcomm Europe | Shubhang Vora (svora@qualcomm.com) | Ingbert | RP-091079 | RP-45 | PCG-23 |
| 446 | 179 | 3.84 Mcps TDD MBSFN Integrated Mobile Broadcast | 395d? | 2007-06-04 A | 2008-12-05 A | 100% |  | 2007-06-04 | 2008-12-05 | 395d? |  |  | R1 | 3160h | 3160h | MBSFN-DOB | Rel-8 | Ericsson | Lars.Lindbom@ericsson.com | Patrick | RP-080218 |  |  |
| 447 | 180 | Conformance Test Aspects – 3.84 Mcps TDD MBSFN Integrated Mobile Broadcast | 211d? | 2009-05-30 A | 2010-03-19 | 95% | 10.55d? | 2009-05-30 | 2010-03-19 | 211d? | 390d | finish no earlier than 2010-03-19 | R5 | 1688h | 1603.6h | MBSFN_IMB_UEConTest | Rel-8 | IPwireless | Phil Young (pyoung@ipwireless.com) | Ingbert | RP-091072 | RP-44 | PCG-23 |
| 448 | 181 | GERAN support for GERAN - 3G Long Term Evolution interworking | 641d? | 2006-09-08 A | 2009-02-20 A | 100% |  | 2006-09-08 | 2009-02-20 | 641d? |  | finish no earlier than 2009-02-20 | GP | 5128h | 5128h | GELTE | Rel-8 | Nokia, Nokia Siemens Networks | sergio.parolari@nsn.com, vlora.rexhepi@nokia.com | Paolo |  |  |  |
| 449 | 182 | U-TDOA Enhancement | 131d? | 2007-05-18 A | 2007-11-16 A | 100% |  | 2007-05-18 | 2007-11-16 | 131d? |  | finish no earlier than 2007-05-18 | GP | 1048h | 1048h | GUTEN | Rel-8 | TruePosition | Terry Brooks (terri.brooks@trueposition.com) | Paolo |  |  |  |

Notes:
- 420: -
- 421: SR in RP-080518. RP#41 completed / Text3: 25.308, 25.211, 25.212, 25.213, 25.306, 25.331, 25.433, 25.435, 25.423, 25.425, 25.101, 25.104, 25.141
- 422: SR in RP-080265. RP#40 completed / Text3: 25.319, 25.301, 25.306, 25.321, 25.331, 25.433, 25.435, 25.423, 25.425, 25.427
- 423: SR in RP-080804. RP#42 completed / Text3: 25.309, 25.211, 25.214, 25.321, 25.331, 25.423, 25.433
- 424: SR in RP-080520. RP#41 completed / Text3: 25.306, 25.308, 25.321, 25.331, 25.423
- 425: SR in RP-080521. RP#41 completed / Text3: 25.306, 25.308, 25.321, 25.331, 25.423, 25.433, 25.214, 25.133
- 426: SR in RP-080805. RP#42 completed. WID updated RP-070760=>RP-080830 / Text3: 25.401, 25.413, 25.420, 25.423, 25.427, 25.433, 25.446, 25.301, 25.346
- 427: SR in RP-080806. RP#42 completed / Text3: 25.102, 25.105, 25.123, 25.142, 25.201, 25.221, 25.222, 25.223, 25.224, 25.306, 25.308, 25.321, 25.331, 25.423, 25.433
- 428: SR in RP-080807. RP#42 completed / Text3: 25.123, 25.221, 25.222, 25.224, 25.301, 25.302, 25.304, 25.306, 25.308, 25.319, 25.321, 25.331, 25.401, 25.423, 25.425, 25.433, 25.435
- 429: RP#44 completed / Text3: 25.929, 25.308, 25.319
- 430: RP#43 completed / Text3: 25.331, 25.413
- 431: SR in RP-080811. RP#42 completed / Text3: 25.101, 25.104, 25.133, 25.212, 25.214, 25.308, 25.321, 25.331, 25.423, 25.433
- 432: RP#43 completed (part missing R4 performance part) / Text3: 25.201, 25.221, 25.222, 25.223, 25.224, 25.306, 25.308, 25.321, 25.331, 25.423, 25.433, 25.102, 25.105, 25.142
- 433: RP#42 completed except R4 performance part 05/09. Triggered by FS_RAN-DCHS UID_390032 / Text3: 25.101, 25.104, 25.133, 25.141, 25.211, 25.212, 25.213, 25.214, 25.215, 25.306, 25.308, 25.321, 25.331, 25.423, 25.433
- 434: Linked to Feature UID_20029 (RANimp)
- 435: RP#46 completed / Text3: 34.108, 34.121-1, 34.121-2, 34.123-1, 34.123-2
- 436: RP#45 completed. Testing for UID_370036 / Text3: 34.108, 34.123-1, 34.123-2, 34.123-3
- 437: RP#44 completed. Testing for UID_380075 / Text3: 34.108, 34.122, 34.123-1, 34.123-2, 34.123-3
- 438: RP#46 completion 12/09 (was 09/09)=>03/10. Testing for UID_400052 / Text3: 34.108, 34.121-1, 34.121-2, 34.123-1, 34.123-2, 34.123-3
- 439: Testing for UID_370037 / Text3: 34.108, 34.121-1, 34.121-2, 34.123-1, 34.123-2, 34.123-3
- 440: RP#46 completed. Testing for Receiver Type3i in 25.101 UE radio Tx and Rx FDD / Text3: 34.108, 34.121-1, 34.121-2
- 441: Testing for UID_380076 / Text3: 34.108, 34.123-1, 34.123-2, 34.123-3
- 442: Testing for Rel-7 UID_340039 Improved L2 support for high data rates and Rel-8 UID_370036 Improved L2 for uplink / Text3: 34.108, 34.123-1, 34.123-2, 34.123-3
- 443: Testing for UID_390028 / Text3: 34.108, 34.123-1, 34.123-2, 34.123-3
- 444: Testing for UID_400050 / Text3: 34.108, 34.123-1, 34.123-2, 34.123-3
- 445: Testing for UID_390030 / Text3: 34.108, 34.121-1, 34.121-2, 34.123-1, 34.123-2, 34.123-3
- 446: RP#42 completed. WID updated RP-070493=>RP-081124 (changed WI title "MBSFN Downlink Optimized Broadcast (DOB) 3.84 Mcps TDD" => "3.84Mcps TDD MBSFN Integrated Mobile Broadcast"). RP#39 SR in RP-080218. / Text3: 25.102, 25.105, 25.123, 25.201, 25.221, 25.222, 25.223, 25.224, 25.304, 25.306, 25.331, 25.346, 25.402, 25.433
- 447: RP#46 completion 12/09=>03/10. Testing for Rel-8 MBSFN-DOB UID_360008 / Text3: 34.108, 34.122, 34.123-1, 34.123-2, 34.123-3
- 448: GP#41 completed (MS conformance testing open) / Text3: 24.008, 43.055, 43.129, 43.246, 44.018, 44.060, 45.002, 45.008, 45.010, 48.008, 48.018, 51.010
- 449: GP#36 completed U-TDOA (Uplink Time Difference of Arrival) / Text3: 43.059, 45.008, 48.071

| ID | WBS | Task | Type | Duration | Start | Finish | Complete | Remaining | Baseline start | Baseline finish | Baseline duration | Total slack | Constraint | Resources | Work | Actual work | Text1 | Text4 | Text6 | Text8 | Text3 | Text2 | Text7 | Text12 | Text9 | Text11 |
| --- | --- | --- | --- | --- | --- | --- | --- | --- | --- | --- | --- | --- | --- | --- | --- | --- | --- | --- | --- | --- | --- | --- | --- | --- | --- | --- |
| 450 | 183 | **GAN Enhancements** |  | 604.2d? | 2007-05-15 A | 2009-09-04 A | 100% |  | 2007-05-15 | 2009-09-04 | 604.2d? |  |  | GP | 9432h | 9432h | GANENH | T-Mobile | Rel-8 | Paolo |  |  |  |  |  |  |
| 451 | 183.1 | Update to GAN specifications |  | 126d? | 2007-08-31 A | 2008-02-22 A | 100% |  | 2007-08-31 | 2008-02-22 | 126d? |  | finish no earlier than 2008-02-22 | GP | 1008h | 1008h | GANENH-SPEC | T-Mobile | Rel-8 | Paolo | 43.318, 44.318 |  |  |  |  |  |
| 452 | 183.2 | Update TS 51.010 Mobile Station (MS) Conformance Specification for GAN Enhancements |  | 526d? | 2007-05-15 A | 2009-09-04 A | 100% |  | 2007-05-15 | 2009-09-04 | 526d? |  | finish no earlier than 2009-09-04 | G3new | 4208h | 4208h | GANENH-MStest | T-Mobile | Rel-8 | Ingbert | 51.010 |  |  |  |  |  |
| 453 | 184 | **AoIP (A-interface over IP)** |  | 2335d? | 2000-01-03 A | 2008-12-11 A | 100% |  | 2000-01-03 | 2008-12-11 | 2335d? |  |  | GP,S4,C4,C1,C3 | 41412.1h | 41412.1h | AoIP | China Mobile, Ericsson | Rel-8 | Paolo |  | PCG-21 |  |  |  |  |
| 454 | 184.1 | GERAN aspects of AoIP |  | 2321d? | 2000-01-03 A | 2008-11-21 A | 100% |  | 2000-01-03 | 2008-11-21 | 2321d? |  | finish no earlier than 2008-11-21 | GP | 18560h | 18560h | AoIP | China Mobile, Ericsson | Rel-8 | Paolo | 48.001, 48.002, 48.008, 48.020, 49.008, 48.103 | PCG-21 | SP-40 |  |  |  |
| 455 | 184.2 | Media Requirements for CS over IP based User Plane |  | 267d? | 2007-12-05 A | 2008-12-11 A | 100% |  | 2007-12-05 | 2008-12-11 | 267d? |  | finish no earlier than 2008-12-11 | S4 | 1996.09h | 1996.09h | AoIP-CSoIP | China Mobile, Ericsson | Rel-8 | Paolo | 26.102, 26.103, 26.202 | PCG-21 | SP-40 |  |  |  |
| 456 | 184.3 | Core Network Impacts for A-Interface User Plane over IP |  | 136d? | 2008-05-30 A | 2008-12-05 A | 100% |  | 2008-05-30 | 2008-12-05 | 136d? |  | start no earlier than 2008-05-30 | C4 | 1088h | 1088h | AoIP-CN | Ericsson | Rel-8 | Kimmo | 23.205, 23.153, 23.231, 29.232 | PCG-21 | CP-40 |  |  |  |
| 457 | 184.4 | Core Network Impacts for A-Interface User Plane over IP |  | 68d? | 2008-05-30 A | 2008-12-05 A | 100% |  | 2008-05-30 | 2008-12-05 | 68d? |  | finish no earlier than 2008-12-05 | C1 | 544h | 544h | AoIP-CN | Ericsson | Rel-8 | Frederic | 23.009 | PCG-21 | CP-40 |  |  |  |
| 458 | 184.5 | Core Network Impacts for A-Interface User Plane over IP |  | 68d? | 2008-05-30 A | 2008-12-05 A | 100% |  | 2008-05-30 | 2008-12-05 | 68d? |  | finish no earlier than 2008-12-05 | C3 | 544h | 544h | AoIP-CN | Ericsson | Rel-8 | Gwiho | 29.007 | PCG-21 | CP-40 |  |  |  |
| 459 | 185 | New multicarrier BTS class |  | 261d? | 2007-08-31 A | 2008-08-29 A | 100% |  | 2007-08-31 | 2008-08-29 | 261d? |  | finish no earlier than 2008-08-29 | G1 | 2088h | 2088h | MCBTS | Alcatel-Lucent | Rel-8 | Paolo | 45.005, 45.050, 51.021 |  |  |  |  |  |
| 460 | 186 | **Conformance testing for the Latency Reductions feature** |  | 532d? | 2008-02-22 A | 2010-03-05 | 97% | 17.84d? | 2008-02-22 | 2010-03-05 | 532d? | 400d |  | G1, G3new | 10592h | 10236.4h | CTLATRED | Ericsson | Rel-8 | Paolo |  | PCG-21 |  |  |  |  |
| 461 | 186.1 | MS conformance testing for the Latency Reductions feature |  | 532d? | 2008-02-22 A | 2010-03-05 | 95% | 26.6d? | 2008-02-22 | 2010-03-05 | 532d? | 400d | finish no earlier than 2010-03-05 | G3new | 4248h | 4035.2h | CTLATRED-MStest | Ericsson | Rel-8 | Ingbert | 51.010 | PCG-21 |  |  |  |  |
| 462 | 186.2 | BTS conformance testing for the Latency Reductions feature |  | 261d? | 2008-02-22 A | 2009-02-20 A | 100% |  | 2008-02-22 | 2009-02-20 | 261d? |  | finish no earlier than 2009-02-20 | G1 | 2088h | 2088h | CTLATRED-BTStest | Ericsson | Rel-8 | Paolo | 51.021 | PCG-21 |  |  |  |  |
| 463 | 187 | MS conformance testing of changes introduced by WI “Support of Packet-switched Handover for GERAN A/Gb mode” |  | 196d? | 2008-02-22 A | 2008-11-21 A | 100% |  | 2008-02-22 | 2008-11-21 | 196d? |  | finish no earlier than 2008-11-21 | G3new | 1568h | 1568h | PSHCT-MStest | Rohde & Schwarz | Rel-8 | Ingbert | 51.010 | PCG-21 |  |  |  |  |
| 464 | 188 | (Small) Technical Enhancements and Improvements for Rel-8 |  | 509d? | 2007-01-01 A | 2008-12-11 A | 100% |  | 2007-01-01 | 2008-12-11 | 509d? |  | finish no earlier than 2008-12-11 | All | 4072h | 4072h | TEI8 | ALL | Rel-8 |  |  |  |  |  |  |  |
| 465 | 189 | Test - (Small) Technical Enhancements and Improvements for Rel-8 |  | 672d? | 2007-03-07 A | 2010-12-24 | 60% | 268.8d? | 2007-03-07 | 2010-12-24 | 672d? | 190d | finish no earlier than 2010-12-24 | R5,G3new | 5376h | 3225.6h | TEI8_Test | ALL | Rel-8 | Ingbert |  | PCG-21 | RP-40 |  |  |  |
| 466 | 190 | Deleted - was Rel7 - LCS for 3GPP Interworking WLAN | milestone | 0d? | 2007-09-28 A | 2007-09-28 A | 100% |  | 2007-09-28 | 2007-09-28 | 0d? |  | start no earlier than 2007-09-28 | S2 |  |  | LCS4_IWLAN | LG Electronics | Rel-8 | Maurice | 23.234, 23.271, 23.167 |  |  | SP-35 |  |  |
| 467 | 191 | Deleted - never approved- FBI Phase 2 | milestone | 0d | 2007-09-28 A | 2007-09-28 A | 100% |  | 2007-09-28 | 2007-09-28 | 0d |  | start no earlier than 2007-09-28 | S2 |  |  | FBI2 | Nokia Siemens Networks | Rel-8 | Maurice |  |  |  | SP-38 |  |  |
| 468 | 192 | Deleted - MS conformance testing of Support of Conversational Services in A/Gb mode via the PS domain |  | 401d? | 2008-02-25 A | 2009-09-04 A | 100% |  | 2008-02-25 | 2009-09-04 | 401d? |  | finish no earlier than 2009-09-04 | G3new | 3208h | 3208h | SCSAGBCT-MStest | Nokia | Rel-8 | Ingbert | 51.010 | PCG-21 |  | GP-43 | PCG-23 |  |
| 469 | 193 | Release 8 Studies | milestone | 0d? | 2008-03-20 | 2008-03-20 |  |  | 2008-03-20 | 2008-03-20 | 0d? | 912d | finish no earlier than 2008-03-20 | CP,GP,RP,SP |  |  |  |  | Rel-8 |  |  |  |  |  |  |  |
| 470 | 194 | **Study on 3GPP System Architecture Evolution** |  | 1115d? | 2004-12-03 A | 2009-03-12 A | 100% |  | 2004-12-03 | 2009-03-12 | 1115d? |  |  | S2,S3 | 23456h | 23456h | FS_SAE | Vodafone | Rel-8 | Maurice |  |  |  |  |  |  |
| 471 | 194.1 | Stage 2 Interim conclusion for RAN Work to start |  | 990d? | 2004-12-03 A | 2008-09-18 A | 100% |  | 2004-12-03 | 2008-09-18 | 990d? |  | finish no earlier than 2005-09-23 | S2 | 7920h | 7920h | FS_SAE | Vodafone | Rel-8 | Maurice | 23.882 |  |  |  |  |  |
| 472 | 194.2 | Stage 2 study on 3GPP architectural development |  | 704d? | 2006-01-09 A | 2008-09-18 A | 100% |  | 2006-01-09 | 2008-09-18 | 704d? |  | finish no earlier than 2007-09-28 | S2 | 5632h | 5632h | FS_SAE | Vodafone | Rel-8 | Maurice | 23.882 |  |  |  |  |  |
| 473 | 194.3 | Security study for Inter-access mobility between non-3GPP and 3GPP system |  | 334d? | 2007-09-03 A | 2009-03-12 A | 100% |  | 2007-09-03 | 2009-03-12 | 334d? |  | finish no earlier than 2009-03-12 | S3 | 2672h | 2672h | FS_SAE | Nokia | Rel-8 | Dionisio | 33.821, 33.822 |  |  |  |  |  |
| 474 | 195 | Study on Stage 2 aspects of IMS Service Brokering |  | 589d? | 2006-06-19 A | 2008-09-18 A | 100% |  | 2006-06-19 | 2008-09-18 | 589d? |  | finish no earlier than 2008-09-18 | S2 | 4712h | 4712h | FS_ISB_ST2 | Telcordia | Rel-8 | Maurice | 23.810 |  |  |  |  |  |
| 475 | 196 | Study on IMS utilizing multicast bearer services |  | 447d? | 2006-03-22 A | 2007-12-06 A | 100% |  | 2006-03-22 | 2007-12-06 | 447d? |  | finish no earlier than 2007-12-03 | S2 | 3576h | 3576h | FS_MLTICAST-IMS | Nokia Siemens Networks | Rel-8 | Maurice | 23.847 |  |  |  |  |  |
| 476 | 197 | Study on Mobility between 3GPP-WLAN Interworking and 3GPP Systems |  | 393d? | 2007-03-20 A | 2008-09-18 A | 100% |  | 2007-03-20 | 2008-09-18 | 393d? |  | finish no earlier than 2008-09-18 | S2 | 3144h | 3144h | FS_SM3GWLAN | Orange | Rel-8 | Maurice | 23.827 withdrawn |  |  |  |  |  |
| 477 | 198 | Study on Multimedia Session Continuity |  | 291d? | 2007-04-26 A | 2008-06-05 A | 100% |  | 2007-04-26 | 2008-06-05 | 291d? |  | finish no earlier than 2008-06-05 | S2 | 2328h | 2328h | FS_MMSC | LG Electronics | Rel-8 | Maurice | 23.893 |  |  |  |  |  |
| 478 | 199 | Study on Architecture of IMS based Customized Alerting Tone (CAT) |  | 208d? | 2007-12-04 A | 2008-09-18 A | 100% |  | 2007-12-04 | 2008-09-18 | 208d? |  | finish no earlier than 2008-09-08 | S2 | 1664h | 1664h | FS_CAT-St2 | China Mobile | Rel-8 | Maurice | 23.872 | PCG-21 | SP-38 |  |  |  |
| 479 | 200 | Study on Home (e)NodeB Security |  | 321d? | 2007-12-20 A | 2009-03-12 A | 100% |  | 2007-12-20 | 2009-03-12 | 321d? |  | finish no earlier than 2009-03-10 | S3 | 2568h | 2568h | FS_HNB_Sec | Huawei | Rel-8 | Dionisio | 33.820 | PCG-21 | SP-38 |  |  |  |
| 480 | 201 | Study on Transferring of emergency call data – in-band modem solution |  | 265d? | 2006-12-07 A | 2007-12-12 A | 100% |  | 2006-12-07 | 2007-12-12 | 265d? |  | finish no earlier than 2008-09-18 | S4 | 2120h | 2120h | eCALLIBMS | Airbiquity | Rel-8 | Paolo | 26.967 |  |  |  |  |  |
| 481 | 202 | Study on Element Operations Systems Function (EOSF) definition |  | 266d? | 2007-06-07 A | 2008-06-12 A | 100% |  | 2007-06-07 | 2008-06-12 | 266d? |  | finish no earlier than 2008-12-11 | S5 | 2128h | 2128h | OAM7-NIM- EOSF | China Mobile | Rel-8 | Dionisio | 32.819 |  |  |  |  |  |
| 482 | 203 | Study on SA5 MTOSI XML Harmonization |  | 351d? | 2006-05-10 A | 2007-09-12 A | 100% |  | 2006-05-10 | 2007-09-12 | 351d? |  | finish no earlier than 2007-12-14 | S5 | 2808h | 2808h | OAM8-NIM-XML | Nortel | Rel-8 | Dionisio | 32.818 |  |  |  |  |  |
| 483 | 204 | Study on Common Profile Storage (CPS) Framework of User Data for network services and management |  | 244d? | 2006-07-03 A | 2007-06-07 A | 100% |  | 2006-07-03 | 2007-06-07 | 244d? |  | finish no earlier than 2007-06-07 | S5 | 1952h | 1952h | OAM7-CPS | T-Mobile | Rel-8 | Dionisio | 32.808 |  |  |  |  |  |
| 484 | 205 | Study on Management for LTE and SAE |  | 526d? | 2006-12-07 A | 2008-12-11 A | 100% |  | 2006-12-07 | 2008-12-11 | 526d? |  | finish no earlier than 2008-12-11 | S5 | 4208h | 4208h | FS_OAM_LTE_SAE | Ericsson | Rel-8 | Dionisio | 32.816 |  |  |  |  |  |
| 485 | 206 | Study on Charging Aspects of 3GPP System Evolution |  | 179d? | 2007-04-02 A | 2007-12-06 A | 100% |  | 2007-04-02 | 2007-12-06 | 179d? |  | finish no earlier than 2007-12-06 | S5 | 1432h | 1432h | FS_SAEcharg | Nokia Siemens Networks | Rel-8 | Dionisio | 32.820 |  |  |  |  |  |
| 486 | 207 | Study on AS-MRFC media server control protocol |  | 583d? | 2006-03-22 A | 2008-06-13 A | 100% |  | 2006-03-22 | 2008-06-13 | 583d? |  | finish no earlier than 2008-06-13 | C1 | 4664h | 4664h | MRFC | HP | Rel-8 | Frederic | 24.880 |  |  |  |  |  |
| 487 | 208 | Study on IMS Restoration Procedures |  | 310d? | 2007-03-26 A | 2008-05-30 A | 100% |  | 2007-03-26 | 2008-05-30 | 310d? |  | finish no earlier than 2008-05-30 | C4 | 2480h | 2480h | FS_IMS_RP | Ericsson | Rel-8 | Kimmo | 23.820 |  |  |  |  |  |
| 488 | 209 | Study on IMS Application Server Service Data Descriptions for AS interoperability |  | 261d? | 2007-09-14 A | 2008-09-12 A | 100% |  | 2007-09-14 | 2008-09-12 | 261d? |  | finish no earlier than 2008-09-12 | C4 | 2088h | 2088h | FS_IMS_ASIO | Alcatel-Lucent | Rel-8 | Kimmo | 29.864 |  |  |  |  |  |
| 489 | 210 | Study on Customized Alerting Tone (CAT) solution for voice and video call in CS domain |  | 261d? | 2007-09-14 A | 2008-09-12 A | 100% |  | 2007-09-14 | 2008-09-12 | 261d? |  |  | C4 | 626.4h | 626.4h | FS_CAT_VVC_CS | China Mobile | Rel-8 | Kimmo | 29.882 |  |  |  |  |  |
| 490 | 211 | Study on InterWorking Function between MAP based and Diameter based interfaces |  | 266d? | 2007-11-30 A | 2008-12-05 A | 100% |  | 2007-11-30 | 2008-12-05 | 266d? |  | finish no earlier than 2008-12-05 | C4 | 2128h | 2128h | FS_MAP2Diam | Huawei | Rel-8 | Kimmo | 29.805 | PCG-21 | CP-38 |  |  |  |
| 491 | 212 | Study on Scope of future HSPA Evolution for 1.28 Mcps TDD |  | 186d? | 2007-09-14 A | 2008-05-30 A | 100% |  | 2007-09-14 | 2008-05-30 | 186d? |  | finish no earlier than 2008-05-30 | R1 | 1488h | 1488h | FS_RAN-LCRTDDHSPAEvo | RITT | Rel-8 | Patrick | 25.824 |  | RP-37 |  |  | RP-080290 |
| 492 | 213 | Study on Synchronized E-DCH for UTRA FDD |  | 126d? | 2007-09-14 A | 2008-03-07 A | 100% |  | 2007-09-14 | 2008-03-07 | 126d? |  | finish no earlier than 2008-03-14 | R1 | 1008h | 1008h | FS_RAN-UplinkSync | Nokia Siemens Networks | Rel-8 | Patrick | 25.823 |  | RP-37 |  |  | RP-080068 |
| 493 | 214 | Study on Improved network controlled mobility between LTE and 3GPP2/mobile WiMAX radio technologies |  | 131d? | 2007-06-04 A | 2007-12-03 A | 100% |  | 2007-06-04 | 2007-12-03 | 131d? |  | finish no earlier than 2007-12-03 | R4 | 1048h | 1048h | FS_RAN-LTEmob | Motorola | Rel-8 | Issam | 36.938 |  |  |  |  | RP-070827 |
| 494 | 215 | Study on 3G Home NodeB/eNodeB |  | 325d? | 2007-03-05 A | 2008-05-30 A | 100% |  | 2007-03-05 | 2008-05-30 | 325d? |  | finish no earlier than 2008-05-30 | R4 | 2600h | 2600h | FS_RAN-HNBeNB | Motorola | Rel-8 | Issam | 25.820 |  |  |  |  | RP-080289 |
| 495 | 216 | Study on HS-PDSCH serving cell change enhancements |  | 60d? | 2007-12-17 A | 2008-03-07 A | 100% |  | 2007-12-17 | 2008-03-07 | 60d? |  | finish no earlier than 2008-06-12 | R4 | 480h | 480h | FS_RAN-HSPDSCH | Qualcomm Europe | Rel-8 | Issam | none | PCG-21 | RP-38 |  |  | RP-080070 |
| 496 | 217 | Study on Dual-Cell HSDPA operation |  | 261d? | 2007-08-15 A | 2009-03-06 A | 100% |  | 2007-08-15 | 2009-03-06 | 261d? |  | finish no earlier than 2009-03-06 | R1 | 2088h | 2088h | FS_RAN-DCHS | Qualcomm Europe | Rel-8 | Patrick | withdrawn 25.825 v100 | PCG-21 | RP-39 |  |  | RP-090066 |
| 497 | 218 | Study on A-interface over IP |  | 126d? | 2007-08-31 A | 2008-02-22 A | 100% |  | 2007-08-31 | 2008-02-22 | 126d? |  | finish no earlier than 2008-02-22 | GP | 1008h | 1008h | AINTIP | China Mobile, Ericsson | Rel-8 | Paolo | 43.903 |  |  |  |  |  |
| 498 | 219 | Study on Multi-User Reusing-One-Slot |  | 602d? | 2007-11-16 A | 2010-03-05 | 98% | 12.04d? | 2007-11-16 | 2010-03-05 | 602d? | 400d | finish no earlier than 2010-03-05 | GP | 4808h | 4711.68h | MUROS | Nokia Siemens Networks | Rel-8 | Paolo | 45.914 |  |  |  |  | GP-092021 |
| 499 | 220 | Study on Optimized Transmit Pulse Shape for Downlink EGPRS2-B |  | 602d? | 2007-11-16 A | 2010-03-05 | 95% | 30.1d? | 2007-11-16 | 2010-03-05 | 602d? | 400d | finish no earlier than 2010-03-05 | G1 | 4808h | 4567.2h | WIDER | RIM, Nokia Siemens Networks | Rel-8 | Paolo | 45.913 |  |  |  |  | GP-092126 |
| 500 | 221 | Deleted - Study on Evaluation of LCS Control Plane Solution for EPS |  | 100d? | 2008-01-14 A | 2008-05-30 A | 100% |  | 2008-01-14 | 2008-05-30 | 100d? |  | finish no earlier than 2009-03-20 | S2 | 800h | 800h | FS_LCS_EPS | SiRF | Rel-8 | Maurice | 23.891 |  | SP-38 | SP-40 | PCG-21 |  |
| 501 | 222 | Release 7 Features |  | 1d? | 2000-01-03 | 2000-01-03 |  |  | 2000-01-03 | 2000-01-03 | 1d? | 3056d | start no earlier than 2000-01-01 | CP,GP,RP,SP | 8h |  |  |  | Rel-7 |  |  |  |  |  |  |  |
| 502 | 223 | Multimedia Telephony Service for IMS (MTSI) - UE Conformance Testing |  | 387d | 2007-09-19 A | 2009-03-12 A | 100% |  | 2007-09-19 | 2009-03-12 | 387d |  | finish no earlier than 2009-03-13 | R5 | 1664h | 1664h | MTSI-UEConfTest | Ericsson, Motorola | Rel-7 | Ingbert | 34.123-1, 34.123-2, 34.123-3, 34.229-1, 34.229-2 |  |  |  |  | RP-090056 |
| 503 | 224 | IMS Support of Conferencing |  | 355d? | 2005-11-04 A | 2007-03-15 A | 100% |  | 2005-11-04 | 2007-03-15 | 355d? |  | finish no earlier than 2007-03-15 | C1 | 2840h | 2840h | IMSconf | Alcatel-Lucent | Rel-7 | Frederic | 24.147, 24.229 |  |  |  |  |  |
| 504 | 225 | Performance Characterization of VoIMS over HSDPA\EUL channels |  | 713d? | 2005-03-15 A | 2007-12-06 A | 100% |  | 2005-03-15 | 2007-12-06 | 713d? |  | finish no earlier than 2007-12-06 | S4 | 5704h | 5704h | VoIMS-PCVoIMS | Alcatel-Lucent | Rel-7 | Paolo | 26.935 |  |  |  |  |  |

Notes:
- 450: GP#37 completed. GP#43 completed Testing / Text5: mohammed.versi@t-mobile.com
- 451: GP#37 completed / Text5: mohammed.versi@t-mobile.com
- 452: GP#43 completed / Text5: mohammed.versi@t-mobile.com
- 453: GP#40/TSG#42 completed . Triggered by TR 43.903 Study on A-interface over IP (AINTIP) UID_50589. / Text5: wangshuaiyu@chinamobile.com, paul.schliwa-bertling@ericsson.com
- 454: GP#40 completed. GP#39 updated WID GP-080901=>GP-081362. / Text5: wangshuaiyu@chinamobile.com, paul.schliwa-bertling@ericsson.com
- 455: SP#42 completed / Text5: Karl.Hellwig@Ericsson.com
- 456: CP#42 completed. Updated WID CP-080278=>CP-080722 / Text5: philip.hodges@ericsson.com
- 457: CP#42 completed. Updated WID CP-080278=>CP-080722 / Text5: philip.hodges@ericsson.com
- 458: CP#42 completed. Updated WID CP-080278=>CP-080722 / Text5: philip.hodges@ericsson.com
- 459: GP#39 completed / Text5: thomas.bitzer@alcatel-lucent.de
- 460: GP#41 completion 09/09=>11/09 / Text5: mats.y.samuelsson@ericsson.com, hakan.e.grunditz@ericsson.com
- 461: GP#44 completion 11/09=>03/10 / Text5: hakan.e.grunditz@ericsson.com
- 462: GP#41 completed / Text5: mats.y.samuelsson@ericsson.com
- 463: GP#40 completed / Text5: Franz.Segerer@ROHDE-SCHWARZ.COM
- 464: SP#42 completed
- 465: -
- 466: SP-35 stopped / Text5: dhshim@lge.com
- 467: SP#38 stopped
- 468: GP#43 work stopped/abandoned (completion 0%) / Text5: arsi.heino@nokia.com
- 469: -
- 470: SP#43 completed / Text5: Chris Pudney
- 471: SP#41 completed / Text5: Chris Pudney
- 472: SP#41 completed / Text5: Chris Pudney
- 473: SP#43 completed / Text5: dajiang.zhang@nokia.com
- 474: SP#41 completed. No spin-off activity proposed. [Note: IMS Service Brokering enhancements UID_31088 moved back from R8 to R7 to give a home to 22228CR0036_(Rel-7)_S1-051232. Hence, Rel-7 ISB has Stage 1 only (and is misaligned with Rel-7 Stages 2/3.] / Text5: raquel@research.telcordia.com
- 475: SP#38 completed
- 476: 08/08/08 TR 23.827 v 0.4.0 no progress for 1 year. MCC recommended FS be completed and 23.827 brought under CR. SP#41 completed (draft TR 23.827 not SA approved/published; TR content implemented in TSs)
- 477: SP#40 completed
- 478: SP#41 completed as Rel-8 / Text5: WANG, Jing (wangjing@chinamobilecom)
- 479: SP#43 completed / Text5: yangyanmei@huawei.com
- 480: SP#38 completed. Spin-off WID UID_34042 (eCall_Phase2) / Text5: lhong@airbiquity.com
- 481: SP#40 completed. SID updated SP-050608=>SP-070307 / Text5: LI, Jian
- 482: SP#37 completed. SID updated SP-050295=>SP-070305 / Text5: jduguay@nortel.com
- 483: SP#36 completed. Spin-off New Feature UID_400034 (UDC) / Text5: istvan.aba@t-mobile.at
- 484: SP#42 completed / Text5: PETERSEN, Robert
- 485: SP#38 completed / Text5: GÖRMER, Gerald
- 486: CP#40 completed. Spin-off New Feature UID_380035 (MRFC_TS) / Text5: mark.syrett@hp.com
- 487: CP#40 completed. Spin-off WID UID_400012 (IMS_RP) / Text5: german.blanco@ericsson.com
- 488: CP#41 completed. Linked to SA5 Study on Common Profile Storage framework UID_320006. Spin-off WID UID_410003 (IMS_ASIO) / Text5: Jean-Jacques Trottin
- 489: CP#41 completed. Spin-off WID under Feature CAT UID_340029 / Text5: zhanghao@chinamobile.com
- 490: CP#41 Spin-off WID UID_410007 (MAP2Diam). CP#42 completed / Text5: liming49985@huawei.com
- 491: RP#40 completed. SR in RP-080290 / Text5: Xu Fei
- 492: SID in RP-070678. RP#39 completed. SR in RP-080068 / Text5: Karri.Ranta-aho@nsn.com
- 493: RP#38 completed. SR in RP-070827 / Text5: hao.bi@Motorola.com
- 494: RP#40 completed. SR in RP-080289 / Text5: howard.thomas@motorola.com
- 495: SID in RP-071044. SR in RP-080070. The study produced no TR. RP#39 completed. Spin-off New implementation WID in RP-080227
- 496: RP#43 closed. TR 25.825 v100 withdrawn. Conclusions in RP-090318 RAN1 findings of the UTRA Multi-Carrier Evolution study). RP#42 New WID RP-080490 (RANimp-DCHSDPA) UID_400052 approved / Text5: Josef Blanz
- 497: GP#37 completed. Spin-off implementation Feature AoIP (A-interface over IP) UID_50591 / Text5: paul.schliwa-bertling@ericsson.com
- 498: GP#44 completion 11/09=>03/10 (was 11/08=>02/09=>05/09=>11/09). Spin-off implementation WI UID_420002 VAMOS (Voice services over Adaptive Multi-user channels on One Slot) / Text5: juergen.hofmann@nsn.com
- 499: GP#44 completion 11/09=>03/10 (was 11/08=>02/09=>05/09=>11/09). Needs some more work to define possible Rel-9 or Rel-10 implementation work / Text5: jdwyer@RIM.COM and eddie.riddington@nsn.com
- 500: SP#40 spin-off Feature UID_400038 (LCS_CPS_EPS). SP#40 FS stopped
- 501: -
- 502: RP#43 completed. Linked UID_7038 (MTSI) / Text5: Leif.Mattisson@ericsson.com, Jacob.John@motorola.com
- 503: CP#35 revised WID / Text5: Keith Drage (drage@alcatel-lucent.com)
- 504: - / Text5: mcgowan@alcatel-lucent.com

| ID | WBS | Task | Type | Duration | Start | Finish | Complete | Baseline start | Baseline finish | Baseline duration | Constraint | Resources | Work | Actual work | Text1 | Text4 | Text5 | Text6 | Text8 | Text12 | Text2 | Text7 | Text11 |
| --- | --- | --- | --- | --- | --- | --- | --- | --- | --- | --- | --- | --- | --- | --- | --- | --- | --- | --- | --- | --- | --- | --- | --- |
| 505 | 226 | **WLAN Interworking – Private Network access from WLAN 3GPP IP Access** |  | 252d? | 2005-10-10 A | 2006-09-26 A | 100% | 2005-10-10 | 2006-09-26 | 252d? |  | S2,C1,C3,C4 | 8936h | 8936h | WLANPNA | NEC | Toshiyuki Tamura (tamurato@aj.jp.nec.com) | Rel-7 | Maurice |  |  |  |  |
| 506 | 226.1 | WLAN-PNA - Stage 2 |  | 185d? | 2005-10-10 A | 2006-06-23 A | 100% | 2005-10-10 | 2006-06-23 | 185d? | start no earlier than 2005-10-10 | S2 | 1480h | 1480h | WLANPNA-st2 | NEC | Toshiyuki Tamura (tamurato@aj.jp.nec.com) | Rel-7 | Maurice |  |  |  |  |
| 507 | 226.2 | **WLAN-PNA - Stage 3** |  | 170d? | 2006-02-01 A | 2006-09-26 A | 100% | 2006-02-01 | 2006-09-26 | 170d? |  | C1,C3,C4 | 5440h | 5440h | WLANPNA-st3 | NEC |  | Rel-7 | Frederic |  |  |  |  |
| 508 | 226.2.1 | CT1 aspets for WLAN-PNA |  | 170d? | 2006-02-01 A | 2006-09-26 A | 100% | 2006-02-01 | 2006-09-26 | 170d? | start no earlier than 2006-02-01 | C1 | 1360h | 1360h | WLANPNA-st3 | NEC |  | Rel-7 | Frederic |  |  |  |  |
| 509 | 226.2.2 | CT3 aspets for WLAN-PNA |  | 170d? | 2006-02-01 A | 2006-09-26 A | 100% | 2006-02-01 | 2006-09-26 | 170d? | start no earlier than 2006-02-01 | C3 | 1360h | 1360h | WLANPNA-st3 | NEC |  | Rel-7 | Gwiho |  |  |  |  |
| 510 | 226.2.3 | Deleted - CT4 aspets for WLAN-PNA |  | 170d? | 2006-02-01 A | 2006-09-26 A | 100% | 2006-02-01 | 2006-09-26 | 170d? | start no earlier than 2006-02-01 | C4 | 1360h | 1360h | WLANPNA-st3 | NEC |  | Rel-7 | Kimmo | CP-32 |  |  |  |
| 511 | 227 | **Enhancements to support QoS provisioning over 3GPP/WLAN Interworking** |  | 520d? | 2005-03-14 A | 2007-03-09 A | 100% | 2005-03-14 | 2007-03-09 | 520d? |  | S2,C4,C1 | 8360h | 8360h | WLANQOS | Samsung |  | Rel-7 | Maurice |  |  |  |  |
| 512 | 227.1 | Deleted - TR on support of QoS on WLAN |  | 232d? | 2005-03-14 A | 2006-01-31 A | 100% | 2005-03-14 | 2006-01-31 | 232d? | start no earlier than 2005-03-14 | S2 | 1856h | 1856h | WLANQOS | Samsung |  | Rel-7 | Maurice | SP-32 |  |  |  |
| 513 | 227.2 | Stage 2 on support of QoS over 3GPP/WLAN interworking |  | 108d? | 2006-02-01 A | 2006-06-30 A | 100% | 2006-02-01 | 2006-06-30 | 108d? | start no earlier than 2006-02-01 | S2 | 864h | 864h | WLANQOS | Samsung |  | Rel-7 | Maurice |  |  |  |  |
| 514 | 227.3 | Stage 3 CT4 on support of QoS over 3GPP/WLAN Interworking |  | 121d? | 2006-09-22 A | 2007-03-09 A | 100% | 2006-09-22 | 2007-03-09 | 121d? | finish no earlier than 2007-03-09 | C4 | 968h | 968h | WLANQOS | Huawei | zhang.peng@huawei.com | Rel-7 | Kimmo |  |  |  |  |
| 515 | 227.4 | Stage 3 CT1 on support of QoS over 3GPP/WLAN Interworking |  | 64d? | 2006-09-04 A | 2006-11-30 A | 100% | 2006-09-04 | 2006-11-30 | 64d? | finish no earlier than 2006-11-30 | C1 | 512h | 512h | WLANQOS | Huawei | zhang.peng@huawei.com | Rel-7 | Frederic |  |  |  |  |
| 516 | 228 | **MBMS - UE Conformance Testing** |  | 657d? | 2007-06-01 A | 2009-12-04 A | 100% | 2007-06-01 | 2009-12-04 | 657d? |  | R5 | 13848h | 13848h | MBMSE_UEConTest |  |  | Rel-7 | Ingbert |  | PCG-21 | SP-40 |  |
| 517 | 228.1 | Conformance Test Aspects – MBMS TDD Physical layer Enhancements – MBSFN for HCR and VHCR TDD |  | 336d? | 2007-06-01 A | 2008-09-12 A | 100% | 2007-06-01 | 2008-09-12 | 336d? | start no earlier than 2007-06-01 | R5 | 2688h | 2688h | MBMSE-RANPhysTDD_UEConTest | IPWireless | tspeight@ipwireless.com | Rel-7 | Ingbert |  |  |  | RP-080541 |
| 518 | 228.2 | Conformance Test Aspects – MBMS LCR TDD Physical Layer Enhancement |  | 342d? | 2008-05-30 A | 2009-09-18 A | 100% | 2008-05-30 | 2009-09-18 | 342d? | finish no earlier than 2009-09-18 | R5 | 2728h | 2728h | MBMSE-RANPhysLCRTDD_UEConTest | CATT | chenxiaozhong@datangmobile.cn | Rel-7 | Ingbert |  | PCG-21 | RP-40 | RP-090715 |
| 519 | 228.3 | Conformance Test Aspects – MBSFN for FDD |  | 397d? | 2008-05-30 A | 2009-12-04 A | 100% | 2008-05-30 | 2009-12-04 | 397d? | finish no earlier than 2009-12-04 | R5 | 3176h | 3176h | MBMSE-UEConTest_RANPhysFDD | Huawei | Xiang Li (trica_li@huawei.com) | Rel-7 | Ingbert |  | PCG-21 | RP-40 | RP-091214 |
| 520 | 229 | MBMS User Service Extensions |  | 392d? | 2005-12-07 A | 2007-06-07 A | 100% | 2005-12-07 | 2007-06-07 | 392d? | finish no earlier than 2007-06-07 | S4 | 3136h | 3136h | MBMSUSE | Ericsson | Thorsten.Lohmar@ericsson.com | Rel-7 | Paolo |  |  |  |  |
| 521 | 230 | A-GPS Minimum Performance |  | 351d? | 2006-04-28 A | 2007-08-31 A | 100% | 2006-04-28 | 2007-08-31 | 351d? | finish no earlier than 2007-08-31 | GP | 2808h | 2808h | GAGR | Spirent | richard.catmur@spirentcom.com | Rel-7 | Paolo |  |  |  |  |
| 522 | 231 | Network Selection enhancements (NSP) - UE Conformance Testing |  | 396d? | 2007-06-01 A | 2008-12-05 A | 100% | 2007-06-01 | 2008-12-05 | 396d? | finish no earlier than 2008-12-05 | R5 | 3168h | 3168h | NSP-CR_UEConTest | Nokia | jarkko.hellsten@nokia.com | Rel-7 | Ingbert |  |  |  | RP-080819 |
| 523 | 232 | **Access Class Barring and Overload Protection** |  | 650d? | 2004-03-15 A | 2006-09-08 A | 100% | 2004-03-15 | 2006-09-08 | 650d? |  | S2,C1 | 3568h | 3568h | ACBOP | Vodafone | Chris Pudney | Rel-7 | Maurice |  |  |  |  |
| 524 | 232.1 | TR on Stage 2 |  | 274d? | 2004-03-15 A | 2005-03-31 A | 100% | 2004-03-15 | 2005-03-31 | 274d? | finish no earlier than 2005-03-31 | S2 | 2192h | 2192h | ACBOP | NTT DoCoMo | Jean-Jacques Davidian (davidian@docomo.fr) | Rel-7 | Maurice |  |  |  |  |
| 525 | 232.2 | Stage 3 CN aspects of ACBOP |  | 172d? | 2005-06-06 A | 2006-01-31 A | 100% | 2005-06-06 | 2006-01-31 | 172d? | start no earlier than 2005-06-06 | C1 | 1376h | 1376h | ACBOP |  |  | Rel-7 | Frederic |  |  |  |  |
| 526 | 232.3 | Deleted - Potential impact on Iu interface Overload functionality | milestone | 0d? | 2004-03-15 A | 2004-03-15 A | 100% | 2004-03-15 | 2004-03-15 | 0d? | finish no earlier than 2004-03-15 | RP |  |  | ACBOP |  |  | Rel-7 | Issam | RP-25 |  |  |  |
| 527 | 232.4 | Deleted - Extra ACBOP information in RAN | milestone | 0d? | 2004-03-15 A | 2004-03-15 A | 100% | 2004-03-15 | 2004-03-15 | 0d? | finish no earlier than 2004-03-15 | RP |  |  | ACBOP |  |  | Rel-7 | Issam | RP-25 |  |  |  |
| 528 | 232.5 | Deleted - Extra ACBOP information in GERAN | milestone | 0d? | 2006-09-08 A | 2006-09-08 A | 100% | 2006-09-08 | 2006-09-08 | 0d? | start no earlier than 2006-09-08 | GP |  |  | ACBOP |  |  | Rel-7 | Paolo | RP-33 |  |  |  |

Notes:
- 505: -
- 506: Approved at SP#29 / Text3: 23.234, 33.234
- 507: Approved at CP#29
- 508: Approved at CP#29 / Text3: 24.234
- 509: Approved at CP#29 / Text3: 29.161
- 510: CT4#31; no impacts identified, therefore completed. CP-32 stopped / Text3: 29.234
- 511: Moved from FS section Feb 06. SP-30 updated WID
- 512: SP-32 stopped / Text3: 23.836
- 513: SP-30 updated WID / Text3: 23.234
- 514: CP-32 approved WID / Text3: 29.234, 23.008
- 515: CP-32 approved WID / Text3: 24.234
- 516: Linked to Rel-7 Feature UID_31084 (MBMSE)
- 517: SR in RP-080541. RP#41 completed / Text3: 34.108, 34.122, 34.123-1/2/3
- 518: RP#45 completed / Text3: 34.108, 34.123-1
- 519: RP#46 completed / Text3: 34.108, 34.109, 34.121-1, 34.121-2, 34.123-1, 34.123-2, 34.123-3
- 520: - / Text3: 26.346, 26.946
- 521: - / Text3: 45.005, 51.010
- 522: RP#42 completed. SR in RP-080819. Linked to UID_7041 (NSP-CR). / Text3: 34.108, 34.123-1, 34.123-2, 34.123-3
- 523: - / Text3: 23.898
- 524: - / Text3: 23.898
- 525: NEW - inserted on 2/9/2004 / Text3: 24.008
- 526: - / Text3: 25.413
- 527: - / Text3: 25.331
- 528: - / Text3: 44.018

| ID | WBS | Task | Duration | Start | Finish | Complete | Baseline start | Baseline finish | Baseline duration | Constraint | Resources | Work | Actual work | Text1 | Text6 | Text8 | Text4 | Text5 | Text3 | Text12 |
| --- | --- | --- | --- | --- | --- | --- | --- | --- | --- | --- | --- | --- | --- | --- | --- | --- | --- | --- | --- | --- |
| 529 | 233 | **System enhancements for fixed broadband access to IMS** | 876d? | 2003-11-05 A | 2007-03-14 A | 100% | 2003-11-05 | 2007-03-14 | 876d? |  | S2,S3,S5,C1,C3,C4 | 36656h | 36656h | FBI | Rel-7 | Maurice |  |  |  |  |
| 530 | 233.1 | **TISPAN Rel 1 related aspects** | 873d? | 2003-11-05 A | 2007-03-09 A | 100% | 2003-11-05 | 2007-03-09 | 873d? |  | S2 | 31568h | 31568h | FBI-TIS1 | Rel-7 | Maurice |  |  |  |  |
| 531 | 233.1.1 | Stage 2 of FBI for TISPAN R1 | 365d? | 2004-10-14 A | 2006-03-08 A | 100% | 2004-10-14 | 2006-03-08 | 365d? | start no earlier than 2004-10-14 | S2 | 2920h | 2920h | FBI-TIS1 | Rel-7 | Maurice |  |  |  |  |
| 532 | 233.1.2 | **Protocol impact of FBI for TISPAN R1** | 873d? | 2003-11-05 A | 2007-03-09 A | 100% | 2003-11-05 | 2007-03-09 | 873d? |  | C1 | 20720h | 20720h | FBI-TIS1 | Rel-7 | Frederic | Siemens | peter.leis@nsn.com |  |  |
| 533 | 233.1.2.1 | CT1 aspects of FBI for TISPAN R1 | 802d? | 2003-11-05 A | 2006-11-30 A | 100% | 2003-11-05 | 2006-11-30 | 802d? | finish no earlier than 2006-11-30 | C1 | 6416h | 6416h | FBI-TIS1 | Rel-7 | Frederic | Siemens | peter.leis@nsn.com | 24.819, 24.229 |  |
| 534 | 233.1.2.2 | CT3 aspects of FBI for TISPAN R1 | 808d? | 2003-11-05 A | 2006-12-08 A | 100% | 2003-11-05 | 2006-12-08 | 808d? | finish no earlier than 2006-12-08 | C3 | 6464h | 6464h | FBI-TIS1 | Rel-7 | Gwiho | Siemens | peter.leis@nsn.com | 29.163, 29.209 |  |
| 535 | 233.1.2.3 | CT4 aspects of FBI for TISPAN R1 | 301d? | 2006-01-13 A | 2007-03-09 A | 100% | 2006-01-13 | 2007-03-09 | 301d? | finish no earlier than 2007-03-09 | C4 | 2408h | 2408h | FBI-TIS1-st3-c4 | Rel-7 | Kimmo | Siemens | peter.leis@nsn.com | 29.229 |  |
| 536 | 233.1.3 | Security Enhancements for FBI | 118d? | 2005-06-28 A | 2005-12-08 A | 100% | 2005-06-28 | 2005-12-08 | 118d? | start no earlier than 2005-06-28 | S3 | 944h | 944h | FBI-ISE | Rel-7 | Dionisio | Ericsson | Bengt.Sahlin@ericsson.com | 33.203 |  |
| 537 | 233.2 | **PacketCable Related aspects** | 291d? | 2006-02-01 A | 2007-03-14 A | 100% | 2006-02-01 | 2007-03-14 | 291d? |  | S2,S5,C1 | 5088h | 5088h | FBI-PCBL | Rel-7 | Maurice | CableLabs | Bernie McKibben |  |  |
| 538 | 233.2.1 | Stage 1,2 of FBI for PacketCable | 228d? | 2006-02-01 A | 2006-12-15 A | 100% | 2006-02-01 | 2006-12-15 | 228d? | finish no earlier than 2006-12-15 | S2 | 1824h | 1824h | FBI-PCBL | Rel-7 | Maurice | CableLabs | Bernie McKibben | 22.228, 23.228 |  |
| 539 | 233.2.2 | Protocol impact of FBI for PacketCable | 228d? | 2006-05-01 A | 2007-03-14 A | 100% | 2006-05-01 | 2007-03-14 | 228d? | finish no earlier than 2007-03-15 | C1 | 1824h | 1824h | FBI-PCBL | Rel-7 | Frederic |  |  |  |  |
| 540 | 233.2.3 | SA5 Charging aspects of FBI for PacketCable | 180d? | 2006-03-31 A | 2006-12-07 A | 100% | 2006-03-31 | 2006-12-07 | 180d? | finish no earlier than 2006-12-07 | S5 | 1440h | 1440h | FBI-PCBL-CH | Rel-7 | Dionisio | CableLabs | Bernie McKibben | 32.240, 32.260, 32.298, 32.299 |  |
| 541 | 234 | **Support of SMS over generic 3GPP IP access** | 696d? | 2004-10-14 A | 2007-06-14 A | 100% | 2004-10-14 | 2007-06-14 | 696d? |  | S2,C4,C1 | 12408h | 12408h | SMSIP | Rel-7 | Maurice | Huawei | zhangwenlin@huawei.com |  |  |
| 542 | 234.1 | FS on SMSIP | 173d? | 2004-10-14 A | 2005-06-13 A | 100% | 2004-10-14 | 2005-06-13 | 173d? | start no earlier than 2004-10-14 | S2 | 1384h | 1384h | SMSIP | Rel-7 | Maurice | Huawei | zhangwenlin@huawei.com | 23.804 |  |
| 543 | 234.2 | Stage 2 for SMSIP | 333d? | 2005-06-08 A | 2006-09-15 A | 100% | 2005-06-08 | 2006-09-15 | 333d? | finish no earlier than 2006-09-15 | S2 | 2664h | 2664h | SMSIP | Rel-7 | Maurice | Huawei | zhangwenlin@huawei.com | 23.204 |  |
| 544 | 234.3 | **Stage 3 for SMSIP** | 527d? | 2005-06-08 A | 2007-06-14 A | 100% | 2005-06-08 | 2007-06-14 | 527d? |  | C4,C1 | 8360h | 8360h | SMSIP-St3 | Rel-7 | Kimmo | Nokia | jari.jansson@nokia.com |  |  |
| 545 | 234.3.1 | CT1 aspects for SMSIP | 527d? | 2005-06-08 A | 2007-06-14 A | 100% | 2005-06-08 | 2007-06-14 | 527d? | finish no earlier than 2007-06-15 | C1 | 4216h | 4216h | SMSIP | Rel-7 | Frederic | Nokia | jari.jansson@nokia.com | 23.040, 24.229 |  |
| 546 | 234.3.2 | CT4 aspects for SMSIP | 518d? | 2005-06-08 A | 2007-06-01 A | 100% | 2005-06-08 | 2007-06-01 | 518d? | finish no earlier than 2007-06-01 | C4 | 4144h | 4144h | SMSIP-St3-c4 | Rel-7 | Kimmo | Nokia | jari.jansson@nokia.com | 23.008, 29.002 |  |
| 547 | 235 | **Evolution of Policy Control and Charging** | 817d? | 2004-10-14 A | 2007-11-30 A | 100% | 2004-10-14 | 2007-11-30 | 817d? |  | S2,S5,C3,C1 | 30336h | 30336h | PCC | Rel-7 | Maurice | Nokia | balazs.bertenyi@nsn.com |  |  |
| 548 | 235.1 | Deleted - TR for PCC | 315d? | 2004-10-14 A | 2005-12-29 A | 100% | 2004-10-14 | 2005-12-29 | 315d? | finish no earlier than 2005-12-28 | S2 | 2520h | 2520h | PCC | Rel-7 | Maurice | Nokia | balazs.bertenyi@nsn.com | 23.803 | SP-33 |
| 549 | 235.2 | Stage 2 for PCC | 315d? | 2005-07-04 A | 2006-09-15 A | 100% | 2005-07-04 | 2006-09-15 | 315d? | finish no earlier than 2006-09-15 | S2 | 2520h | 2520h | PCC | Rel-7 | Maurice | Nokia | balazs.bertenyi@nsn.com | 23.203 |  |
| 550 | 235.3 | Evolution of policy control and flow based bearer level charging | 109d? | 2006-08-01 A | 2006-12-29 A | 100% | 2006-08-01 | 2006-12-29 | 109d? | start no earlier than 2006-08-01 | S2 | 872h | 872h | PCC | Rel-7 | Maurice | Nokia | balazs.bertenyi@nsn.com | 23.207, 23.002, 23.228 |  |
| 551 | 235.4 | SA5 Charging aspects of PCC | 316d? | 2006-03-31 A | 2007-06-15 A | 100% | 2006-03-31 | 2007-06-15 | 316d? | finish no earlier than 2007-06-15 | S5 | 2528h | 2528h | PCC-CH | Rel-7 | Dionisio | Orange | alain.bibas@orange-ft.com | 32.250, 32.251, 32.298, 32.299 |  |
| 552 | 235.5 | Gx reference point for Policy and Charging Control | 521d? | 2005-12-02 A | 2007-11-30 A | 100% | 2005-12-02 | 2007-11-30 | 521d? | finish no earlier than 2007-09-14 | C3 | 4168h | 4168h | PCC-Gx | Rel-7 | Gwiho | Siemens | Thomas.Belling@nsn.com | 29.212 (not progressed to Rel-7: 29.210, 29.207, 29.208) |  |

Notes:
- 529: -
- 530: -
- 531: -
- 532: -
- 533: end date updated by CT1-chairman after CP#33
- 534: -
- 535: CT4#32: a set of CRs on FBI for cable labs
- 536: Duplicated entry ("ACCSEC2", "Access Security Enhancements", SP-040865) deleted by A.Sultan
- 537: -
- 538: -
- 539: -
- 540: 03/2006 SP#31 WID approved
- 541: SP#33 updated WID (removed MMS)
- 542: SP#33 updated WID
- 543: SP#33 updated WID
- 544: CP#34 updated WID
- 545: CP#34 updated WID
- 546: CP#34 updated WID
- 547: SP-29 approved WID. SP-31 updated WID adding SA5 charging. 23.125 will be discontinued from Rel-7.
- 548: SP-30: S2 has no intention for TR completion
- 549: SP-29 approved WID. SP-31 updated WID. 23.125 will be discontinued from Rel-7.
- 550: SP-29 approved WID. SP-31 updated WID. 23.125 will be discontinued from Rel-7.
- 551: SP-31 updated WID with SA5 charging.
- 552: -

| ID | WBS | Task | Type | Duration | Start | Finish | Complete | Baseline start | Baseline finish | Baseline duration | Constraint | Resources | Work | Actual work | Text1 | Text4 | Text5 | Text6 | Text8 | Text3 | Text12 |
| --- | --- | --- | --- | --- | --- | --- | --- | --- | --- | --- | --- | --- | --- | --- | --- | --- | --- | --- | --- | --- | --- |
| 553 | 235.6 | **Rx reference point for PCC CT3 aspects** |  | 521d? | 2005-12-02 A | 2007-11-30 A | 100% | 2005-12-02 | 2007-11-30 | 521d? |  | C3,C1 | 11192h | 11192h | PCC-Rx | Ericsson | j.javier.pastor@ericsson.com | Rel-7 | Gwiho |  |  |
| 554 | 235.6.1 | PCC-Rx CT3 aspects |  | 521d? | 2005-12-02 A | 2007-11-30 A | 100% | 2005-12-02 | 2007-11-30 | 521d? | finish no earlier than 2007-09-14 | C3 | 4168h | 4168h | PCC-Rx-c3 | Ericsson | j.javier.pastor@ericsson.com | Rel-7 | Gwiho | 29.213, 29.214 (not progressed to Rel-7: 29.209, 29.211) |  |
| 555 | 235.6.2 | PCC-Rx CT1 aspects |  | 357d? | 2005-12-02 A | 2007-06-15 A | 100% | 2005-12-02 | 2007-06-15 | 357d? | finish no earlier than 2007-06-15 | C1 | 2856h | 2856h | PCC-Rx-Gx-c1 | Ericsson | j.javier.pastor@ericsson.com | Rel-7 | Frederic | 24.229 |  |
| 556 | 236 | **One Tunnel solution for optimization of Packet Data Traffic** |  | 418d? | 2006-03-27 A | 2007-10-31 A | 100% | 2006-03-27 | 2007-10-31 | 418d? |  | S2 | 7048h | 7048h | OPTUNEL | Nokia | antti.j.pasanen@nokia.com | Rel-7 | Maurice |  |  |
| 557 | 236.1 | Deleted - Study on Stage 2 for One Tunnel solution |  | 125d? | 2006-03-27 A | 2006-09-15 A | 100% | 2006-03-27 | 2006-09-15 | 125d? | finish no earlier than 2005-09-12 | S2 | 1000h | 1000h | OPTUNEL-Study | Nokia | antti.j.pasanen@nokia.com | Rel-7 | Maurice | 23.809 | SP-34 |
| 558 | 236.2 | One Tunnel Deployment Guideline |  | 268d? | 2006-10-23 A | 2007-10-31 A | 100% | 2006-10-23 | 2007-10-31 | 268d? | finish no earlier than 2007-10-31 | S2 | 2144h | 2144h | OPTUNEL-Guide | Huawei | lan.liu@huawei.com | Rel-7 | Maurice | 23.919 |  |
| 559 | 236.3 | Stage 2 specification for One Tunnel solution |  | 70d? | 2006-09-11 A | 2006-12-15 A | 100% | 2006-09-11 | 2006-12-15 | 70d? | finish no earlier than 2006-12-15 | S2 | 560h | 560h | OPTUNEL-Stage2 | Nokia | antti.j.pasanen@nokia.com | Rel-7 | Maurice | 23.060 |  |
| 560 | 237 | **CSI Terminating Session handling** |  | 267d? | 2006-06-08 A | 2007-06-15 A | 100% | 2006-06-08 | 2007-06-15 | 267d? |  | S2,C1 | 4728h | 4728h | CSItermS | Samsung | Osok Song | Rel-7 | Maurice |  |  |
| 561 | 237.1 | Stage 2 of CStermS |  | 192d? | 2006-06-08 A | 2007-03-02 A | 100% | 2006-06-08 | 2007-03-02 | 192d? | start no earlier than 2006-06-08 | S2 | 1536h | 1536h | CSItermS | Samsung | Osok Song | Rel-7 | Maurice | 23.279 |  |
| 562 | 237.2 | Stage 3 of CStermS |  | 132d? | 2006-12-14 A | 2007-06-15 A | 100% | 2006-12-14 | 2007-06-15 | 132d? | finish no earlier than 2007-06-15 | C1 | 1056h | 1056h | CSItermS | Samsung | chenho.chin@samsung.com | Rel-7 | Frederic | 24.229, 24.279 |  |
| 563 | 237.3 | Deleted - duplicated with UID 340015 -Stage 3 CSI Terminating Session handling | milestone | 0d? | 2007-03-09 A | 2007-03-09 A | 100% | 2007-03-09 | 2007-03-09 | 0d? | start no earlier than 2007-03-09 | C1 |  |  | CSItermS | Samsung | chenho.chin@samsung.com | Rel-7 | Frederic | 24.229, 24.179, 24.279 | CP-34 |
| 564 | 238 | Liberty Alliance and 3GPP Security Interworking |  | 451d? | 2005-03-10 A | 2006-11-30 A | 100% | 2005-03-10 | 2006-11-30 | 451d? | finish no earlier than 2006-11-30 | S3 | 3608h | 3608h | LibSec | Nokia | Silke.Holtmanns@NOKIA.COM | Rel-7 | Dionisio | 33.980 |  |
| 565 | 239 | Trust Requirements for Open Platforms in 3GPP |  | 499d? | 2005-01-03 A | 2006-11-30 A | 100% | 2005-01-03 | 2006-11-30 | 499d? | finish no earlier than 2006-11-30 | S3 | 3992h | 3992h | TrustOP | Nokia | Silke.Holtmanns@NOKIA.COM | Rel-7 | Dionisio | 33.905 |  |
| 566 | 240 | Development of UEA2 and UIA2 |  | 268d? | 2004-12-01 A | 2005-12-09 A | 100% | 2004-12-01 | 2005-12-09 | 268d? | finish no earlier than 2005-12-09 | S3 | 2144h | 2144h | AlgUEA2 | TeliaSonera | per.christoffersson@teliasonera.com | Rel-7 | Dionisio | 35.919, 35.215, 35.216, 35.217, 35.218 |  |
| 567 | 241 | Lawful Interception in the 3GPP Rel-7 architecture |  | 118d? | 2005-06-28 A | 2005-12-08 A | 100% | 2005-06-28 | 2005-12-08 | 118d? | start no earlier than 2005-06-28 | S3 | 944h | 944h | LI-7A | BMWI | berthold.wilhelm@regtp.de | Rel-7 | Dionisio | 33.106, 33.107, 33.108 |  |
| 568 | 242 | Key establishment between a UICC and a terminal |  | 201.45d? | 2005-12-07 A | 2006-09-28 A | 100% | 2005-12-07 | 2006-09-28 | 201.45d? | finish no earlier than 2006-09-28 | S3 | 1611.6h | 1611.6h | KeyEstUTerm | Gemalto | mireille.pauliac@gemplus.com | Rel-7 | Dionisio | 33.110 |  |
| 569 | 243 | NDS Authentication Framework Extension for Transport Layer Security |  | 50d? | 2006-09-28 A | 2006-12-06 A | 100% | 2006-09-28 | 2006-12-06 | 50d? | finish no earlier than 2006-09-28 | S3 | 400h | 400h | NDSAFTLS | Nokia | tiina.s.koskinen@nokia.com | Rel-7 | Dionisio | 33.310 |  |
| 570 | 244 | **Security enhancements** |  | 319d? | 2005-09-12 A | 2006-11-30 A | 100% | 2005-09-12 | 2006-11-30 | 319d? |  | S3,C1,C4 | 4856h | 4856h | SEC7 |  |  | Rel-7 | Dionisio |  |  |
| 571 | 244.1 | HTTPS connection between a UICC and a NAF |  | 1d? | 2005-09-12 A | 2005-09-12 A | 100% | 2005-09-12 | 2005-09-12 | 1d? | start no earlier than 2005-09-12 | S3,C1 | 8h | 8h | SEC7-HSUN | Gemalto | JSeif@axalto.com, mireille.pauliac@gemplus.com | Rel-7 | Dionisio | 33.918, 33.222, 24.109 |  |
| 572 | 244.2 | 2G GBA: 2G SIM usage in 3GPP GAA framework |  | 61d? | 2005-09-12 A | 2005-12-05 A | 100% | 2005-09-12 | 2005-12-05 | 61d? | finish no earlier than 2005-12-05 | S3 | 488h | 488h | SEC7-2GGBA | Nokia | Silke.Holtmanns@nokia.com | Rel-7 | Dionisio | 33.920, 33.220 |  |
| 573 | 244.3 | Generic Authentication Architecture usage extensions and optimizations |  | 319d? | 2005-09-12 A | 2006-11-30 A | 100% | 2005-09-12 | 2006-11-30 | 319d? | finish no earlier than 2006-11-30 | S3 | 2552h | 2552h | SEC7-GAA2 | Nokia | Silke.Holtmanns@nokia.com | Rel-7 | Dionisio | 33.220, 29.109, 24.109, (33.223 goes to R8) |  |
| 574 | 244.4 | **SS7 TCAP security Gateway** |  | 241d? | 2005-09-12 A | 2006-08-14 A | 100% | 2005-09-12 | 2006-08-14 | 241d? |  | S3,C4 | 1808h | 1808h | SEC7-NDS-TCAPsec | Siemens | marc.blommaert.ext@nsn.com | Rel-7 | Dionisio |  |  |
| 575 | 244.4.1 | SA3 aspects of SEC7-NDS-TCAPsec |  | 130d? | 2005-09-12 A | 2006-03-10 A | 100% | 2005-09-12 | 2006-03-10 | 130d? | finish no earlier than 2006-03-10 | S3 | 1040h | 1040h | SEC7-NDS-TCAPsec-SA3 | Siemens | marc.blommaert.ext@nsn.com | Rel-7 | Dionisio | 33.204 |  |
| 576 | 244.4.2 | TCAPsec Gateway |  | 96d? | 2006-04-03 A | 2006-08-14 A | 100% | 2006-04-03 | 2006-08-14 | 96d? | start no earlier than 2006-04-01 | C4 | 768h | 768h | SEC7-TCAP | Siemens | Ulrich.wiehe@gksag.de | Rel-7 | Kimmo | 29.204, 29.002 |  |
| 577 | 245 | IMS Stage 3 IETF Protocol alignment |  | 589d? | 2004-12-10 A | 2007-03-14 A | 100% | 2004-12-10 | 2007-03-14 | 589d? | finish no earlier than 2007-03-15 | C1 | 4712h | 4712h | IMSProtoc |  |  | Rel-7 | Frederic | 24.930 |  |

Notes:
- 553: WID approved at CP#30, Revised at CP#31, Revised at CP#33
- 554: -
- 555: -
- 556: -
- 557: S2#52 CREATED. TR for Info SP-33. SP-34: S2 Report intention to discontinue TR
- 558: -
- 559: S2#52 CREATED
- 560: Triggered by the abandoned Study UID_32117
- 561: -
- 562: CP-34 approved WID. CP-35 updated WID
- 563: CP-34 approved WID
- 564: WID approved SP#27.
- 565: WID approved SP#26.
- 566: WID approved SP#26, Dependant on Funding Availability.
- 567: -
- 568: -
- 569: TLS profile is moved to Rel-8
- 570: -
- 571: -
- 572: -
- 573: 33.223 goes to R8
- 574: -
- 575: -
- 576: -
- 577: TR 24.930: Signalling flows for the session setup in the IM CN subsystem based on Session Initiation Protocol (SIP)

| ID | WBS | Task | Type | Duration | Start | Finish | Complete | Baseline start | Baseline finish | Baseline duration | Total slack | Constraint | Resources | Work | Actual work | Text1 | Text4 | Text5 | Text6 | Text8 | Text3 | Text12 | Text2 | Text7 |
| --- | --- | --- | --- | --- | --- | --- | --- | --- | --- | --- | --- | --- | --- | --- | --- | --- | --- | --- | --- | --- | --- | --- | --- | --- |
| 578 | 246 | **Interoperability between VGCS/VBS and A/Gb flexibility** |  | 253d? | 2006-03-22 A | 2007-03-09 A | 100% | 2006-03-22 | 2007-03-09 | 253d? |  |  | C1,C4 | 3296h | 3296h | VGCSFlex | Siemens | robert.zaus@nsn.com | Rel-7 | Frederic |  |  |  |  |
| 579 | 246.1 | CT1 aspects of VGCSFlex |  | 159d? | 2006-03-22 A | 2006-10-30 A | 100% | 2006-03-22 | 2006-10-30 | 159d? |  | finish no earlier than 2006-10-30 | C1 | 1272h | 1272h | VGCSFlex | Siemens | robert.zaus@nsn.com | Rel-7 | Frederic | 43.068, 43.069 |  |  |  |
| 580 | 246.2 | CT4 aspects of VGCSFlex |  | 253d? | 2006-03-22 A | 2007-03-09 A | 100% | 2006-03-22 | 2007-03-09 | 253d? |  | finish no earlier than 2007-03-09 | C4 | 2024h | 2024h | VGCSFlex-c4 | Siemens | robert.zaus@nsn.com | Rel-7 | Kimmo | 29.002 |  |  |  |
| 581 | 247 | DIAMETER on the GGSN Gi interface |  | 586d? | 2004-09-10 A | 2006-12-08 A | 100% | 2004-09-10 | 2006-12-08 | 586d? |  | finish no earlier than 2006-12-08 | C3 | 4688h | 4688h | DIAMGi | Vodafone | Nico.Gabriele@vodafone.com | Rel-7 | Gwiho | 29.061 |  |  |  |
| 582 | 248 | DIAMETER on the PDG Wi interface |  | 586d? | 2004-09-10 A | 2006-12-08 A | 100% | 2004-09-10 | 2006-12-08 | 586d? |  | finish no earlier than 2006-12-08 | C3 | 4688h | 4688h | DIAMWi | Vodafone | Nico.Gabriele@vodafone.com | Rel-7 | Gwiho | 29.161 |  |  |  |
| 583 | 249 | Interworking between the 3GPP CS domain with BICC or ISUP as signalling protocol and external SIP-I networks |  | 478d? | 2006-09-22 A | 2008-07-22 A | 100% | 2006-09-22 | 2008-07-22 | 478d? |  | finish no earlier than 2007-09-14 | C3 | 3824h | 3824h | ExtSIPI | Siemens | Thomas.Belling@nsn.com | Rel-7 | Gwiho | 29.164 |  |  |  |
| 584 | 250 | PDU multiplexing at Nb Interface with IP transport |  | 427d? | 2006-12-04 A | 2008-07-22 A | 100% | 2006-12-04 | 2008-07-22 | 427d? |  | start no earlier than 2006-12-04 | C3 | 3416h | 3416h | NbIPMux | Alcatel-Lucent | Jean.Rzeznik@alcatel-lucent.fr | Rel-7 | Gwiho | 29.414 |  |  |  |
| 585 | 251 | **Mp (MRFC - MRFP) interface** |  | 345d? | 2006-02-13 A | 2007-06-08 A | 100% | 2006-02-13 | 2007-06-08 | 345d? |  |  | C4,C1 | 4384h | 4384h | Mp | Ericsson | philip.hodges@ericsson.com | Rel-7 | Kimmo |  |  |  |  |
| 586 | 251.1 | CT1 aspects of Mp |  | 1d | 2006-02-13 A | 2006-02-13 A | 100% | 2006-02-13 | 2006-02-13 | 1d |  | finish no earlier than 2006-02-13 | C1 | 8h | 8h | Mp | Ericsson | philip.hodges@ericsson.com | Rel-7 | Frederic | 24.229 |  |  |  |
| 587 | 251.2 | Deleted - CT3 aspects of Mp |  | 1d | 2006-09-22 A | 2006-09-22 A | 100% | 2006-09-22 | 2006-09-22 | 1d |  | start no earlier than 2006-09-22 | C3 | 8h | 8h | Mp | Ericsson | philip.hodges@ericsson.com | Rel-7 | Gwiho | 29.162 | CP-33 |  |  |
| 588 | 251.3 | Procedures description |  | 201d? | 2006-06-02 A | 2007-03-09 A | 100% | 2006-06-02 | 2007-03-09 | 201d? |  | finish no earlier than 2007-03-09 | C4 | 1608h | 1608h | Mp-PROCc4 | Huawei | Chencheng@huawei.com | Rel-7 | Kimmo | 23.333 |  |  |  |
| 589 | 251.4 | Stage 3 |  | 345d | 2006-02-13 A | 2007-06-08 A | 100% | 2006-02-13 | 2007-06-08 | 345d |  | finish no earlier than 2007-06-08 | C4 | 2760h | 2760h | Mp-St3c4 | Ericsson | philip.hodges@ericsson.com | Rel-7 | Kimmo | 29.333 |  |  |  |
| 590 | 252 | Routeing of MT-SMS via the HPLMN |  | 71d? | 2006-12-01 A | 2007-03-09 A | 100% | 2006-12-01 | 2007-03-09 | 71d? |  | finish no earlier than 2007-03-09 | C4,C1 | 568h | 568h | SMSviaH | Vodafone | Nick.Russell@vodafone.com | Rel-7 | Kimmo | 23.040, 29.002 |  |  |  |
| 591 | 253 | Mobile Termination whilst the MS is moving to another MSC |  | 60d? | 2007-03-09 A | 2007-05-31 A | 100% | 2007-03-09 | 2007-05-31 | 60d? |  | start no earlier than 2007-03-09 | C4 | 480h | 480h | MTmovMS | Alcatel-Lucent | bruno.landais@alcatel-lucent.fr | Rel-7 | Kimmo | 23.008, 23.012, 23.018, 23.078, 23.079, 29.002 |  |  |  |
| 592 | 254 | ISIM API for Java Card |  | 620d? | 2005-03-14 A | 2007-07-27 A | 100% | 2005-03-14 | 2007-07-27 | 620d? |  | finish no earlier than 2007-07-27 | C6 | 4960h | 4960h | APIJAVA | Sun | Sebastian Hans | Rel-7 | Xavier | 31.103, 102 241 |  |  |  |
| 593 | 255 | Rel-7 (U)SIM API Testing (TS 31.213) |  | 206d? | 2009-05-30 | 2010-03-12 |  | 2009-05-30 | 2010-03-12 | 206d? | 395d | finish no earlier than 2010-03-12 | C6 | 1648h |  | USIM_API_test | Sagem Orga | gerrit.hartbrod@sagem-orga.com | Rel-7 | Xavier | 31.213 |  | PCG-23 | CP-44 |
| 594 | 256 | High speed interface between the UICC and the ME |  | 311d? | 2006-09-22 A | 2007-11-30 A | 100% | 2006-09-22 | 2007-11-30 | 311d? |  | finish no earlier than 2007-11-30 | C6 | 2488h | 2488h | HSI | Gemalto | jacques.seif@GEMALTO.COM | Rel-7 | Xavier | 31.101 |  |  |  |
| 595 | 257 | Video Codec Performance Requirements |  | 634d? | 2005-01-03 A | 2007-06-07 A | 100% | 2005-01-03 | 2007-06-07 | 634d? |  | finish no earlier than 2007-06-07 | S4 | 5072h | 5072h | VICPer | Siemens | juergen.pandel@siemens.com | Rel-7 | Paolo | 26.234, 26.235, 26.346, 26.140, 26.902 |  |  |  |
| 596 | 258 | Dynamic and Interactive Multimedia Scenes |  | 583d? | 2005-03-15 A | 2007-06-07 A | 100% | 2005-03-15 | 2007-06-07 | 583d? |  | finish no earlier than 2007-06-07 | S4 | 4664h | 4664h | DIMS | Streamezzo | gaelle.martin-cocher@streamezzo.com | Rel-7 | Paolo | 26.140, 26.142, 26.234, 26.244, 23.346 |  |  |  |
| 597 | 259 | 3G-324M Video Telephony Call Setup Times Improvements |  | 341d? | 2005-06-08 A | 2006-09-27 A | 100% | 2005-06-08 | 2006-09-27 | 341d? |  | finish no earlier than 2006-09-27 | S4 | 2728h | 2728h | VTCSTI | Vodafone | edward.hall@vodafone.co.uk | Rel-7 | Paolo | 26.911 |  |  |  |
| 598 | 260 | **Optimizations for Multimedia Telephony over IMS** |  | 0d? | 2005-09-28 A | 2005-09-28 A | 100% | 2005-09-28 | 2005-09-28 | 0d? |  |  | S4 |  |  | OMTIMS | Ericsson | olle.franceschi@ericsson.com | Rel-7 | Paolo | 26.235, 26.236 |  |  |  |
| 599 | 260.1 | Deleted - Characterisation of Adaptive Jitter Management Performance for VoIP Services | milestone | 0d? | 2005-09-28 A | 2005-09-28 A | 100% | 2005-09-28 | 2005-09-28 | 0d? |  | start no earlier than 2007-03-15 | S4 |  |  | OMTIMS-CAJMP | Lucent | dhuo@lucent.com | Rel-7 | Paolo |  | SP-35 |  |  |
| 600 | 261 | End-to-End Multimedia Services Performance Metrics |  | 382d? | 2005-09-28 A | 2007-03-15 A | 100% | 2005-09-28 | 2007-03-15 | 382d? |  | finish no earlier than 2007-03-15 | S4 | 3056h | 3056h | E2EMSPM | China Mobile | zhangyanyf@chinamobile.com | Rel-7 | Paolo | 26.944 |  |  |  |
| 601 | 262 | Packet Switched Streaming Enhancements |  | 261d? | 2006-06-08 A | 2007-06-07 A | 100% | 2006-06-08 | 2007-06-07 | 261d? |  | finish no earlier than 2007-06-07 | S4 | 2088h | 2088h | PSSe | Ericsson | olle.franceschi@ericsson.com | Rel-7 | Paolo | 26.234, 26.244 |  |  |  |

Notes:
- 578: Voice Group Call Service
- 579: -
- 580: -
- 581: -
- 582: -
- 583: -
- 584: -
- 585: -
- 586: -
- 587: CP#34: CT3 not involved in Mp interface definition
- 588: -
- 589: -
- 590: WID approved in CP#34
- 591: -
- 592: -
- 593: Update of Rel-6 (U)SIM API for Java Card Testing UID_43007 under Rel-6 UICC/USIM enhancements and interworking UID_1800
- 594: Following ETSI publication of TS 102 600, expected to be completed at CT6 meeting 45
- 595: -
- 596: -
- 597: -
- 598: -
- 599: SP-35 stopped
- 600: -
- 601: -

| ID | WBS | Task | Type | Duration | Start | Finish | Complete | Baseline start | Baseline finish | Baseline duration | Constraint | Resources | Work | Actual work | Text1 | Text4 | Text5 | Text6 | Text8 | Text12 |
| --- | --- | --- | --- | --- | --- | --- | --- | --- | --- | --- | --- | --- | --- | --- | --- | --- | --- | --- | --- | --- |
| 602 | 263 | **OAM&P Rel-7** |  | 472.86d? | 2005-09-02 A | 2007-06-26 A | 100% | 2005-09-02 | 2007-06-26 | 472.86d? |  | S5 | 82725.8h | 82725.8h | OAM7 | Huawei | Christian.Toche@huawei.com | Rel-7 | Dionisio |  |
| 603 | 263.1 | **Network Infrastructure Management** |  | 465d? | 2005-09-02 A | 2007-06-14 A | 100% | 2005-09-02 | 2007-06-14 | 465d? |  | S5 | 41800h | 41800h | OAM7-NIM |  |  | Rel-7 | Dionisio |  |
| 604 | 263.1.1 | Enhance NRM to accommodate NGN (IMS as basis of the Next Generation Network) |  | 465d? | 2005-09-02 A | 2007-06-14 A | 100% | 2005-09-02 | 2007-06-14 | 465d? | finish no earlier than 2007-06-14 | S5 | 3720h | 3720h | OAM7-NIM | Motorola |  | Rel-7 | Dionisio |  |
| 605 | 263.1.2 | Co-operative Element Management interface (CO-OP) (Study + Implementation) |  | 400d? | 2005-09-02 A | 2007-03-15 A | 100% | 2005-09-02 | 2007-03-15 | 400d? | finish no earlier than 2007-03-15 | S5 | 3200h | 3200h | OAM7-NIM | Motorola |  | Rel-7 | Dionisio |  |
| 606 | 263.1.3 | Network Management (NM) Itf-N performance criteria |  | 465d? | 2005-09-02 A | 2007-06-14 A | 100% | 2005-09-02 | 2007-06-14 | 465d? | finish no earlier than 2007-06-14 | S5 | 3720h | 3720h | OAM7-NIM | China Mobile |  | Rel-7 | Dionisio |  |
| 607 | 263.1.4 | Delta synchronization between IRP Manager and IRP Agent (Study + Implementation) |  | 465d? | 2005-09-02 A | 2007-06-14 A | 100% | 2005-09-02 | 2007-06-14 | 465d? | finish no earlier than 2007-06-14 | S5 | 3720h | 3720h | OAM7-NIM | Siemens |  | Rel-7 | Dionisio |  |
| 608 | 263.1.5 | Subscription Management (SuM) IRP Solution Sets |  | 330d? | 2005-09-02 A | 2006-12-07 A | 100% | 2005-09-02 | 2006-12-07 | 330d? | finish no earlier than 2006-12-07 | S5 | 2640h | 2640h | OAM7-NIM | Ericsson |  | Rel-7 | Dionisio |  |
| 609 | 263.1.6 | Integration Reference Point (IRP) Security Management |  | 400d? | 2005-09-02 A | 2007-03-15 A | 100% | 2005-09-02 | 2007-03-15 | 400d? | finish no earlier than 2007-03-15 | S5 | 3200h | 3200h | OAM7-NIM | Huawei | Christian.Toche@huawei.com | Rel-7 | Dionisio |  |
| 610 | 263.1.7 | Partial suspension of Itf-N during maintenance/testing (Study + Implementation) |  | 465d? | 2005-09-02 A | 2007-06-14 A | 100% | 2005-09-02 | 2007-06-14 | 465d? | finish no earlier than 2007-06-14 | S5 | 3720h | 3720h | OAM7-NIM | Siemens |  | Rel-7 | Dionisio |  |
| 611 | 263.1.8 | Deleted - Management of Legacy Equipment |  | 336d? | 2005-09-02 A | 2006-12-15 A | 100% | 2005-09-02 | 2006-12-15 | 336d? | finish no earlier than 2006-12-15 | S5 | 2688h | 2688h | OAM7-NIM | Siemens |  | Rel-7 | Dionisio | SP-35 |
| 612 | 263.1.9 | Deleted - Rules for Vendor Specific Extensions |  | 400d? | 2005-09-02 A | 2007-03-15 A | 100% | 2005-09-02 | 2007-03-15 | 400d? | finish no earlier than 2007-03-15 | S5 | 3200h | 3200h | OAM7-NIM | Siemens |  | Rel-7 | Dionisio | SP-35 |
| 613 | 263.1.10 | Backward and Forward Compatibility of IRP systems |  | 465d? | 2005-09-02 A | 2007-06-14 A | 100% | 2005-09-02 | 2007-06-14 | 465d? | finish no earlier than 2007-06-14 | S5 | 3720h | 3720h | OAM7-NIM | Ericsson |  | Rel-7 | Dionisio |  |
| 614 | 263.1.11 | Repeater Network Resource Model (NRM) definition |  | 214d? | 2006-02-13 A | 2006-12-07 A | 100% | 2006-02-13 | 2006-12-07 | 214d? | finish no earlier than 2006-12-07 | S5 | 1712h | 1712h | OAM7-NIM | China Mobile |  | Rel-7 | Dionisio |  |
| 615 | 263.1.12 | UTRAN radio channel power monitoring |  | 284d? | 2006-02-13 A | 2007-03-15 A | 100% | 2006-02-13 | 2007-03-15 | 284d? | finish no earlier than 2007-03-15 | S5 | 2272h | 2272h | OAM7-NIM | China Mobile |  | Rel-7 | Dionisio |  |
| 616 | 263.1.13 | Notification XML Schema |  | 71d? | 2006-12-07 A | 2007-03-15 A | 100% | 2006-12-07 | 2007-03-15 | 71d? | finish no earlier than 2007-03-15 | S5 | 568h | 568h | OAM7-NIM | Huawei | Christian.Toche@huawei.com | Rel-7 | Dionisio |  |
| 617 | 263.2 | **Performance Management** |  | 465d? | 2005-09-02 A | 2007-06-14 A | 100% | 2005-09-02 | 2007-06-14 | 465d? |  | S5 | 22992h | 22992h | OAM7-PM |  |  | Rel-7 | Dionisio |  |
| 618 | 263.2.1 | Performance measurements definition for CN CS |  | 400d? | 2005-09-02 A | 2007-03-15 A | 100% | 2005-09-02 | 2007-03-15 | 400d? | finish no earlier than 2007-03-15 | S5 | 3200h | 3200h | OAM7-PM | China Mobile |  | Rel-7 | Dionisio |  |
| 619 | 263.2.2 | Enhancement UTRAN performance measurements definition |  | 465d? | 2005-09-02 A | 2007-06-14 A | 100% | 2005-09-02 | 2007-06-14 | 465d? | finish no earlier than 2007-06-14 | S5 | 3720h | 3720h | OAM7-PM | China Mobile |  | Rel-7 | Dionisio |  |
| 620 | 263.2.3 | Add TDD specific counters in Performance measurement |  | 330d? | 2005-09-02 A | 2006-12-07 A | 100% | 2005-09-02 | 2006-12-07 | 330d? | finish no earlier than 2006-12-15 | S5 | 2640h | 2640h | OAM7-PM | CATT |  | Rel-7 | Dionisio |  |
| 621 | 263.2.4 | ATM bearer network Performance measurements |  | 400d? | 2005-09-02 A | 2007-03-15 A | 100% | 2005-09-02 | 2007-03-15 | 400d? | finish no earlier than 2007-03-15 | S5 | 3200h | 3200h | OAM7-PM | ZTE |  | Rel-7 | Dionisio |  |
| 622 | 263.2.5 | Performance measurements definition for IMS |  | 465d? | 2005-09-02 A | 2007-06-14 A | 100% | 2005-09-02 | 2007-06-14 | 465d? | finish no earlier than 2007-06-14 | S5 | 3720h | 3720h | OAM7-PM | China Mobile |  | Rel-7 | Dionisio |  |
| 623 | 263.2.6 | HSDPA performance measurements |  | 349d? | 2006-02-13 A | 2007-06-14 A | 100% | 2006-02-13 | 2007-06-14 | 349d? | finish no earlier than 2007-06-14 | S5 | 2792h | 2792h | OAM7-PM | China Mobile |  | Rel-7 | Dionisio |  |
| 624 | 44.5 | **Trace Management** |  | 472.86d? | 2005-09-02 A | 2007-06-26 A | 100% | 2005-09-02 | 2007-06-26 | 472.86d? |  | S5 | 14150.9h | 14150.9h | OAM7-Trace | Vodafone |  | Rel-7 | Dionisio |  |
| 625 | 263.3.1 | End-to-end Service Level tracing for IMS |  | 350d? | 2005-11-11 A | 2007-03-15 A | 100% | 2005-11-11 | 2007-03-15 | 350d? | finish no earlier than 2007-03-15 | S5 | 2800h | 2800h | OAM7-Trace | Vodafone |  | Rel-7 | Dionisio | SP-31 |
| 626 | 263.3.2 | Trace record content for UTRAN TDD |  | 330d? | 2005-09-02 A | 2006-12-07 A | 100% | 2005-09-02 | 2006-12-07 | 330d? | finish no earlier than 2006-12-07 | S5 | 2640h | 2640h | OAM7-Trace | Nokia |  | Rel-7 | Dionisio |  |
| 627 | 263.3.3 | IRP for Subscriber and Equipment Trace Management |  | 465d? | 2005-09-02 A | 2007-06-14 A | 100% | 2005-09-02 | 2007-06-14 | 465d? | finish no earlier than 2007-06-14 | S5 | 3720h | 3720h | OAM7-Trace | Nokia |  | Rel-7 | Dionisio |  |
| 628 | 263.3.4 | Deleted - SIP enhancements for trace | milestone | 0d? | 2007-06-15 A | 2007-06-26 A | 100% | 2007-06-15 | 2007-06-26 | 0d? | start no earlier than 2007-06-15 | C1 |  |  | OAM7-Trace |  |  | Rel-7 | Frederic | CP-32 |
| 629 | 263.3.5 | Deleted - duplicated with UID 35063 - IRP for Subscriber and Equipment Trace Management |  | 336d? | 2005-09-02 A | 2006-12-15 A | 100% | 2005-09-02 | 2006-12-15 | 336d? | finish no earlier than 2006-12-15 | S5 | 2688h | 2688h | OAM7-Trace | Nokia |  | Rel-7 | Dionisio | SP-33 |

Notes:
- 602: -
- 603: -
- 604: - / Text3: 32.731/2/3/5, 32.631/2/3/5
- 605: - / Text3: 32.806, 32.814, 32.101
- 606: - / Text3: 32.811
- 607: - / Text3: 32.391/2/3/5
- 608: - / Text3: 32.307/317/607/667/665, 32.101, 32.175
- 609: - / Text3: 32.372/3/5, 32.111,32.30x,32.32x,32.33x,32.34x,32.35x,32.36x,32.41x,32.60x,32.61x,32.66x
- 610: - / Text3: 32.381/2/3/5
- 611: Request to TSG#35 to STOP the WI / Text3: new 32.xxx
- 612: Request to TSG#35 to STOP the WI / Text3: 32.62n; For n = 1 to 5
- 613: - / Text3: 32.154
- 614: - / Text3: 32.721/2/3/5
- 615: - / Text3: 32.405, 32.64n; For n = 1 to 5
- 616: 12/2006 SP#34 WID approved / Text3: New 32.325/345/365/415, CR to 32.335/615/665
- 617: -
- 618: - / Text3: 32.407, 32.408
- 619: - / Text3: 32.405
- 620: - / Text3: 32.405
- 621: - / Text3: No impact on 32.404, 32.405, 32.406, 32.407
- 622: - / Text3: 32.404,32.409,32.437, 32.632/3/4/5
- 623: - / Text3: 32.405
- 624: -
- 625: 07/2005: OMA (Stage 1), Stage 2/3 SA5, CT1/3/4 / Text3: CR 32.101, 32.421/2/3.
- 626: - / Text3: CR 32.421/2/3.
- 627: - / Text3: 32.441/2/3/5, CRs 32.632/3/5
- 628: combined with UID 11067
- 629: - / Text3: 32.421,32.422,32.423. 3 new 32.4x1,2,3

| ID | WBS | Task | Type | Duration | Start | Finish | Complete | Baseline start | Baseline finish | Baseline duration | Constraint | Deadline | Resources | Work | Actual work | Text1 | Text4 | Text5 | Text6 | Text8 | Text11 | Text12 | Text9 | Text10 |
| --- | --- | --- | --- | --- | --- | --- | --- | --- | --- | --- | --- | --- | --- | --- | --- | --- | --- | --- | --- | --- | --- | --- | --- | --- |
| 630 | 264 | **Charging Management small Enhancements Rel-7** |  | 279d? | 2006-05-22 A | 2007-06-14 A | 100% | 2006-05-22 | 2007-06-14 | 279d? |  |  | S5 | 5952h | 5952h | CH7 | Orange | alain.bibas@orange-ft.com | Rel-7 | Dionisio |  |  |  |  |
| 631 | 264.1 | Alternate Charged Party (ACP) for IMS |  | 279d? | 2006-05-22 A | 2007-06-14 A | 100% | 2006-05-22 | 2007-06-14 | 279d? | finish no earlier than 2007-06-14 |  | S5 | 2232h | 2232h | CH7-IMS-ACP | Lucent | njmazzarella@alcatel-lucent.com | Rel-7 | Dionisio |  |  |  |  |
| 632 | 264.2 | Align 3GPP Charging with OMA PoC Enabler Release 2.0 |  | 186d? | 2006-09-28 A | 2007-06-14 A | 100% | 2006-09-28 | 2007-06-14 | 186d? | finish no earlier than 2007-06-14 |  | S5 | 1488h | 1488h | CH7-PoC | Siemens | Gerald GÖRMER | Rel-7 | Dionisio |  |  |  |  |
| 633 | 8.5 | **Multiple Input Multiple Output antennas (MIMO)** |  | 1177d? | 2003-03-14 A | 2007-09-17 A | 100% | 2003-03-14 | 2007-09-17 | 1177d? |  |  | R1 | 40272h | 40272h | MIMO | Alcatel-Lucent | hchuang@Alcatel-Lucent.com | Rel-7 | Patrick | RP-070037, RP-070531 |  |  |  |
| 634 | 265.1 | MIMO - Physical layer |  | 915d? | 2003-09-12 A | 2007-03-15 A | 100% | 2003-09-12 | 2007-03-15 | 915d? | finish no earlier than 2007-03-15 |  | R1 | 7320h | 7320h | MIMO-Phys | Alcatel-Lucent | hchuang@Alcatel-Lucent.com | Rel-7 | Patrick | RP-070037 |  |  |  |
| 635 | 265.2 | MIMO - Layer 2,3 aspects |  | 915d? | 2003-09-12 A | 2007-03-15 A | 100% | 2003-09-12 | 2007-03-15 | 915d? | finish no earlier than 2007-03-15 |  | R2 | 7320h | 7320h | MIMO-L23 | Alcatel-Lucent | hchuang@Alcatel-Lucent.com | Rel-7 | Joern | RP-070037 |  |  |  |
| 636 | 265.3 | MIMO - Iub/Iur Protocol Aspects |  | 1045d? | 2003-03-14 A | 2007-03-15 A | 100% | 2003-03-14 | 2007-03-15 | 1045d? | finish no earlier than 2007-03-15 |  | R3 | 8360h | 8360h | MIMO-IurIub | Alcatel-Lucent | hchuang@Alcatel-Lucent.com | Rel-7 | Juha | RP-070037 |  |  |  |
| 637 | 265.4 | MIMO - RF Radio Transmission/Reception, System Performance Requirements and Conformance Testing |  | 982d? | 2003-12-12 A | 2007-09-17 A | 100% | 2003-12-12 | 2007-09-17 | 982d? | finish no earlier than 2007-09-17 |  | R4 | 7856h | 7856h | MIMO-RF | Alcatel-Lucent | ngm@Alcatel-Lucent.com | Rel-7 | Issam | RP-070531 |  |  |  |
| 638 | 266 | **Rel-7 Improvements of the Radio Interface** |  | 709d? | 2004-09-15 A | 2007-06-04 A | 100% | 2004-09-15 | 2007-06-04 | 709d? |  |  | RP | 29696h | 29696h | RInImp |  |  | Rel-7 | Issam |  |  |  |  |
| 639 | 266.1 | Extended UMTS 1.7/2.1 GHz |  | 198d? | 2006-03-15 A | 2006-12-15 A | 100% | 2006-03-15 | 2006-12-15 | 198d? | finish no earlier than 2006-12-15 |  | R4 | 1584h | 1584h | RInImp-UMTS1721Ext | Ericsson | Johan Sköld (johan.skold@ericsson.com) | Rel-7 | Issam | RP-060681 |  |  |  |
| 640 | 266.2 | UMTS 2.6 GHz 7.68 Mcps TDD |  | 67d? | 2006-06-15 A | 2006-09-15 A | 100% | 2006-06-15 | 2006-09-15 | 67d? | finish no earlier than 2006-09-15 |  | R4 | 536h | 536h | RInImp-UMTS26VHCRTDD | IPWireless | Shin Horng Wong (shwong@ipwireless.com) | Rel-7 | Issam | RP-060451 |  |  |  |
| 641 | 266.3 | UMTS 2.6 GHz |  | 195d? | 2004-09-15 A | 2005-06-14 A | 100% | 2004-09-15 | 2005-06-14 | 195d? | finish no earlier than 2005-06-14 |  | R4 | 1560h | 1560h | RInImp-UMTS2600 | Nokia | jussi.numminen@nokia.com | Rel-7 | Issam | RP-050184 |  |  |  |
| 642 | 266.4 | UMTS 2.6 GHz TDD |  | 261d? | 2004-12-15 A | 2005-12-14 A | 100% | 2004-12-15 | 2005-12-14 | 261d? | finish no earlier than 2005-12-15 |  | R4 | 2088h | 2088h | RInImp-UMTS2600TDD | IPWireless | Shin Horng Wong (shwong@ipwireless.com) | Rel-7 | Issam | RP-050661 |  |  |  |
| 643 | 266.5 | UMTS 900 MHz |  | 261d? | 2004-12-15 A | 2005-12-14 A | 100% | 2004-12-15 | 2005-12-14 | 261d? | finish no earlier than 2005-12-15 |  | R4 | 2088h | 2088h | RInImp-UMTS900 | Nortel | Yannick Li (yli@nortelnetworks.com) | Rel-7 | Issam | RP-050662 |  |  |  |
| 644 | 266.6 | UMTS 1700 MHz |  | 197d? | 2005-03-15 A | 2005-12-14 A | 100% | 2005-03-15 | 2005-12-14 | 197d? | finish no earlier than 2005-12-15 |  | R4 | 1576h | 1576h | RInImp-UMTS1700 | NTT DoCoMo | Takehiro Nakamura (nakamurata@nttdocomo.co.jp) | Rel-7 | Issam | RP-050824 |  |  |  |
| 645 | 266.7 | UE Antenna Performance Evaluation Method and Requirements |  | 644d? | 2004-12-15 A | 2007-06-04 A | 100% | 2004-12-15 | 2007-06-04 | 644d? | finish no earlier than 2007-06-04 |  | R4 | 5152h | 5152h | RInImp-UEAnt | TeliaSonera | Christian.Bergljung@TeliaSonera.com | Rel-7 | Issam | RP-070281 |  |  |  |
| 646 | 266.8 | Improved Performance Requirements for HSDPA UE based on Rx Diversity (type 1) & LMMSE equalizer (type 2) | milestone | 0d? | 2005-03-15 A | 2005-03-15 A | 100% | 2005-03-15 | 2005-03-15 | 0d? | finish no earlier than 2005-03-15 |  | R4 |  |  | RInImp-HSPerf-Type3 | Cingular | Marc Grant | Rel-7 | Issam | RP-060015 |  |  |  |
| 647 | 266.9 | **Additional minimum UE performance requirement for non-HSDPA channels based on type 1 enhanced receiver (Rx Diversity)** |  | 327d? | 2005-09-15 A | 2006-12-15 A | 100% | 2005-09-15 | 2006-12-15 | 327d? |  |  | R4 | 7344h | 7344h | RInImp-RxDiv | Qualcomm Europe | Serge Willenegger (sergew@qualcomm.com) | Rel-7 | Issam |  |  |  |  |
| 648 | 266.9.1 | Additional minimum UE performance requirement for DL physical channels in support of DCH/HS-DSCH operation based on type 1 enhanced receiver (RX-Diversity) |  | 195d? | 2005-09-15 A | 2006-06-14 A | 100% | 2005-09-15 | 2006-06-14 | 195d? | finish no earlier than 2006-06-15 |  | R4 | 1560h | 1560h | RInImp-RxDiv-DCH | Cingular | Marc Grant | Rel-7 | Issam | RP-060235 |  |  |  |
| 649 | 266.9.2 | Additional minimum UE performance requirement for downlink physical channels in support of MTCH and MCCH operation based on type 1 enhanced receiver (Rx-Diversity) |  | 198d? | 2006-03-15 A | 2006-12-15 A | 100% | 2006-03-15 | 2006-12-15 | 198d? | finish no earlier than 2006-12-15 |  | R4 | 1584h | 1584h | RInImp-RxDiv-MBMS | Qualcomm Europe | Serge Willenegger (sergew@qualcomm.com) | Rel-7 | Issam | RP-060678 |  |  |  |
| 650 | 266.9.3 | Additional minimum UE performance requirement for downlink physical channels in support of E-DCH operation based on type 1 enhanced receiver (Rx-Diversity) |  | 198d? | 2006-03-15 A | 2006-12-15 A | 100% | 2006-03-15 | 2006-12-15 | 198d? | finish no earlier than 2006-12-15 |  | R4 | 1584h | 1584h | RInImp-RxDiv-EDCH | Qualcomm Europe | Serge Willenegger (sergew@qualcomm.com) | Rel-7 | Issam | RP-060679 |  |  |  |
| 651 | 266.10 | Deleted Improved support of gaming over HSDPA/EDCH |  | 262d? | 2005-12-15 A | 2006-12-15 A | 100% | 2005-12-15 | 2006-12-15 | 262d? | finish no earlier than 2006-12-15 |  | R2 | 2096h | 2096h | RInImp-Gaming | Cingular | Don Zelmer (dz1069@att.com) | Rel-7 | Joern | RP-060680 | RP-34 |  |  |
| 652 | 266.11 | Deleted (not approved at PCG) - UMTS 2.6 GHz FDD DL External | milestone | 0d? | 2005-09-15 A | 2005-09-15 A | 100% | 2005-09-15 | 2005-09-15 | 0d? | finish no earlier than 2005-09-15 |  | R4 |  |  | RInImp-UMTS2600Ext | T-mobile | han.van.bussel@t-mobile.de | Rel-7 | Issam |  | RP-31 | PCG-16 |  |
| 653 | 267 | **Rel-7 Improvements of the Radio Interface - UE Conformance Testing** |  | 741d? | 2005-11-11 A | 2008-09-12 A | 100% | 2005-11-11 | 2008-09-12 | 741d? |  |  | R5 | 17568h | 17568h | RInImp-UEConTest |  |  | Rel-7 | Ingbert |  |  |  |  |
| 654 | 16.5.1 | UE Conformance Test for UMTS 2600 MHz |  | 146d | 2005-11-11 A | 2006-06-02 A | 100% | 2005-11-11 | 2006-06-02 | 146d | finish no earlier than 2006-06-02 | 2006-06-02 | R5 | 1168h | 1168h | RInImp-UMTS2600_Test | Nokia | Aleksi.Heino@nokia.com | Rel-7 | Ingbert |  |  |  | Fri 7/11/05 |
| 655 | 16.5.1 | UE Conformance Test for UMTS 900 MHz (band VIII) |  | 146d | 2005-11-11 A | 2006-06-02 A | 100% | 2005-11-11 | 2006-06-02 | 146d | finish no earlier than 2006-06-02 | 2006-06-02 | R5 | 1168h | 1168h | RInImp-UMTS900_Test | Qualcomm Europe | hanye@qualcomm.com | Rel-7 | Ingbert |  |  |  | Fri 11/03/05 |
| 656 | 267.3 | Conformance Test Aspects – Improved Performance of HSDPA Receiver type 3 |  | 191d? | 2006-03-10 A | 2006-12-01 A | 100% | 2006-03-10 | 2006-12-01 | 191d? | finish no earlier than 2006-12-01 |  | R5 | 1528h | 1528h | RInImp-HSPerf-Type3_Test | Motorola | carolyn.taylor@motorola.com | Rel-7 | Ingbert |  |  |  |  |
| 657 | 267.4 | UE antenna Over The Air (OTA) conformance testing |  | 518d? | 2006-09-20 A | 2008-09-12 A | 100% | 2006-09-20 | 2008-09-12 | 518d? | finish no earlier than 2008-09-12 |  | R5 | 4144h | 4144h | RInImp-UEAnt_Test | Nokia | Aleksi.Heino@nokia.com | Rel-7 | Ingbert | RP-080535 |  |  |  |
| 658 | 267.5 | UE conformance testing for FDD Inter-Band Operation |  | 131d? | 2006-06-02 A | 2006-12-01 A | 100% | 2006-06-02 | 2006-12-01 | 131d? | finish no earlier than 2006-12-01 |  | R5 | 1048h | 1048h | RInImp-InterBand_Test | NEC, Motorola | Jacob.John@motorola.com | Rel-7 | Ingbert |  |  |  |  |
| 659 | 267.6 | Conformance Test Aspects – Extended UMTS 1.7/2.1 GHz |  | 131d? | 2006-12-01 A | 2007-06-01 A | 100% | 2006-12-01 | 2007-06-01 | 131d? | finish no earlier than 2007-06-01 |  | R5 | 1048h | 1048h | RInImp-UEConTest_UMTS1721Ext | Motorola | carolyn.taylor@motorola.com | Rel-7 | Ingbert |  |  |  |  |
| 660 | 267.7 | Conformance Test Aspects – Minimum UE performance requirement for downlink physical channels in support of E-DCH operation based on type 1 enhanced receiver (Rx-Diversity) |  | 136d? | 2007-06-01 A | 2007-12-07 A | 100% | 2007-06-01 | 2007-12-07 | 136d? | finish no earlier than 2007-12-07 |  | R5 | 1088h | 1088h | RInImp-UEConTest_RxDivEDCH | Motorola | carolyn.taylor@motorola.com | Rel-7 | Ingbert |  |  |  |  |
| 661 | 267.8 | Conformance Test Aspects – Minimum UE performance requirement for downlink physical channels in support of MTCGH and MCCH operation based on type 1 enhanced receiver (Rx-Diversity) |  | 201d? | 2007-06-01 A | 2008-03-07 A | 100% | 2007-06-01 | 2008-03-07 | 201d? | finish no earlier than 2008-03-07 |  | R5 | 1608h | 1608h | RInImp-UEConTest_RxDivMBMS | Ericsson | leif.mattisson@ericsson.com | Rel-7 | Ingbert | RP-080056 |  |  |  |

Notes:
- 630: -
- 631: - / Text3: 32.240, 32.260, 32.298, 32.299
- 632: 09/2006 SP#33 WID approved / Text3: 32.240, 32.272, 32.299, 32.298
- 633: Completed Sep 2007; SR in RP-070037and RP-070531 / Text3: 25.876, 25.996
- 634: Completed Sep 2007; SR in RP-070037 / Text3: 25.211, 25.212, 25.213, 25.214, 25.215, 25.221
- 635: Completed Sep 2007; SR in RP-070037 / Text3: 25.876
- 636: Completed Sep 2007; SR in RP-070037
- 637: Completed Sep 2007; SR in RP-070531
- 638: Generic feature
- 639: SR in RP-060681. Introduction of Band X (Extended UMTS 1.7/2.1 GHz) in 25.307 / Text3: 25.806, 25.101, 25.104, 25.133, 24.141, 25.331, 25.306, 25.307, 25.423, 25.461, 25.463, 34.121
- 640: Completed Sep 2006; SR in RP-060451 / Text3: 25.102, 25.105, 25.123, 25.113, 25.142, 34.124
- 641: SR in RP-050184. Introduction of UMTS2600 internal band, Band VII in 25.307 / Text3: 25.101, 25.104, 25.133, 25.141, 25.331, 25.942, 25.306, 25.307, 34.121
- 642: SR in RP-050661 / Text3: 25.102, 25.105, 25.113, 25.123, 25.142, 25.331, 25.942, 25.306, 25.307, 34.122, 34.124
- 643: SR in RP-050662. Introduction of UMTS 900 (Band VIII) in 25.307 / Text3: 25.101, 25.104, 25.113, 25.133, 25.141, 25.331, 25.942, 25.306, 25.307, 34.121
- 644: SR in RP-050824 / Text3: 25.101, 25.104, 25.113, 25.133, 25.141, 25.306, 25.307, 25.331, 34.121
- 645: RP#36 (May 2007) completed. SR in RP-070281 / Text3: 25.101, 25.963
- 646: Completed Mar 2006, SR in RP-060015 / Text3: 25.101
- 647: - / Text3: 25.101
- 648: Completed Jun 2006, SR in RP-060235 / Text3: 25.101
- 649: Completed Dec 2006, SR in RP-060678 / Text3: 25.101
- 650: Completed Dec 2006, SR in RP-060679 / Text3: 25.101
- 651: RP#34 (Dec 2006) stopped. SR in RP-060680
- 652: This item was conditionnaly approved pending decision of PCG 16 who decided not to approve it / Text3: 25.101, 25.104, 25.133, 25.141, 25.331, 25.942, 25.306, 25.307, 34.121
- 653: 05/08: Linked to Feature UID_20028 (RInImp)
- 654: - / Text3: 34.108, 34.121
- 655: - / Text3: 34.108, 34.121
- 656: - / Text3: 34.121, 34.108
- 657: SR in RP-080535. RP#41 completed (GERAN aspects might need to be included later) / Text3: 34.114
- 658: - / Text3: 34.108, 34.123-1, 34.123-2, 34.123-3
- 659: - / Text3: 34.108, 34.121-1, 34.121-2
- 660: -
- 661: SR in RP-080056

| ID | WBS | Task | Duration | Start | Finish | Complete | Baseline start | Baseline finish | Baseline duration | Constraint | Resources | Work | Actual work | Text1 | Text6 | Text4 | Text5 | Text8 | Text11 |
| --- | --- | --- | --- | --- | --- | --- | --- | --- | --- | --- | --- | --- | --- | --- | --- | --- | --- | --- | --- |
| 662 | 268 | **Rel-7 RAN improvements** | 653d? | 2004-12-15 A | 2007-06-15 A | 100% | 2004-12-15 | 2007-06-15 | 653d? |  | RP | 29920h | 29920h | RANimp | Rel-7 |  |  |  |  |
| 663 | 268.1 | Optimization of channelisation code utilisation for 1.28 Mcps TDD | 523d? | 2004-12-15 A | 2006-12-15 A | 100% | 2004-12-15 | 2006-12-15 | 523d? | finish no earlier than 2006-12-15 | R1 | 4184h | 4184h | RANimp-RABSE-CodOptLCRTDD | Rel-7 | UTStarcom | Ka Leong Lo (kaleong.lo@UTSTAR.COM) | Patrick | RP-060682 |
| 664 | 268.2 | Delay optimization for procedures applicable to CS and PS Connections | 394d? | 2005-03-15 A | 2006-09-15 A | 100% | 2005-03-15 | 2006-09-15 | 394d? | finish no earlier than 2006-09-15 | R2 | 3152h | 3152h | RANimp-DelayOpt | Rel-7 | Nokia | juho.pirskanen@nokia.com | Joern | RP-060453 |
| 665 | 268.3 | Improved support of IMS Realtime Services using HSDPA/HSUPA | 197d? | 2005-03-15 A | 2005-12-14 A | 100% | 2005-03-15 | 2005-12-14 | 197d? | start no earlier than 2005-03-15 | R2 | 1576h | 1576h | RANimp-IMSRealTime | Rel-7 | Cingular | Don Zelmer (dz1069@att.com) | Joern | RP-050667 |
| 666 | 268.4 | UE Performance Requirements for MBMS (TDD) | 328d? | 2005-03-15 A | 2006-06-15 A | 100% | 2005-03-15 | 2006-06-15 | 328d? | finish no earlier than 2006-06-15 | R4 | 2624h | 2624h | MBMS-RAN-RF-TDD | Rel-7 | IPwireless | shwong@ipwireless.com | Issam | RP-060477 |
| 667 | 268.5 | Continuous connectivity for packet data users | 524d? | 2005-03-14 A | 2007-03-15 A | 100% | 2005-03-14 | 2007-03-15 | 524d? | finish no earlier than 2007-03-15 | R1 | 4192h | 4192h | RANimp-CPC | Rel-7 | Siemens | Joern.Krause@siemens.com | Patrick | RP-070033 |
| 668 | 268.6 | Extended WCDMA Cell Range | 198d? | 2006-03-15 A | 2006-12-15 A | 100% | 2006-03-15 | 2006-12-15 | 198d? | finish no earlier than 2006-12-15 | R3 | 1584h | 1584h | RANimp-ExtCell | Rel-7 | Ericsson | Muhammad Kazmi | Juha | RP-060685 |
| 669 | 268.7 | 7.68 Mcps TDD Enhanced Uplink | 198d? | 2006-03-15 A | 2006-12-15 A | 100% | 2006-03-15 | 2006-12-15 | 198d? | finish no earlier than 2006-12-15 | R1 | 1584h | 1584h | RANimp-VHCRTDD-EDCH | Rel-7 | IPwireless | nanderson@ipwireless.com | Patrick | RP-060684 |
| 670 | 268.8 | Enhanced CELL_FACH State in FDD | 181d? | 2006-09-25 A | 2007-06-04 A | 100% | 2006-09-25 | 2007-06-04 | 181d? | finish no earlier than 2007-06-04 | R2 | 1448h | 1448h | RANimp-EnhState | Rel-7 | Nokia | juho.pirskanen@nokia.com | Joern | RP-070286 |
| 671 | 268.9 | 64QAM for HSDPA (FDD) | 110d? | 2006-12-15 A | 2007-06-04 A | 100% | 2006-12-15 | 2007-06-04 | 110d? | finish no earlier than 2007-06-04 | R1 | 880h | 880h | RANimp-64QamDownlink | Rel-7 | Ericsson | Johan.Bergman@ericsson.com | Patrick | RP-070287 |
| 672 | 268.10 | Improved L2 support for high data rates | 122d? | 2006-12-15 A | 2007-06-04 A | 100% | 2006-12-15 | 2007-06-04 | 122d? | finish no earlier than 2007-06-04 | R2 | 976h | 976h | RANimp-L2DataRates | Rel-7 | Ericsson | Janne.Peisa@ericsson.com | Joern | RP-070289 |
| 673 | 268.11 | Introduction of 16QAM in HSUPA (FDD) | 110d? | 2006-12-15 A | 2007-06-04 A | 100% | 2006-12-15 | 2007-06-04 | 110d? | finish no earlier than 2007-06-04 | R1 | 880h | 880h | RANimp-16QamUplink | Rel-7 | Nokia | Karri.Ranta-aho@nsn.com | Patrick | RP-070288 |
| 674 | 268.12 | **Interface to control Tower Mounted Amplifiers (TMAs)** | 101d? | 2007-01-26 A | 2007-06-15 A | 100% | 2007-01-26 | 2007-06-15 | 101d? |  | R3 | 1616h | 1616h | RANImp-TMA | Rel-7 | Vodafone | alexej.kulakov@vodafone.com | Juha | RP-070140 |
| 675 | 268.12.1 | OAM aspects to Interface to control TMAs | 101d? | 2007-01-26 A | 2007-06-15 A | 100% | 2007-01-26 | 2007-06-15 | 101d? | finish no earlier than 2007-06-15 | S5 | 808h | 808h | RANImp-TMA-OAM | Rel-7 | Vodafone | Adrian.Neal@vodafone.com | Dionisio |  |
| 676 | 269 | **Rel-7 RAN improvements - UE Conformance Testing** | 784d? | 2006-09-20 A | 2009-09-18 A | 100% | 2006-09-20 | 2009-09-18 | 784d? |  | R5 | 25472h | 25472h | RANimp-UEConTest | Rel-7 |  |  | Ingbert |  |
| 677 | 269.1 | Conformance Test Aspects - 3.84 Mcps and 7.68 Mcps TDD Enhanced Uplink | 518d? | 2006-09-20 A | 2008-09-12 A | 100% | 2006-09-20 | 2008-09-12 | 518d? | finish no earlier than 2008-09-12 | R5 | 4144h | 4144h | RANimp-UEConTest_EDCHTDH | Rel-7 | IPWireless | tspeight@ipwireless.com | Ingbert | RP-080536 |
| 678 | 269.2 | Conformance Test Aspects – 64QAM for HSDPA (FDD) | 257d? | 2007-03-09 A | 2008-03-03 A | 100% | 2007-03-09 | 2008-03-03 | 257d? | finish no earlier than 2008-03-03 | R5 | 2056h | 2056h | RANimp-UEConTest_64QamDownlink | Rel-7 | Ericsson | leif.mattisson@ericsson.com | Ingbert | RP-080059 |
| 679 | 269.3 | Conformance Test Aspects – 16QAM for HSUPA (FDD) | 321d? | 2007-03-09 A | 2008-05-30 A | 100% | 2007-03-09 | 2008-05-30 | 321d? | finish no earlier than 2008-05-30 | R5 | 2568h | 2568h | RANimp-UEConTest_16QamUplink | Rel-7 | Motorola | carolyn.taylor@motorola.com | Ingbert | RP-080281 |
| 680 | 269.4 | Conformance Test Aspects – Improved L2 support for high data rates | 321d? | 2007-03-09 A | 2008-05-30 A | 100% | 2007-03-09 | 2008-05-30 | 321d? | finish no earlier than 2008-05-30 | R5 | 2568h | 2568h | RANimp-UEConTest_L2DataRates | Rel-7 | Ericsson | leif.mattisson@ericsson.com | Ingbert | RP-080256 |
| 681 | 269.5 | Conformance Test Aspects – Continuous connectivity for packet data users | 321d? | 2007-03-09 A | 2008-05-30 A | 100% | 2007-03-09 | 2008-05-30 | 321d? | finish no earlier than 2008-05-30 | R5 | 2568h | 2568h | RANimp-UEConTest_CPC | Rel-7 | Nokia | jarkko.hellsten@nokia.com | Ingbert | RP-080282 |
| 682 | 269.6 | Conformance Test Aspects – Enhanced CELL_FACH state in FDD | 662d? | 2007-03-09 A | 2009-09-18 A | 100% | 2007-03-09 | 2009-09-18 | 662d? | finish no earlier than 2009-09-18 | R5 | 5296h | 5296h | RANimp-UEConTest_EnhancedCellFACHState | Rel-7 | Nokia | jarkko.hellsten@nokia.com | Ingbert | RP-090711 |
| 683 | 270 | **7.68 Mcps TDD option** | 457d? | 2004-09-15 A | 2006-06-15 A | 100% | 2004-09-15 | 2006-06-15 | 457d? |  | RP | 19824h | 19824h | VHCRTDD | Rel-7 | IPwireless | Martin Beale (mbeale@ipwireless.com) |  | RP-060684 |
| 684 | 270.1 | VHCRTDD: Stage 2 | 391d? | 2004-09-15 A | 2006-03-15 A | 100% | 2004-09-15 | 2006-03-15 | 391d? | finish no earlier than 2006-03-15 | R1 | 3128h | 3128h | VHCRTDD-Stage2 | Rel-7 | IPwireless | Martin Beale (mbeale@ipwireless.com) | Patrick |  |
| 685 | 270.2 | VHCRTDD: Physical Layer | 391d? | 2004-09-15 A | 2006-03-15 A | 100% | 2004-09-15 | 2006-03-15 | 391d? | finish no earlier than 2006-03-15 | R1 | 3128h | 3128h | VHCRTDD-Phys | Rel-7 | IPwireless | Martin Beale (mbeale@ipwireless.com) | Patrick |  |
| 686 | 270.3 | VHCRTDD: Layer 2 and layer 3 protocol aspects | 391d? | 2004-09-15 A | 2006-03-15 A | 100% | 2004-09-15 | 2006-03-15 | 391d? | finish no earlier than 2006-03-15 | R2 | 3128h | 3128h | VHCRTDD-L23 | Rel-7 | IPwireless | drichards@ipwireless.com | Joern |  |
| 687 | 270.4 | VHCRTDD: UTRAN Iub/Iur Protocol Aspects | 391d? | 2004-09-15 A | 2006-03-15 A | 100% | 2004-09-15 | 2006-03-15 | 391d? | finish no earlier than 2006-03-15 | R3 | 3128h | 3128h | VHCRTDD-IurIub | Rel-7 | IPwireless | Peter Legg (plegg@ipwireless.com) | Juha |  |
| 688 | 270.5 | VHCRTDD: RF Radio Transmission/ Reception, System Performance Requirements and Conformance Testing | 457d? | 2004-09-15 A | 2006-06-15 A | 100% | 2004-09-15 | 2006-06-15 | 457d? | finish no earlier than 2006-06-15 | R4 | 3656h | 3656h | VHCRTDD-RF | Rel-7 | IPwireless | Shin Horng Wong (shwong@ipwireless.com) | Issam |  |

Notes:
- 662: Generic feature
- 663: Completed Dec 2006; SR in RP-060682
- 664: Completed Sep 2006; SR in RP-060453 / Text3: 25.815, 25.321, 25.322, 25.331
- 665: Closed Dec 2005; SR in RP-050667
- 666: Completed Sep 2006; SR in RP-060477 / Text3: 25.102, 25.123
- 667: Completed at Mar 2007; SR in RP-070033 / Text3: 25.903, 25.201, 25.211, 25.212, 25.214, 25.308, 25.321, 25.331, 25.423, 25.433, 25.101, 25.133
- 668: Completed Dec 2006; SR in RP-060685 / Text3: 25.133, 25.423, 25.425, 25.433, 25.435, 25.453, 25.331
- 669: Completed Dec 2006; SR in RP-060684 / Text3: 25.201, 25.202, 25.221, 25.222, 25.223, 25.224, 25.225, 25.331, 23.321, 25.306, 25.302, 25.401, 25.420, 25.423, 25.427, 25.433, 25.102, 25.105, 25.142
- 670: Completed May 2007; SR in RP-070286 / Text3: 25.308, 25.304, 25.306, 25.321, 25.331, 25.433, 25.435, 25.423, 25.425,
- 671: Completed May 2007; SR in RP-070287 / Text3: 25.308, 25.211, 25.212, 25.213, 25.306, 25.331, 25.433, 25.435, 25.423, 25.425, 25.101, 25.104, 25.141
- 672: Completed May 2007; SR in RP-070289 / Text3: 25.301, 25.308,25.306, 25.321, 25.322, 25.331, 25.433, 25.435, 25.423, 25.425, 25.999
- 673: Completed May 2007; SR in RP-070288 / Text3: 25.319, 25.101, 25.104, 25.133, 25.141, 25.211, 25.212, 25.213, 25.214, 25.306, 25.321, 25.331, 25.423, 25.433
- 674: Completed Mar 2007; SR in RP-070140
- 675: SP#36 Jun 2007 completed / Text3: 32.642/3/5 – Align with RAN 25.466
- 676: 05/08: Linked to Feature UID_20029 (RANimp)
- 677: SR in RP-080536. RP#41 completed / Text3: 34.108, 34.122, 34.123-1, 34.123-2, 34.123-3
- 678: SR in RP-080059. RP#39 completed. / Text3: 34.108, 34.121-1, 34.121-2, 34.123-1, 34.123-2, 34.123-3
- 679: SR in RP-080281. RP#40 completed / Text3: 34.108, 34.121-1, 34.121-2, 34.123-1, 34.123-2, 34.123-3
- 680: SR in RP-080256. RP#40 completed / Text3: 34.108, 34.123-1, 34.123-2, 34.123-3
- 681: SR in RP-080282. RP#40 completed / Text3: 34.108, 34.121-1, 34.121-2, 34.123-1, 34.123-2, 34.123-3
- 682: RP#45 completed / Text3: 34.108, 34.123-1, 34.123-2, 34.123-3
- 683: Completed Dec 2006, SR in RP-060684
- 684: Feature completed and closed at RP#33 with the presentation of the test WI / Text3: 25.202
- 685: Feature completed and closed at RP#33 with the presentation of the test WI / Text3: 25.221, 25.222, 25.223, 25.224,25.225
- 686: Feature completed and closed at RP#33 with the presentation of the test WI / Text3: 25.301, 25.302, 25.305, 25.306, 25.321, 25.331
- 687: Feature completed and closed at RP#33 with the presentation of the test WI / Text3: 25.401, 25.420, 25.423, 25.425, 25.427, 25.430, 25.433, 25.435
- 688: Feature completed and closed at RP#33 with the presentation of the test WI / Text3: 25.102, 25.105, 25.123, 25.133, 25.142

| ID | WBS | Task | Type | Duration | Start | Finish | Complete | Baseline start | Baseline finish | Baseline duration | Constraint | Resources | Work | Actual work | Text1 | Text4 | Text5 | Text6 | Text11 | Text8 | Text12 |
| --- | --- | --- | --- | --- | --- | --- | --- | --- | --- | --- | --- | --- | --- | --- | --- | --- | --- | --- | --- | --- | --- |
| 689 | 271 | **3.84 Mcps TDD Enhanced Uplink** |  | 394d? | 2005-03-15 A | 2006-09-15 A | 100% | 2005-03-15 | 2006-09-15 | 394d? |  | RP | 18384h | 18384h | EDCHTDD | IPwireless | nanderson@ipwireless.com | Rel-7 | RP-060684 |  |  |
| 690 | 271.1 | EDCHTDD: Stage 2 |  | 328d? | 2005-03-15 A | 2006-06-15 A | 100% | 2005-03-15 | 2006-06-15 | 328d? | finish no earlier than 2006-06-15 | R2 | 2624h | 2624h | EDCHTDD-Stage2 | IPwireless | nanderson@ipwireless.com | Rel-7 |  | Joern |  |
| 691 | 271.2 | EDCHTDD: Physical Layer |  | 394d? | 2005-03-15 A | 2006-09-15 A | 100% | 2005-03-15 | 2006-09-15 | 394d? | finish no earlier than 2006-09-15 | R1 | 3152h | 3152h | EDCHTDD-Phys | IPwireless | nanderson@ipwireless.com | Rel-7 |  | Patrick |  |
| 692 | 271.3 | EDCHTDD: Layer 2 and 3 Protocol Aspects |  | 394d? | 2005-03-15 A | 2006-09-15 A | 100% | 2005-03-15 | 2006-09-15 | 394d? | finish no earlier than 2006-09-15 | R2 | 3152h | 3152h | EDCHTDD-L23 | IPwireless | drichards@ipwireless.com | Rel-7 |  | Joern |  |
| 693 | 271.4 | EDCHTDD: UTRAN Iub/Iur Protocol Aspects |  | 394d? | 2005-03-15 A | 2006-09-15 A | 100% | 2005-03-15 | 2006-09-15 | 394d? | finish no earlier than 2006-09-15 | R3 | 3152h | 3152h | EDCHTDD-IurIub | Interdigital | jim.miller@interdigital.com | Rel-7 |  | Juha |  |
| 694 | 271.5 | EDCHTDD: RF Radio Transmission/ Reception, System Performance Requirements and Conformance Testing |  | 394d? | 2005-03-15 A | 2006-09-15 A | 100% | 2005-03-15 | 2006-09-15 | 394d? | finish no earlier than 2006-09-15 | R4 | 3152h | 3152h | EDCHTDD-RF | IPwireless | Shin Horng Wong (shwong@ipwireless.com) | Rel-7 |  | Issam |  |
| 695 | 272 | **1.28 Mcps TDD Enhanced Uplink** |  | 328d? | 2006-03-15 A | 2007-06-15 A | 100% | 2006-03-15 | 2007-06-15 | 328d? |  | RP | 11536h | 11536h | LCRTDD-EDCH | CATT | Haijing Hu | Rel-7 | RP-070296 |  |  |
| 696 | 272.1 | 1.28 Mcps TDD Enhanced Uplink: Physical Layer |  | 262d? | 2006-03-15 A | 2007-03-15 A | 100% | 2006-03-15 | 2007-03-15 | 262d? | finish no earlier than 2007-03-15 | R1 | 2096h | 2096h | LCRTDD-EDCH-Phys | CATT | Ke Wang | Rel-7 |  | Patrick |  |
| 697 | 272.2 | 1.28 Mcps TDD Enhanced Uplink: Layer 2 and 3 Protocol Aspects |  | 262d? | 2006-03-15 A | 2007-03-15 A | 100% | 2006-03-15 | 2007-03-15 | 262d? | finish no earlier than 2007-03-15 | R2 | 2096h | 2096h | LCRTDD-EDCH-L23 | CATT | Haiyang Quan | Rel-7 |  | Joern |  |
| 698 | 272.3 | 1.28 Mcps TDD Enhanced Uplink: UTRAN Iub/Iur Protocol Aspects |  | 262d? | 2006-03-15 A | 2007-03-15 A | 100% | 2006-03-15 | 2007-03-15 | 262d? | finish no earlier than 2007-03-15 | R3 | 2096h | 2096h | LCRTDD-EDCH-IubIur | CATT | Yincheng Zhang | Rel-7 |  | Juha |  |
| 699 | 272.4 | 1.28 Mcps TDD Enhanced Uplink: RF Radio Transmission/ Reception, System Performance Requirements and Conformance Testing |  | 328d? | 2006-03-15 A | 2007-06-15 A | 100% | 2006-03-15 | 2007-06-15 | 328d? | finish no earlier than 2007-06-15 | R4 | 2624h | 2624h | LCRTDD-EDCH-RF | CATT | Yuexia Song | Rel-7 |  | Issam |  |
| 700 | 273 | 1.28 Mcps TDD Enhanced Uplink - UE Conformance Testing |  | 257d? | 2007-09-20 A | 2008-09-12 A | 100% | 2007-09-20 | 2008-09-12 | 257d? | finish no earlier than 2008-09-11 | R5 | 624h | 624h | LCRTDD-EDCH-UEConTest | CATT | chenxiaozhong@datangmobile.cn | Rel-7 | RP-080539 | Ingbert |  |
| 701 | 274 | MS Antenna Performance Evaluation Method and Requirements |  | 731d? | 2005-01-28 A | 2007-11-16 A | 100% | 2005-01-28 | 2007-11-16 | 731d? | finish no earlier than 2007-11-16 | GP | 5848h | 5848h | APEMR | TeliaSonera | Ulf.Tegth@teliasonera.com | Rel-7 |  | Paolo |  |
| 702 | 275 | **Lower 700 MHz Inclusion in the GERAN Specifications** |  | 390d? | 2005-01-03 A | 2006-06-30 A | 100% | 2005-01-03 | 2006-06-30 | 390d? |  | GP | 7632h | 7632h | GSM710 | UTC | dcotton@mtview.union-tel.com | Rel-7 |  | Paolo |  |
| 703 | 275.1 | Inclusion of the 698 – 746 MHz band into GERAN core specifications |  | 129d? | 2005-01-03 A | 2005-06-30 A | 100% | 2005-01-03 | 2005-06-30 | 129d? | finish no earlier than 2005-06-30 | G1 | 1032h | 1032h | GSM710-core |  |  | Rel-7 |  | Paolo |  |
| 704 | 275.2 | G1 aspects of GSM710 |  | 217.5d? | 2005-08-31 A | 2006-06-30 A | 100% | 2005-08-31 | 2006-06-30 | 217.5d? | finish no earlier than 2006-06-30 | G1 | 1740h | 1740h | GSM-710-test |  |  | Rel-7 |  | Paolo |  |
| 705 | 275.3 | G3 aspects of GSM710 |  | 217.5d? | 2005-08-31 A | 2006-06-30 A | 100% | 2005-08-31 | 2006-06-30 | 217.5d? | finish no earlier than 2006-06-30 | G3new | 1740h | 1740h | GSM-710-test |  |  | Rel-7 |  | Ingbert |  |
| 706 | 276 | **Support of Conversational Services in A/Gb mode via the PS domain** |  | 626d? | 2005-04-08 A | 2007-08-31 A | 100% | 2005-04-08 | 2007-08-31 | 626d? |  | GP | 15442.8h | 15442.8h | SCSAGB | Ericsson | gunnar.hedby@ericsson.com | Rel-7 |  | Paolo |  |
| 707 | 276.1 | Minimise the transfer delay between the SGSN and the MS |  | 604.95d? | 2005-04-08 A | 2007-08-31 A | 100% | 2005-04-08 | 2007-08-31 | 604.95d? | finish no earlier than 2007-08-31 | GP | 4839.6h | 4839.6h | SCSAGB-MTD | Ericsson | gunnar.hedby@ericsson.com | Rel-7 |  | Paolo |  |
| 708 | 276.2 | Definition of radio resource management functionality |  | 626d? | 2005-04-08 A | 2007-08-31 A | 100% | 2005-04-08 | 2007-08-31 | 626d? | finish no earlier than 2007-08-31 | G1 | 5008h | 5008h | SCSAGB-RRM | Ericsson | gunnar.hedby@ericsson.com | Rel-7 |  | Paolo |  |
| 709 | 276.3 | Support of Conversational Services in A/Gb mode via the PS domain – RLC Non-Persistent mode |  | 101d? | 2006-06-30 A | 2006-11-17 A | 100% | 2006-06-30 | 2006-11-17 | 101d? | finish no earlier than 2006-11-17 | G2 | 808h | 808h | SCSAGB-RLCNP | Ericsson | gunnar.hedby@ericsson.com | Rel-7 |  | Gert |  |
| 710 | 276.4 | Deleted- Radio Channel Support | milestone | 0d? | 2006-07-17 A | 2006-07-17 A | 100% | 2006-07-17 | 2006-07-17 | 0d? | start no earlier than 2006-07-17 | G2 |  |  | SCSAGB-RCHS | Ericsson | gunnar.hedby@ericsson.com | Rel-7 |  | Gert | SP-32 |
| 711 | 276.5 | Deleted- Modifications to FLO | milestone | 0d? | 2006-07-17 A | 2006-07-17 A | 100% | 2006-07-17 | 2006-07-17 | 0d? | start no earlier than 2006-07-17 | G2 |  |  | SCSAGB-FLO | Ericsson | gunnar.hedby@ericsson.com | Rel-7 |  | Gert | SP-32 |
| 712 | 277 | **Addition of new frequency band to GSM (T-GSM810)** |  | 626d? | 2005-04-08 A | 2007-08-31 A | 100% | 2005-04-08 | 2007-08-31 | 626d? |  | GP | 12112h | 12112h | TGSM810 | Huawei | chende@huawei.com | Rel-7 |  | Paolo |  |
| 713 | 277.1 | Changes to core specification |  | 106d? | 2005-04-08 A | 2005-09-02 A | 100% | 2005-04-08 | 2005-09-02 | 106d? | finish no earlier than 2005-09-02 | GP | 848h | 848h | TGSM810-Core | Huawei | chende@huawei.com | Rel-7 |  | Paolo |  |
| 714 | 277.2 | Changes to MS testing specification |  | 626d? | 2005-04-08 A | 2007-08-31 A | 100% | 2005-04-08 | 2007-08-31 | 626d? | finish no earlier than 2007-08-31 | G3new | 5008h | 5008h | TGSM810-MStest | Huawei | chende@huawei.com | Rel-7 |  | Ingbert |  |
| 715 | 277.3 | Changes to BTS testing specification |  | 156d? | 2005-04-08 A | 2005-11-11 A | 100% | 2005-04-08 | 2005-11-11 | 156d? | finish no earlier than 2005-11-11 | G1 | 1248h | 1248h | TGSM810-BTStest | Huawei | chende@huawei.com | Rel-7 |  | Paolo |  |

Notes:
- 689: Completed Dec 2006, SR in RP-060684
- 690: -
- 691: - / Text3: 25.201, 25.221,25.222, 25.223, 25.224, 25.225
- 692: - / Text3: 25.301, 25.302, 25.306, 25.321, 25.331
- 693: - / Text3: 25.401, 25.420, 25.423, 25.427, 25.430, 25.433, 25.435
- 694: - / Text3: 25.102, 25.105, 25.123, 25.142
- 695: Completed May 2007; SR in RP-070038 and RP-070296
- 696: - / Text3: 25.201, 25.221, 25.222, 25.223, 25.224, 25.225
- 697: - / Text3: 25.301, 25.302, 25.306, 25.321, 25.331
- 698: - / Text3: 25.401, 25.420, 25.423, 25.425, 25.427, 25.430, 25.433, 25.435
- 699: - / Text3: 25.102, 25.105, 25.123, 25.142
- 700: UID_350046->350146. 05/08: Linked to Feature UID_20055 (LCRTDD-EDCH). SR in RP-080539. RP#41 completed / Text3: 34.108, 34.122, 34.123-1/2/3
- 701: GP#36 completed for R7 / Text3: 25.914, 25.144, 45.005
- 702: - / Text3: 24.008, 43.022, 44.018, 44.118, 45, 001, 45.005, 51.010, 51.021
- 703: Completed / Text3: 24.008, 43.022, 44.018, 44.118, 45, 001, 45.005,
- 704: - / Text3: 51.021
- 705: - / Text3: 51.010
- 706: Originally started Nov. 2003 as GP-030443
- 707: -
- 708: -
- 709: - / Text3: 43.955, 43.064, 44.060, 45.001, 45.002, 45.003, 45.005, 45.010, 51.010, 51.021
- 710: -
- 711: -
- 712: - / Text3: 45.005, 45.050, 24.008, 45.008, 45.001, 43.022, 43.030, 44.018, 44.060, 51.010-1, 51.021
- 713: - / Text3: 45.005, 45.050, 24.008, 45.008, 45.001, 43.022, 43.030, 44.018, 44.060
- 714: - / Text3: 51010-1
- 715: - / Text3: 51021

| ID | WBS | Task | Duration | Start | Finish | Complete | Baseline start | Baseline finish | Baseline duration | Constraint | Resources | Work | Actual work | Text1 | Text4 | Text5 | Text6 | Text8 | Text12 |
| --- | --- | --- | --- | --- | --- | --- | --- | --- | --- | --- | --- | --- | --- | --- | --- | --- | --- | --- | --- |
| 716 | 278 | **Handover of dedicated and shared resources while in Dual Transfer Mode** | 421d? | 2005-04-08 A | 2006-11-17 A | 100% | 2005-04-08 | 2006-11-17 | 421d? |  | GP | 12672h | 12672h | HODSRDTM | Nokia | rami.vaittinen@nokia.com | Rel-7 | Paolo |  |
| 717 | 278.1 | Handover of dedicated and shared resources while in Dual Transfer Mode | 321d? | 2005-04-08 A | 2006-06-30 A | 100% | 2005-04-08 | 2006-06-30 | 321d? | finish no earlier than 2006-06-30 | G2 | 2568h | 2568h | HODSRDTM-G2 | Nokia | rami.vaittinen@nokia.com | Rel-7 | Gert |  |
| 718 | 278.2 | Deleted - MS Conformance Testing | 421d? | 2005-04-08 A | 2006-11-17 A | 100% | 2005-04-08 | 2006-11-17 | 421d? | finish no earlier than 2006-11-17 | G3new | 3368h | 3368h | HODSRDTM-Mstest | Nokia | rami.vaittinen@nokia.com | Rel-7 | Ingbert | GP-32 |
| 719 | 278.3 | Deleted - BTS conformance testing | 421d? | 2005-04-08 A | 2006-11-17 A | 100% | 2005-04-08 | 2006-11-17 | 421d? | finish no earlier than 2006-11-17 | G1 | 3368h | 3368h | HODSRDTM-BTStest | Nokia | rami.vaittinen@nokia.com | Rel-7 | Paolo | GP-32 |
| 720 | 279 | **Mobile Station Receive Diversity (DARP Phase II)** | 526d? | 2005-11-11 A | 2007-11-16 A | 100% | 2005-11-11 | 2007-11-16 | 526d? |  | GP | 16360h | 16360h | MSRD2 | Nokia | kent.pedersen@nokia.com | Rel-7 | Paolo |  |
| 721 | 279.1 | Performance Requirements for Mobile Station Receive Diversity, DARP Phase II | 331d? | 2005-11-11 A | 2007-02-16 A | 100% | 2005-11-11 | 2007-02-16 | 331d? | finish no earlier than 2007-02-16 | GP | 2648h | 2648h | MSRD2-PerfReq | Nokia | kent.pedersen@nokia.com | Rel-7 | Paolo |  |
| 722 | 279.2 | Capability signalling of Mobile Station Receive Diversity, DARP Phase II | 331d? | 2005-11-11 A | 2007-02-16 A | 100% | 2005-11-11 | 2007-02-16 | 331d? | finish no earlier than 2007-02-16 | GP | 2648h | 2648h | MSRD2-CapSig | Nokia | kent.pedersen@nokia.com | Rel-7 | Paolo |  |
| 723 | 279.3 | Test Scenarios for Mobile Station Receive Diversity, DARP Phase II | 331d? | 2005-11-11 A | 2007-02-16 A | 100% | 2005-11-11 | 2007-02-16 | 331d? | finish no earlier than 2007-02-16 | GP | 2648h | 2648h | MSRD2-TestSc | Nokia | kent.pedersen@nokia.com | Rel-7 | Paolo |  |
| 724 | 279.4 | MS conformance test of DARP Phase II (MSRD) | 526d? | 2005-11-11 A | 2007-11-16 A | 100% | 2005-11-11 | 2007-11-16 | 526d? | finish no earlier than 2007-11-16 | GP | 4208h | 4208h | MSRD2-Msconf | Nokia | kent.pedersen@nokia.com | Rel-7 | Ingbert |  |
| 725 | 280 | **Downlink Dual Carrier** | 421d? | 2006-01-20 A | 2007-08-31 A | 100% | 2006-01-20 | 2007-08-31 | 421d? |  | GP | 7664h | 7664h | GDCDL | Nokia Siemens Networks | leonardo.provvedi@roke.co.uk | Rel-7 | Paolo |  |
| 726 | 280.1 | Downlink Dual Carrier Stage 2 | 116d? | 2006-01-20 A | 2006-06-30 A | 100% | 2006-01-20 | 2006-06-30 | 116d? | finish no earlier than 2006-06-30 | G1 | 928h | 928h | GDCDL-Stage2 | Nokia Siemens Networks | leonardo.provvedi@roke.co.uk | Rel-7 | Paolo |  |
| 727 | 280.2 | Downlink Dual Carrier Stage 3 | 421d? | 2006-01-20 A | 2007-08-31 A | 100% | 2006-01-20 | 2007-08-31 | 421d? | finish no earlier than 2007-08-31 | G1 | 3368h | 3368h | GDCDL-Stage2 | Nokia Siemens Networks | leonardo.provvedi@roke.co.uk | Rel-7 | Paolo |  |
| 728 | 281 | **Downlink Dual Carrier – MS Conformance Test** | 947d? | 2006-01-20 A | 2009-09-04 A | 100% | 2006-01-20 | 2009-09-04 | 947d? |  | G3new | 11150.6h | 11150.6h | GDCDL-Stage3 | Nokia Siemens Networks | leonardo.provvedi@roke.co.uk | Rel-7 | Ingbert |  |
| 729 | 281.1 | Downlink Dual Carrier – MS Conformance Test | 446.82d? | 2006-01-20 A | 2009-09-04 A | 100% | 2006-01-20 | 2009-09-04 | 446.82d? | finish no earlier than 2009-09-04 | G3new | 3574.6h | 3574.6h | GDCDL-Stage3 | Nokia Siemens Networks | leonardo.provvedi@roke.co.uk | Rel-7 | Ingbert |  |
| 730 | 282 | Support of SIGTRAN in GERAN | 116d? | 2006-01-20 A | 2006-06-30 A | 100% | 2006-01-20 | 2006-06-30 | 116d? | finish no earlier than 2006-06-30 | G3new | 928h | 928h | GDCDL-MStest | Ericsson | peter.ostrup@ericsson.com | Rel-7 | Ingbert |  |
| 731 | 283 | **Latency Reductions** | 306d? | 2006-06-30 A | 2007-08-31 A | 100% | 2006-06-30 | 2007-08-31 | 306d? |  | GP | 7344h | 7344h | LATRED | Ericsson | Hakan.Persson@Ericsson.com | Rel-7 | Paolo |  |
| 732 | 283.1 | Improved Ack/Nack reporting | 306d? | 2006-06-30 A | 2007-08-31 A | 100% | 2006-06-30 | 2007-08-31 | 306d? | finish no earlier than 2007-08-31 | G2 | 2448h | 2448h | LATRED-ACKNAR | Ericsson | Hakan.Persson@Ericsson.com | Rel-7 | Gert |  |
| 733 | 283.2 | Reduced TTI | 306d? | 2006-06-30 A | 2007-08-31 A | 100% | 2006-06-30 | 2007-08-31 | 306d? | finish no earlier than 2007-08-31 | G2 | 2448h | 2448h | LATRED-REDTTI | Ericsson | Hakan.Persson@Ericsson.com | Rel-7 | Gert |  |
| 734 | 284 | PS Handover between GERAN/UTRAN mode and GAN Mode | 166d? | 2006-06-30 A | 2007-02-16 A | 100% | 2006-06-30 | 2007-02-16 | 166d? | finish no earlier than 2007-02-16 | G2 | 1328h | 1328h | GUGAN | Ericsson | John.Diachina@Ericsson.com | Rel-7 | Gert |  |
| 735 | 285 | **Higher Uplink performance for GERAN Evolution** | 516d? | 2006-09-08 A | 2008-08-29 A | 100% | 2006-09-08 | 2008-08-29 | 516d? |  | GP | 15440h | 15440h | HUGE | Nokia Siemens Networks, Ericsson | eddie.riddington@nokia.com, stefan.g.eriksson@ericsson.com | Rel-7 | Paolo |  |
| 736 | 285.1 | Stage 2 of HUGE | 261d? | 2006-09-08 A | 2007-09-07 A | 100% | 2006-09-08 | 2007-09-07 | 261d? | finish no earlier than 2007-09-07 | G1 | 2088h | 2088h | HUGE-Stage2 | Nokia Siemens Networks, Ericsson | eddie.riddington@nokia.com, stefan.g.eriksson@ericsson.com | Rel-7 | Paolo |  |
| 737 | 285.2 | Layer 1 Support of HUGE | 381d? | 2006-09-08 A | 2008-02-22 A | 100% | 2006-09-08 | 2008-02-22 | 381d? | finish no earlier than 2008-02-22 | G1 | 3048h | 3048h | HUGE-Layer1 | Nokia Siemens Networks, Ericsson | eddie.riddington@nokia.com, stefan.g.eriksson@ericsson.com | Rel-7 | Paolo |  |
| 738 | 285.3 | Layer 2/3 Support of HUGE | 256d? | 2006-09-08 A | 2007-08-31 A | 100% | 2006-09-08 | 2007-08-31 | 256d? | finish no earlier than 2007-08-31 | G2 | 2048h | 2048h | HUGE-Layer23 | Nokia Siemens Networks, Ericsson | eddie.riddington@nokia.com, stefan.g.eriksson@ericsson.com | Rel-7 | Gert |  |
| 739 | 285.4 | Performance requirements | 516d? | 2006-09-08 A | 2008-08-29 A | 100% | 2006-09-08 | 2008-08-29 | 516d? | finish no earlier than 2008-08-29 | G1 | 4128h | 4128h | HUGE-Perfreq | Nokia Siemens Networks, Ericsson | eddie.riddington@nokia.com, stefan.g.eriksson@ericsson.com | Rel-7 | Paolo |  |

Notes:
- 716: GP#30 completed. Started at GP#24
- 717: GP#30 completed / Text3: 43.055, 44.018, 44.060
- 718: Stopped, no work done. 12/2008 Marked as stopped ("deleted") / Text3: 51-010
- 719: Stopped, no work done. 12/2008 Marked as stopped ("deleted") / Text3: 51.026
- 720: GP#36 completed / Text3: 24.008, 45.005, 51.010
- 721: GP#33 completed / Text3: 45.005
- 722: GP#33 completed / Text3: 24.008
- 723: GP#33 completed / Text3: 45.005
- 724: GP#36 completed / Text3: 51.010
- 725: GP#35 completed
- 726: GP#30 completed / Text3: 43.055, 43.064
- 727: GP#35 completed / Text3: 24.008, 44.018, 44.060, 45.001, 45.002, 45.005, 45.008
- 728: GP#43 completed / Text3: 51.010
- 729: GP#43 completed / Text3: 51.010
- 730: GP#30 completed / Text3: 48.001, 48.006, 43.059, 49.031
- 731: GP#35 completed / Text3: 45.001, 45.002, 45.003, 45.005, 45.010, 43.055, 43.064, 44.060, 51.010-1, 51.021
- 732: GP#35 completed / Text3: 45.001, 45.002, 45.003, 45.005, 45.010, 43.055, 43.064, 44.060, 51.010-1, 51.021
- 733: GP#35 completed / Text3: 45.001, 45.002, 45.003, 45.005, 45.010, 43.055, 43.064, 44.060, 51.010-1, 51.021
- 734: GP#33 completed / Text3: 43.318, 44.318, 43.129, 25.306, 24.008, 44.060, 25.331, 51.010
- 735: GP#39 completed. SP#42 split core from testing specification work.
- 736: GP#35 completed / Text3: 43.055, 43.064
- 737: GP#37 completed / Text3: 45.001, 45.002, 45.003, 45.004, 45.008
- 738: GP#35 completed / Text3: 24.008, 44.018, 44.060
- 739: GP#39 completed / Text3: 45.005

| ID | WBS | Task | Type | Duration | Start | Finish | Complete | Remaining | Baseline start | Baseline finish | Baseline duration | Total slack | Constraint | Resources | Work | Actual work | Text1 | Text4 | Text5 | Text6 | Text8 | Text12 | Text11 |
| --- | --- | --- | --- | --- | --- | --- | --- | --- | --- | --- | --- | --- | --- | --- | --- | --- | --- | --- | --- | --- | --- | --- | --- |
| 740 | 286 | **HUGE Conformance Testing** |  | 912d? | 2006-09-08 A | 2010-03-05 | 57% | 392.6d? | 2006-09-08 | 2010-03-05 | 912d? | 400d |  | G1,G3new | 20832h | 8066h | HUGE | Nokia Siemens Networks, Ericsson | eddie.riddington@nokia.com, stefan.g.eriksson@ericsson.com | Rel-7 | Paolo |  |  |
| 741 | 286.1 | HUGE - MS Conformance Test |  | 911d? | 2006-09-08 A | 2010-03-05 | 20% | 728.8d? | 2006-09-08 | 2010-03-05 | 911d? | 400d | finish no earlier than 2010-03-05 | G3new | 7288h | 1457.6h | HUGE-Mstest | Nokia Siemens Networks, Ericsson | eddie.riddington@nokia.com, stefan.g.eriksson@ericsson.com | Rel-7 | Ingbert |  |  |
| 742 | 286.2 | HUGE - BTS Conformance Test |  | 782d? | 2006-09-08 A | 2009-09-04 A | 100% |  | 2006-09-08 | 2009-09-04 | 782d? |  | finish no earlier than 2009-09-04 | G1 | 6248h | 6248h | HUGE-BTStest | Nokia Siemens Networks, Ericsson | eddie.riddington@nokia.com, stefan.g.eriksson@ericsson.com | Rel-7 | Paolo |  |  |
| 743 | 287 | **REduced symbol Duration, Higher Order modulation and Turbo coding (RED HOT) for downlink** |  | 391d? | 2006-11-17 A | 2008-05-16 A | 100% |  | 2006-11-17 | 2008-05-16 | 391d? |  |  | GP | 7904h | 7904h | REDHOT | Ericsson, Nokia Siemens Networks, Marvell | stefan.g.eriksson@ericsson.com | Rel-7 | Paolo |  |  |
| 744 | 287.1 | Stage 2 for REDHOT |  | 206d? | 2006-11-17 A | 2007-08-31 A | 100% |  | 2006-11-17 | 2007-08-31 | 206d? |  | finish no earlier than 2007-08-31 | G1 | 1648h | 1648h | REDHOT-Stage2 | Ericsson, Nokia Siemens Networks, Marvell | stefan.g.eriksson@ericsson.com | Rel-7 | Paolo |  |  |
| 745 | 287.2 | Stage 3 for REDHOT |  | 391d? | 2006-11-17 A | 2008-05-16 A | 100% |  | 2006-11-17 | 2008-05-16 | 391d? |  | finish no earlier than 2008-05-16 | G1 | 3128h | 3128h | REDHOT-Stage3 | Ericsson, Nokia Siemens Networks, Marvell | stefan.g.eriksson@ericsson.com | Rel-7 | Paolo |  |  |
| 746 | 288 | **REDHOT Conformance Testing** |  | 862d? | 2006-11-17 A | 2010-03-05 | 54% | 392.69d? | 2006-11-17 | 2010-03-05 | 862d? | 400d |  | G1,G3new | 18992h | 6926h | REDHOT | Ericsson, Nokia Siemens Networks, Marvell | stefan.g.eriksson@ericsson.com | Rel-7 | Paolo |  |  |
| 747 | 288.1 | REDHOT - MS Conformance Tests |  | 861d? | 2006-11-17 A | 2010-03-05 | 20% | 688.8d? | 2006-11-17 | 2010-03-05 | 861d? | 400d | finish no earlier than 2010-03-05 | G3new | 6888h | 1377.6h | REDHOT-Mstest | Ericsson | stefan.g.eriksson@ericsson.com | Rel-7 | Ingbert |  |  |
| 748 | 288.2 | BTS Conformance Tests |  | 651d? | 2006-11-17 A | 2009-05-15 A | 100% |  | 2006-11-17 | 2009-05-15 | 651d? |  | finish no earlier than 2009-05-15 | G1 | 5208h | 5208h | REDHOT-BTStest | Ericsson, Nokia Siemens Networks, Marvell | stefan.g.eriksson@ericsson.com | Rel-7 | Paolo |  |  |
| 749 | 289 | (Small) Technical Enhancements and Improvements for Rel-7 | milestone | 0d? | 2007-03-26 A | 2007-03-26 A | 100% |  | 2007-03-26 | 2007-03-26 | 0d? |  | start no earlier than 2007-03-26 | All |  |  | TEI7 |  |  | Rel-7 |  |  |  |
| 750 | 290 | **Deleted - PS domain and IMS support for IMS Emergency sessions** |  | 63.69d? | 2006-06-23 A | 2006-09-21 A | 100% |  | 2006-06-23 | 2006-09-21 | 63.69d? |  |  | S2 |  |  | IMS-EMER | Nokia | curt.c.wong@nokia.com | Rel-7 | Maurice | SP-30 |  |
| 751 | 290.1 | Deleted - IMS aspects to support IMS Emergency sessions | milestone | 0d? | 2006-06-23 A | 2006-09-21 A | 100% |  | 2006-06-23 | 2006-09-21 | 0d? |  | start no earlier than 2006-06-23 | S2 |  |  | IMS-EMER | Nokia | curt.c.wong@nokia.com | Rel-7 | Maurice | SP-30 |  |
| 752 | 290.2 | Deleted - PS domain aspects to support IMS Emergency sessions | milestone | 0d? | 2006-06-23 A | 2006-09-21 A | 100% |  | 2006-06-23 | 2006-09-21 | 0d? |  | start no earlier than 2006-06-23 | S2 |  |  | IMS-EMER | Nokia | curt.c.wong@nokia.com | Rel-7 | Maurice | SP-30 |  |
| 753 | 291 | **Deleted - VoIMS bearer related enhancements** |  | 0d? | 2006-07-21 A | 2006-07-21 A | 100% |  | 2006-07-21 | 2006-07-21 | 0d? |  |  | S2 |  |  | VoIMS |  |  | Rel-7 | Maurice | SP-32 |  |
| 754 | 291.1 | Deleted - FS on enhancement of radio performance for VoIMS | milestone | 0d? | 2006-07-21 A | 2006-07-21 A | 100% |  | 2006-07-21 | 2006-07-21 | 0d? |  | start no earlier than 2006-07-21 | S2 |  |  | VoIMS | Nortel | Laurence Lautier (lautierl@nortel.com) | Rel-7 | Maurice | SP-32 |  |
| 755 | 292 | Release 7 Studies |  | 1d? | 2000-01-03 | 2000-01-03 |  |  | 2000-01-03 | 2000-01-03 | 1d? | 3056d |  | CP,GP,RP,SP | 8h |  |  |  |  | Rel-7 |  |  |  |
| 756 | 293 | Study on Enhancement of E2E QoS |  | 281.4d? | 2004-06-28 A | 2005-09-15 A | 100% |  | 2004-06-28 | 2005-09-15 | 281.4d? |  | finish no earlier than 2005-12-01 | S2 | 2251.2h | 2251.2h | QoS7 | Huawei | Robert Jaksa | Rel-7 | Maurice |  |  |
| 757 | 294 | Study on Bandwidth Saving at Nb Interface with IP transport |  | 261d? | 2006-03-10 A | 2007-03-09 A | 100% |  | 2006-03-10 | 2007-03-09 | 261d? |  | finish no earlier than 2007-03-09 | C3 | 2088h | 2088h | BSNbIP | Siemens | Thomas.Belling@nsn.com | Rel-7 | Gwiho |  |  |
| 758 | 295 | Study on Routeing of MT-SMS via the HPLMN |  | 301d? | 2005-10-07 A | 2006-12-01 A | 100% |  | 2005-10-07 | 2006-12-01 | 301d? |  | finish no earlier than 2006-12-01 | C4 | 2408h | 2408h | SMS7 | Vodafone | Nick.Russell@vodafone.com | Rel-7 | Kimmo |  |  |
| 759 | 296 | Study on the TCAPsec Gateway concept |  | 96d? | 2005-10-28 A | 2006-03-10 A | 100% |  | 2005-10-28 | 2006-03-10 | 96d? |  | finish no earlier than 2006-03-10 | C4 | 768h | 768h | SEC7-TCAP | Siemens | Ulrich.wiehe@gksag.de | Rel-7 | Kimmo |  |  |
| 760 | 297 | Study on using M2PA in 3GPP network |  | 318d? | 2006-03-22 A | 2007-06-08 A | 100% |  | 2006-03-22 | 2007-06-08 | 318d? |  | finish no earlier than 2007-06-08 | C4 | 2544h | 2544h | FS-M2PA | China Mobile | zhaoyuyi@chinamobile.com | Rel-7 | Kimmo |  |  |
| 761 | 298 | **Study on Support of (G)MSC-S - (G)MSC-S Nc Interface based on the SIP-I protocol** |  | 350d? | 2006-05-15 A | 2007-09-14 A | 100% |  | 2006-05-15 | 2007-09-14 | 350d? |  |  | C4 | 7800h | 7800h | NcSIP | Vodafone | david.hutton@vodafone.com | Rel-7 | Kimmo |  |  |
| 762 | 298.1 | CT4 aspects of NcSIP |  | 275d? | 2006-05-15 A | 2007-06-01 A | 100% |  | 2006-05-15 | 2007-06-01 | 275d? |  | finish no earlier than 2007-06-01 | C4 | 2200h | 2200h | NcSIP | Vodafone | david.hutton@vodafone.com | Rel-7 | Kimmo |  |  |
| 763 | 298.2 | CT3 aspects of NcSIP |  | 350d? | 2006-05-15 A | 2007-09-14 A | 100% |  | 2006-05-15 | 2007-09-14 | 350d? |  | finish no earlier than 2007-09-14 | C3 | 2800h | 2800h | NcSIP | Ericsson | ragnar.huslende@ericsson.com | Rel-7 | Gwiho |  |  |
| 764 | 299 | Study on SOAP/HTTP IRP Solution Sets |  | 330d? | 2005-09-02 A | 2006-12-07 A | 100% |  | 2005-09-02 | 2006-12-07 | 330d? |  | finish no earlier than 2006-12-07 | S5 | 2640h | 2640h | OAM7-NIM-XML | Nortel |  | Rel-7 | Dionisio |  |  |
| 765 | 300 | Study on Itf-N Implementation Conformance Statement (ICS) template |  | 400d? | 2005-09-02 A | 2007-03-15 A | 100% |  | 2005-09-02 | 2007-03-15 | 400d? |  | finish no earlier than 2007-03-15 | S5 | 3200h | 3200h | OAM7-NIM-ICS | China Mobile |  | Rel-7 | Dionisio |  |  |
| 766 | 301 | Study on IRP Information Model |  | 400d? | 2005-09-02 A | 2007-03-15 A | 100% |  | 2005-09-02 | 2007-03-15 | 400d? |  | finish no earlier than 2007-03-15 | S5 | 3200h | 3200h | OAM7-NIM-IM | Motorola |  | Rel-7 | Dionisio |  |  |
| 767 | 302 | Study on Evolved UTRA and UTRAN |  | 458d? | 2004-12-15 A | 2006-09-15 A | 100% |  | 2004-12-15 | 2006-09-15 | 458d? |  | finish no earlier than 2006-09-15 | RP | 3664h | 3664h | RANFS-Evo | NTT DoCoMo | nakamurata@NTTDOCOMO.CO.JP | Rel-7 | Issam |  | RP-060472 |
| 768 | 303 | Study on Performance Evaluation of the UE behaviour in high speed trains with speeds up to 350 kmph |  | 328d? | 2005-03-15 A | 2006-06-15 A | 100% |  | 2005-03-15 | 2006-06-15 | 328d? |  | finish no earlier than 2006-06-15 | R4 | 2624h | 2624h | RANFS-HSTrains | Vodafone | Mike.vogel@vodafone.com,tim.frost@vodafone.com | Rel-7 | Issam |  | RP-060412 |
| 769 | 304 | Study on UTRA Tower Mounted Amplifier (FDD) |  | 195d? | 2005-06-15 A | 2006-03-14 A | 100% |  | 2005-06-15 | 2006-03-14 | 195d? |  | finish no earlier than 2006-03-15 | R4 | 1560h | 1560h | RANFS-TMA | Ericsson | Klas.Sjerling@ericsson.com | Rel-7 | Issam |  | RP-060035 |
| 770 | 305 | Study on Continuous connectivity for packet data users |  | 132d? | 2005-03-15 A | 2005-09-14 A | 100% |  | 2005-03-15 | 2005-09-14 | 132d? |  | finish no earlier than 2005-09-15 | R1 | 1056h | 1056h | RANFS-cont-packet | Siemens | joerg.gustrau@siemens.com | Rel-7 | Patrick |  | RP-050427 |
| 771 | 306 | Study on Improvement of the Multimedia Broadcast Multicast Service (MBMS) in UTRAN |  | 262d? | 2005-12-15 A | 2006-12-15 A | 100% |  | 2005-12-15 | 2006-12-15 | 262d? |  | finish no earlier than 2006-12-15 | R2 | 2096h | 2096h | RANFS-MBMSImp | LG Electronics | leego@lge.com | Rel-7 | Joern |  | RP-060692 |
| 772 | 307 | Study on Performance Improvements in Small Cells using HSDPA/EDCH |  | 131d? | 2005-12-15 A | 2006-06-15 A | 100% |  | 2005-12-15 | 2006-06-15 | 131d? |  | finish no earlier than 2006-06-15 | R4 | 1048h | 1048h | SMALLCELLS | Cingular | Marc Grant | Rel-7 | Issam |  | RP-060263 |
| 773 | 308 | Study on Further Improved Performance Requirements for UMTS/HSDPA UE (FDD) |  | 383d? | 2005-12-15 A | 2007-06-04 A | 100% |  | 2005-12-15 | 2007-06-04 | 383d? |  | finish no earlier than 2007-06-04 | R4 | 3064h | 3064h | RANFS-IC | Cingular | Marc Grant | Rel-7 | Issam |  | RP-070499 |
| 774 | 309 | Study on Scope of future FDD HSPA Evolution |  | 394d? | 2006-03-15 A | 2007-09-17 A | 100% |  | 2006-03-15 | 2007-09-17 | 394d? |  | finish no earlier than 2007-09-17 | RP | 3152h | 3152h | RANFS-HSPAEvo | Cingular | Don Zelmer (dz1069@att.com) | Rel-7 | Issam |  | RP-070533 |
| 775 | 310 | Study on Dynamically reconfiguring a FDD UE receiver to reduce power consumption when desired Quality of Service is met | milestone | 0d? | 2007-06-22 A | 2007-06-22 A | 100% |  | 2007-06-22 | 2007-06-22 | 0d? |  |  | R4 |  |  | FSUEPow | Nokia | Chris.callender@nokia.com, tiina.s.koskinen@nokia.com | Rel-7 | Issam |  | RP-070534 |
| 776 | 311 | Study on Future GERAN Evolution |  | 486d? | 2005-04-08 A | 2007-02-16 A | 100% |  | 2005-04-08 | 2007-02-16 | 486d? |  | finish no earlier than 2007-02-16 | GP | 3888h | 3888h | FGE | Nokia | eddie.riddington@nokia.com | Rel-7 | Paolo |  |  |
| 777 | 312 | Study on GAN Enhancements | milestone | 0d? | 2007-08-31 A | 2007-08-31 A | 100% |  | 2007-08-31 | 2007-08-31 | 0d? |  | start no earlier than 2007-08-31 | GP |  |  | EGAN | T-Mobile | janne.linkola@t-mobile.com | Rel-7 | Paolo |  |  |
| 778 | 313 | Deleted - covered by UID33027 - IMS security extensions | milestone | 0d? | 2005-12-08 A | 2005-12-08 A | 100% |  | 2005-12-08 | 2005-12-08 | 0d? |  | start no earlier than 2005-12-08 | S3 |  |  | IMS-SE | Ericsson | Bengt.Sahlin@ericsson.com | Rel-7 | Dionisio | SP-30 |  |
| 779 | 314 | Deleted - covered by 32108 - Study of work on an LCS architecture for I-WLAN | milestone | 0d? | 2006-12-08 A | 2006-12-08 A | 100% |  | 2006-12-08 | 2006-12-08 | 0d? |  | start no earlier than 2006-12-08 | S2 |  |  | IMS-SE | LG Electronics | Donghee Shim dhshim@lge.com ; phede@lge.com | Rel-7 | Maurice | SP-33 |  |

Notes:
- 740: SP#42 split core from testing specification work
- 741: GP#44 target 02/10=>03/10 / Text3: 51.010
- 742: GP#43 completed / Text3: 51.021
- 743: GP#38 completed. SP#42 split core from testing specification work.
- 744: GP#35 completed / Text3: 43.055, 43.064
- 745: GP#38 completed / Text3: 24.008, 44.018, 44.060, 45.001, 45.002, 45.003, 45.004, 45.005, 45.008
- 746: SP#42 split core from testing specification work
- 747: GP#44 completion 02/10=>03/10 / Text3: 51.010
- 748: GP#42 completed / Text3: 51.021
- 749: - / Text3: CP-070260
- 750: Approved at SP#29 / Text3: 23.867, 23.abc, 23.060, 23.002, 23.271
- 751: Approved at SP#29 / Text3: 23.867, 23.abc, 23.060, 23.002, 23.271
- 752: Approved at SP#29 / Text3: 23.867, 23.abc, 23.060, 23.002, 23.271
- 753: Created by MCC to group all VoIMS related items, after consultation of chairs
- 754: WID approved SP#28: SA2#52: CLOSED - To be removed from the work plan / Text3: 23.807
- 755: -
- 756: - / Text3: 23.802
- 757: Moved to FS at CT32 (in line with slides) / Text3: 29.814
- 758: Previously known as "Study of a SMS Centre for MT SMS" / Text3: 23.840
- 759: TR 29.800 content moved to TS 29.204 under implementation WI UID_310005 TCAPsec Gateway / Text3: 29.800
- 760: - / Text3: 29.801
- 761: - / Text3: 29.802
- 762: - / Text3: 29.802
- 763: - / Text3: 29.802
- 764: SP#34 completed / Text3: 32.809
- 765: SP#35 completed / Text3: 32.812
- 766: SP#35 completed / Text3: 32.810
- 767: RP#33 (Sep 2006) completed. SR in RP-060472 / Text3: 25.912
- 768: RP#32 (Jun 2006) completed. SR in RP-060412 / Text3: none
- 769: RP#31 (Mar 2006) completed. SR in RP-060035 / Text3: 25.818
- 770: RP#29 (Sep 2006) completed. SR in RP-050427 / Text3: none
- 771: RP#34 (Dec 2006) completed. SR in RP-060692 / Text3: 25.905
- 772: RP#32 (Jun 2006) closed (no progress). SR in RP-060263 / Text3: none
- 773: RP#36 (May 2007) completed. SR in RP-070499 / Text3: 25.963
- 774: RP#37 (Sep 2007) completed. SR in RP-070533 / Text3: 25.999
- 775: RP#37 (Sep 2007) completed. SR in RP-070534 / Text3: 25.906
- 776: GP#33 completed / Text3: 45.912
- 777: GP#35 completed / Text3: 43.902
- 778: -
- 779: S2#52: Entry created

| ID | WBS | Task | Type | Duration | Start | Finish | Complete | Baseline start | Baseline finish | Baseline duration | Total slack | Constraint | Resources | Work | Actual work | Text1 | Text6 | Text8 | Text12 | Text3 | Text4 | Text5 |
| --- | --- | --- | --- | --- | --- | --- | --- | --- | --- | --- | --- | --- | --- | --- | --- | --- | --- | --- | --- | --- | --- | --- |
| 780 | 315 | **Deleted: Study on applicability of GALILEO for LCS** |  | 0d? | 2005-06-30 A | 2005-06-30 A | 100% | 2005-06-30 | 2005-06-30 | 0d? |  |  | S2 |  |  | Galileo | Rel-7 | Maurice | SP-25 |  |  |  |
| 781 | 315.1 | Deleted - TR on Stage 2 | milestone | 0d? | 2005-06-30 A | 2005-06-30 A | 100% | 2005-06-30 | 2005-06-30 | 0d? |  | finish no earlier than 2005-06-30 | S2 |  |  | Galileo | Rel-7 | Maurice | SP-25 |  |  |  |
| 782 | 315.2 | Deleted - GERAN review of the TR | milestone | 0d? | 2005-06-30 A | 2005-06-30 A | 100% | 2005-06-30 | 2005-06-30 | 0d? |  | start no earlier than 2005-06-30 | GP |  |  | Galileo | Rel-7 | Paolo | SP-26 |  |  |  |
| 783 | 16.7 | **Deleted - IMS Local services** |  | 0d? | 2006-01-06 A | 2006-01-06 A | 100% | 2006-01-06 | 2006-01-06 | 0d? |  |  | S2 |  |  | IMSLocal | Rel-7 | Maurice | SP-28 | 23.228 |  |  |
| 784 | 16.7.1 | Deleted - Stage 2 | milestone | 0d | 2006-01-06 A | 2006-01-06 A | 100% | 2006-01-06 | 2006-01-06 | 0d |  | start no earlier than 2006-01-06 | S2 |  |  | IMSLocal | Rel-7 | Maurice | SP-26 |  |  |  |
| 785 | 316.2 | Deleted - Stage 3 for IMS Local services | milestone | 0d? | 2006-01-06 A | 2006-01-06 A | 100% | 2006-01-06 | 2006-01-06 | 0d? |  | finish no earlier than 2006-01-06 | C1 |  |  | IMSLocal | Rel-7 | Frederic | SP-25 |  | Lucent | Keith Drage (drage@alcatel-lucent.com) |
| 786 | 317 | Deleted - IMS Phase 3 | milestone | 0d? | 2006-01-06 A | 2006-01-06 A | 100% | 2006-01-06 | 2006-01-06 | 0d? |  | start no earlier than 2006-01-06 | S2 |  |  |  | Rel-7 | Maurice | SP-25 |  |  |  |
| 787 | 318 | Deleted - Improvements of Radio Interface | milestone | 0d? | 2004-09-15 A | 2004-09-15 A | 100% | 2004-09-15 | 2004-09-15 | 0d? |  | start no earlier than 2004-09-15 | RP |  |  | RInImp | Rel-7 | Issam | SP-24 |  |  |  |
| 788 | 319 | Deleted: Generic User Profile Phase 2 | milestone | 0d | 2005-08-08 A | 2006-06-30 A | 100% | 2005-08-08 | 2006-06-30 | 0d |  |  | C4 |  |  |  | Rel-7 | Kimmo | SP-27 |  |  |  |
| 789 | 30.4 | Deleted - Stage 3 - Common objects | milestone | 0d | 2005-08-08 A | 2006-06-30 A | 100% | 2005-08-08 | 2006-06-30 | 0d |  | finish no earlier than 2006-06-30 | C4 |  |  |  | Rel-7 | Kimmo | SP-27 | 24.241 |  |  |
| 790 | 321 | Deleted - FS of enhanced support of Video Telephony | milestone | 0d? | 2006-06-30 A | 2006-06-30 A | 100% | 2006-06-30 | 2006-06-30 | 0d? |  | start no earlier than 2006-06-30 | GP |  |  | VIDGER | Rel-7 | Paolo | SP-32 |  | Ericsson | stefan.g.eriksson@ericsson.com |
| 791 | 322 | Deleted (moved to Rel8) - Study on Transferring of emergency call data – in-band modem solution | milestone | 0d? | 2007-06-22 A | 2007-06-22 A | 100% | 2007-06-22 | 2007-06-22 | 0d? |  | start no earlier than 2007-06-22 | S4 |  |  | eCALLIBMS | Rel-7 | Paolo | SP-38 | 26.967 | Airbiquity | lhong@airbiquity.com |
| 792 | 323 | Deleted - covered by UID 20053 - Study on Interference Cancellation for UTRA FDD UE |  | 1d? | 2007-03-28 A | 2007-03-28 A | 100% | 2007-03-28 | 2007-03-28 | 1d? |  | start no earlier than 2007-03-28 | R4 | 8h | 8h | RANFS-InterfCanc | Rel-7 | Issam | SP-38 |  |  |  |
| 793 | 324 | Deleted - Study on Stage 2 (IMS services using CS bearers) |  | 316d? | 2004-06-28 A | 2005-09-12 A | 100% | 2004-06-28 | 2005-09-12 | 316d? |  | finish no earlier than 2005-09-12 | S2 | 2528h | 2528h | IRTSD-IMSCS | Rel-7 | Maurice | SP-30 | 23.899 | Nortel | Mark Watson |
| 794 | 325 | Deleted - Study on IMS enhancements and optimizations for real time communication. |  | 430d? | 2005-10-10 A | 2007-06-01 A | 100% | 2005-10-10 | 2007-06-01 | 430d? |  | finish no earlier than 2007-06-01 | S2 | 3440h | 3440h | IMS-RT | Rel-7 | Maurice | SP-35 | 23.818 | Ericsson | stephen.terrill@ericsson.com |
| 795 | 326 | Deleted - Study on Terminating Session handling |  | 255d? | 2006-01-09 A | 2006-12-29 A | 100% | 2006-01-09 | 2006-12-29 | 255d? |  | finish no earlier than 2006-12-29 | S2 | 2040h | 2040h | CSIterm | Rel-7 | Maurice | SP-32 | 23.819 | Samsung |  |
| 796 | 327 | Deleted - Study on IRP usage scenarios |  | 330d? | 2005-09-02 A | 2006-12-07 A | 100% | 2005-09-02 | 2006-12-07 | 330d? |  | finish no earlier than 2006-12-07 | S5 | 2640h | 2640h | OAM-Study | Rel-7 | Dionisio | SP-32 | 32.8xy | Lucent |  |
| 797 | 328 | Release 6 Features |  | 1d? | 2000-01-03 | 2000-01-03 |  | 2000-01-03 | 2000-01-03 | 1d? | 3056d |  | NP,GP, RP,SP,TP | 8h |  |  | Rel-6 |  |  |  |  |  |
| 798 | 8 | **Rel-6 Improvements of Radio Interface** |  | 1393d? | 2000-08-14 A | 2005-12-14 A | 100% | 2000-08-14 | 2005-12-14 | 1393d? |  |  | RP | 38664h | 38664h | RInImp | Rel-6 | Issam |  |  |  |  |
| 799 | 329.1 | Improved support of IMS Realtime Services using HSDPA/EDCH |  | 197d? | 2005-03-15 A | 2005-12-14 A | 100% | 2005-03-15 | 2005-12-14 | 197d? |  | finish no earlier than 2005-12-14 | R2 | 1576h | 1576h | RInImp-IMSRealTime | Rel-6 | Joern |  |  | Cingular | Don Zelmer (dz1069@att.com) |
| 800 | 329.2 | Improving Receiver Performance Requirements for the FDD UE |  | 401d | 2002-03-08 A | 2003-09-19 A | 100% | 2002-03-08 | 2003-09-19 | 401d |  | start no earlier than 2002-03-08 | R4 | 3208h | 3208h | RInImp-UERecPerf | Rel-6 | Issam |  | 25.101 | Intel | shimon.moshavi@INTEL.COM |
| 801 | 8.2 | **Base station classification** |  | 603d | 2000-08-14 A | 2002-12-04 A | 100% | 2000-08-14 | 2002-12-04 | 603d |  |  | R4 | 9648h | 9648h | RInImp-BSClass | Rel-6 | Issam |  |  |  |  |
| 802 | 8.2.1 | FDD Base station classification |  | 603d | 2000-08-14 A | 2002-12-04 A | 100% | 2000-08-14 | 2002-12-04 | 603d |  | finish no earlier than 2002-12-04 | R4 | 4824h | 4824h | RInImp-BSClass-FDD | Rel-6 | Issam |  | 25.104, 25.141 | Nokia | antti.toskala@nokia.com |
| 803 | 329.4 | UMTS-850 |  | 266d | 2002-12-06 A | 2003-12-12 A | 100% | 2002-12-06 | 2003-12-12 | 266d |  | finish no earlier than 2003-12-15 | R4 | 2128h | 2128h | RInImp-UMTS850 | Rel-6 | Issam |  | 25.101, 25.104, 25.133, 25.141, 25.307, 25.331, 25.942 | Cingular | Don Zelmer (dz1069@att.com) |
| 804 | 329.5 | DS-CDMA introduction in the 800 MHz band |  | 196d | 2003-03-14 A | 2003-12-12 A | 100% | 2003-03-14 | 2003-12-12 | 196d |  | finish no earlier than 2003-12-15 | R4 | 1568h | 1568h | RInImp-UMTS800 | Rel-6 | Issam |  | 25.101, 25.104, 25.133, 25.141, 25.307, 25.331 | NTT DoCoMo | Takehiro Nakamura (nakamurata@nttdocomo.co.jp) |
| 805 | 329.6 | UMTS 1.7/2.1 GHz |  | 261d | 2003-03-14 A | 2004-03-12 A | 100% | 2003-03-14 | 2004-03-12 | 261d |  | finish no earlier than 2004-03-15 | R4 | 2088h | 2088h | RInImp-UMTS1721 | Rel-6 | Issam |  | 25.101, 25.104, 25.133, 25.141, 25.307, 25.331 | Nokia | jussi.numminen@NOKIA.COM |

Notes:
- 780: -
- 781: -
- 782: -
- 783: -
- 784: DAB - Not yet required in SA2 as it exists in previous releases
- 785: -
- 786: -
- 787: Stage 2 description of Interim conclusion
- 788: Created at TSG#27 by A. Sultan because of the move to Rel-7 of "Common Objects".
- 789: No progress in CN4#26. This have to be moved to Rel-7. It was deleted from WID
- 790: FS CLOSED at G#28 (no input)
- 791: SP-38 stopped
- 792: Deleted. Same as FS on Further Improved Performance Requirements for UMTS/HSDPA UE (FDD)
- 793: SP-30: S2 has no intention for TR completion
- 794: abandoned at 65%
- 795: SP#32 Jun 2006 Study abandoned => spin-off Implementation work UID_320029
- 796: -
- 797: -
- 798: This is a generic feature without particular end date
- 799: -
- 800: -
- 801: -
- 802: -
- 803: Introduction of UMTS850 (Band V) in 25.307
- 804: Introduction of UMTS800 in 25.307
- 805: Introduction of UMTS1700/2100 (Band IV)

| ID | WBS | Task | Type | Duration | Start | Finish | Complete | Baseline start | Baseline finish | Baseline duration | Constraint | Resources | Work | Actual work | Text1 | Text4 | Text5 | Text6 | Text8 | Text3 | Text10 | Text12 |
| --- | --- | --- | --- | --- | --- | --- | --- | --- | --- | --- | --- | --- | --- | --- | --- | --- | --- | --- | --- | --- | --- | --- |
| 806 | 329.7 | **Improved Receiver Performance Requirements for HSDPA** |  | 392d? | 2003-12-15 A | 2005-06-14 A | 100% | 2003-12-15 | 2005-06-14 | 392d? |  | R4 | 7304h | 7304h | RInImp-HSPerf | Nokia | jussi.numminen@NOKIA.COM | Rel-6 | Issam |  |  |  |
| 807 | 329.7.1 | Improved Minimum Performance Requirements for HSDPA UE categories 7 and 8 |  | 195d? | 2004-09-15 A | 2005-06-14 A | 100% | 2004-09-15 | 2005-06-14 | 195d? | finish no earlier than 2005-06-14 | R4 | 1560h | 1560h | RInImp-HSPerf-10code | Nokia | jussi.numminen@nokia.com | Rel-6 | Issam | 25.101 |  |  |
| 808 | 329.7.2 | Performance Requirements of Receive Diversity for HSDPA |  | 326d | 2003-12-15 A | 2005-03-14 A | 100% | 2003-12-15 | 2005-03-14 | 326d | finish no earlier than 2005-03-14 | R4 | 2608h | 2608h | RInImp-HSPerf-RxDiv | NTT DoCoMo | Takehiro Nakamura (nakamurata@nttdocomo.co.jp) | Rel-6 | Issam | 25.101 |  |  |
| 809 | 330 | **Rel-6 RAN Feasibility Studies** |  | 1196d? | 2000-08-14 A | 2005-03-14 A | 100% | 2000-08-14 | 2005-03-14 | 1196d? |  | RP | 43048h | 43048h |  |  |  | Rel-6 |  |  |  |  |
| 810 | 330.1 | FS of the improved access to UE measurement data for CRNC to support TDD RRM |  | 270d? | 2002-12-06 A | 2003-12-18 A | 100% | 2002-12-06 | 2003-12-18 | 270d? | finish no earlier than 2003-09-19 | R3 | 2160h | 2160h | RANimp-RRMopt-FSUEMsD | Interdigital | jim.miller@interdigital.com | Rel-6 | Juha | 25.801, 25.423 | SP-24 |  |
| 811 | 330.2 | FS on Radio link performance enhancements |  | 1067d | 2000-08-14 A | 2004-09-14 A | 100% | 2000-08-14 | 2004-09-14 | 1067d | finish no earlier than 2004-09-14 | R1 | 8536h | 8536h | RInImp-Rlperf | Nokia | antti.toskala@nokia.com | Rel-6 | Patrick | 25.899 |  |  |
| 812 | 330.3 | FS on Improvement of inter-frequency and inter-system measurements for 1.28 Mcps TDD |  | 461d | 2001-12-14 A | 2003-09-19 A | 100% | 2001-12-14 | 2003-09-19 | 461d | start no earlier than 2001-12-14 | R1 | 3688h | 3688h | RInImp-IfIsMLCR | Samsung | Li Xiao Qiang (xqli@samsung.co.kr) | Rel-6 | Patrick | 25.888 |  |  |
| 813 | 330.4 | FS for the analysis of OFDM for UTRAN enhancement |  | 526d | 2002-06-10 A | 2004-06-14 A | 100% | 2002-06-10 | 2004-06-14 | 526d | start no earlier than 2002-06-10 | R1 | 4208h | 4208h | RInImp-FSOFDM | Nortel | Sarah Boumendil | Rel-6 | Patrick | 25.892 |  |  |
| 814 | 330.5 | FS on Uplink Enhancements for Dedicated Transport Channels |  | 396d | 2002-09-06 A | 2004-03-12 A | 100% | 2002-09-06 | 2004-03-12 | 396d | finish no earlier than 2004-03-12 | R1 | 3168h | 3168h | RInImp-FSUpDTrCh | Nokia | Karri.Ranta-aho@nsn.com | Rel-6 | Patrick | 25.896 |  |  |
| 815 | 330.6 | FS on Analysis on Higher Chip Rates for UTRA TDD evolutions |  | 528d | 2002-09-06 A | 2004-09-14 A | 100% | 2002-09-06 | 2004-09-14 | 528d | finish no earlier than 2004-09-14 | R1 | 4224h | 4224h | RInImp-FSVHCRTDD | IPWireless | mbeale@ipwireless.com | Rel-6 | Patrick | 25.895 |  |  |
| 816 | 330.7 | FS on Low Output Powers for general purpose FDD BSs |  | 128d | 2003-06-13 A | 2004-03-12 A | 100% | 2003-06-13 | 2004-03-12 | 128d | finish no earlier than 2004-03-12 | R3 | 1024h | 1024h | RInImp-FSLoPw | Telefonica | Ana Burgos (burgos_a@tsm.es) | Rel-6 | Juha | 25.807 |  |  |
| 817 | 330.8 | FS on Uplink enhancements for UTRA TDD |  | 462d | 2003-06-06 A | 2005-03-14 A | 100% | 2003-06-06 | 2005-03-14 | 462d | finish no earlier than 2005-03-14 | R1 | 3696h | 3696h | RInImp-FSUpEnhTDD | Interdigital | Marian.Rudolf@InterDigital.com | Rel-6 | Patrick | 25.804 |  |  |
| 818 | 8.8 | FS on UE antenna efficiency test methods performance requirements (2) |  | 131d | 2002-03-08 A | 2002-09-06 A | 100% | 2002-03-08 | 2002-09-06 | 131d | finish no earlier than 2002-09-06 | R4 | 1048h | 1048h | RInImp-UEAnTM2 | Allgon | Alf Ahlström | Rel-6 | Issam |  |  |  |
| 819 | 9.4 | Deleted - FS on the evolution of the UTRAN architecture |  | 592d | 2002-09-09 A | 2004-12-14 A | 100% | 2002-09-09 | 2004-12-14 | 592d | finish no earlier than 2004-12-15 | R3 | 4736h | 4736h | RANimp-FSEvo | Nokia | woonhee.hwang@nsn.com, Antti.Toskala@nokia.com | Rel-6 | Juha |  |  | RP-26 |
| 820 | 331 | **FDD Enhanced Uplink** |  | 393d | 2004-03-15 A | 2005-09-14 A | 100% | 2004-03-15 | 2005-09-14 | 393d |  | RP | 14128h | 14128h | EDCH | Ericsson | Joakim Bergström | Rel-6 |  |  |  |  |
| 821 | 331.1 | FDD Enhanced Uplink - Stage 2 |  | 197d | 2004-03-15 A | 2004-12-14 A | 100% | 2004-03-15 | 2004-12-14 | 197d | finish no earlier than 2004-12-14 | R2 | 1576h | 1576h | EDCH-Stage2 |  |  | Rel-6 | Joern | 25.309 |  |  |
| 822 | 331.2 | FDD Enhanced Uplink - Physical Layer |  | 261d | 2004-03-15 A | 2005-03-14 A | 100% | 2004-03-15 | 2005-03-14 | 261d | finish no earlier than 2005-03-14 | R1 | 2088h | 2088h | EDCH-Phys | Nokia | Karri.Ranta-aho@nsn.com | Rel-6 | Patrick | 25.211, 25.212, 25.213, 25.214, 25.215 |  |  |
| 823 | 331.3 | FDD Enhanced Uplink - Layer 2 and 3 Protocol Aspects |  | 261d | 2004-03-15 A | 2005-03-14 A | 100% | 2004-03-15 | 2005-03-14 | 261d | finish no earlier than 2005-03-14 | R2 | 2088h | 2088h | EDCH-L23 | Ericsson | Joakim Bergström | Rel-6 | Joern | 25.301, 25.302, 25.306, 25.321, 25.331 |  |  |
| 824 | 331.4 | FDD Enhanced Uplink - UTRAN Iub/Iur Protocol Aspects |  | 261d | 2004-03-15 A | 2005-03-14 A | 100% | 2004-03-15 | 2005-03-14 | 261d | finish no earlier than 2005-03-14 | R3 | 2088h | 2088h | EDCH-IurIub | Nortel | Saso Stojanovski | Rel-6 | Juha | 25.401, 25.420, 25.423, 25.430, 25.433 |  |  |
| 825 | 331.5 | FDD Enhanced Uplink - RF Radio Transmission/ Reception, System Performance Requirements and Conformance Testing |  | 393d | 2004-03-15 A | 2005-09-14 A | 100% | 2004-03-15 | 2005-09-14 | 393d | finish no earlier than 2005-09-15 | R4 | 3144h | 3144h | EDCH-RF | Ericsson | thomas.unshelm@ERICSSON.COM | Rel-6 | Issam | 25.101, 25.104, 25.133, 25.141 |  |  |
| 826 | 332 | **Rel-6 RAN improvements** |  | 656d? | 2002-09-09 A | 2005-03-14 A | 100% | 2002-09-09 | 2005-03-14 | 656d? |  | RP | 28312h | 28312h | RANimp |  |  | Rel-6 |  |  |  |  |
| 827 | 9.2 | **RAB support enhancement** |  | 522d? | 2003-03-14 A | 2005-03-14 A | 100% | 2003-03-14 | 2005-03-14 | 522d? |  | R2 | 9360h | 9360h | RANimp-RABSE | Nokia | Jussi Kähtävä (juha.mikola@nokia.com) | Rel-6 | Joern | 25.862 |  |  |
| 828 | 332.1.1 | Optimization of downlink channelisation code utilisation |  | 262d | 2004-03-12 A | 2005-03-14 A | 100% | 2004-03-12 | 2005-03-14 | 262d | finish no earlier than 2005-03-14 | R1 | 2096h | 2096h | RANimp-RABSE-CodeOptFDD | Nortel | Sarah Boumendil | Rel-6 | Patrick |  |  |  |
| 829 | 332.1.2 | optimization of channelisation code utilisation for 3.84 Mcps TDD |  | 261d | 2004-03-15 A | 2005-03-14 A | 100% | 2004-03-15 | 2005-03-14 | 261d | finish no earlier than 2005-03-15 | R1 | 2088h | 2088h | RANimp-RABSE-CodOptTDD | IPWireless | Nicholas Anderson | Rel-6 | Patrick |  |  |  |
| 830 | 332.1.3 | HS-DPCCH ACK/NACK Enhancement |  | 65d? | 2004-09-15 A | 2004-12-14 A | 100% | 2004-09-15 | 2004-12-14 | 65d? | finish no earlier than 2004-12-15 | R1 | 520h | 520h | RANimp-RABSE-ACKNACK | Nokia | Jussi Kähtävä (juha.mikola@nokia.com) | Rel-6 | Patrick | 25.212, 25.214, 24.331, 25.433 |  |  |
| 831 | 332.1.4 | Deleted - Iu enhancements for IMS support in RAN |  | 320d? | 2003-03-14 A | 2004-06-03 A | 100% | 2003-03-14 | 2004-06-03 | 320d? | start no earlier than 2003-03-14 | R3 | 2560h | 2560h | RANimp-RABSE-IuEnhIMS | Nortel | Philippe.Godin@nortelnetworks.com | Rel-6 | Juha |  |  | RP-24 |
| 832 | 332.1.5 | Deleted - Improvement of RRM across RNS and RNS/BSS | milestone | 0d? | 2003-12-05 A | 2003-12-05 A | 100% | 2003-12-05 | 2003-12-05 | 0d? | finish no earlier than 2003-12-05 | R3 |  |  | RANimp-RRM1 | Nokia | antti.toskala@nokia.com | Rel-6 | Juha |  |  | RP-23 |
| 833 | 9.1 | Beamforming Enhancements |  | 66d | 2003-09-19 A | 2003-12-19 A | 100% | 2003-09-19 | 2003-12-19 | 66d | finish no earlier than 2004-03-12 | R1 | 528h | 528h | RANimp-BFE | Nokia | Jussi Kähtävä (juha.mikola@nokia.com) | Rel-6 | Patrick | 24.215, 25.423, 25.425, 25.433, 25.435 |  |  |

Notes:
- 806: -
- 807: Approved at RP#25 as RP-040375
- 808: -
- 809: -
- 810: -
- 811: Study finished at RP#25
- 812: -
- 813: -
- 814: -
- 815: Study finished at RP#25
- 816: -
- 817: -
- 818: The RInImp-UEAnTM FS was re-opened at TSG RP#15 upon request from WG4
- 819: Study Closed, work will continue within the FS on evolved UTRA and UTRAN
- 820: -
- 821: -
- 822: -
- 823: -
- 824: -
- 825: -
- 826: Generic feature
- 827: building block without particular end date
- 828: -
- 829: WIDS modified in RP#26, RP-040551
- 830: Approved at RP#25 as RP-040390
- 831: Closed RP#24 due to the lack of progress
- 832: abandoned RP-23
- 833: -

| ID | WBS | Task | Type | Duration | Start | Finish | Complete | Baseline start | Baseline finish | Baseline duration | Constraint | Resources | Work | Actual work | Text1 | Text4 | Text5 | Text6 | Text8 | Text3 | Text12 | Text10 |
| --- | --- | --- | --- | --- | --- | --- | --- | --- | --- | --- | --- | --- | --- | --- | --- | --- | --- | --- | --- | --- | --- | --- |
| 834 | 332.3 | **Rel6 RRM optimization for Iur and Iub** |  | 126d | 2003-09-19 A | 2004-03-12 A | 100% | 2003-09-19 | 2004-03-12 | 126d |  | R3 | 2016h | 2016h | RANimp-RRMopt | Ericsson | Gert-Jan.van.Lieshout@eln.ericsson.se | Rel-6 | Juha |  |  |  |
| 835 | 332.3.1 | Improved access to UE measurement data for CRNC to support TDD RRM |  | 126d | 2003-09-19 A | 2004-03-12 A | 100% | 2003-09-19 | 2004-03-12 | 126d | finish no earlier than 2004-03-15 | R3 | 1008h | 1008h | RANimp-RRMopt-UEMsD | Interdigital | jim.miller@interdigital.com | Rel-6 | Juha | 25.423 | RP-22 |  |
| 836 | 332.4 | **Remote Control of Electrical Tilting Antennas** |  | 395d? | 2003-03-14 A | 2004-09-16 A | 100% | 2003-03-14 | 2004-09-16 | 395d? |  | R3 | 7464h | 7464h | RANimp-TiltAnt | Vodafone | Andreas.Hauser@vodafone.com | Rel-6 | Juha |  |  |  |
| 837 | 332.4.1 | Tilting Antenna - RAN aspects |  | 393d? | 2003-03-14 A | 2004-09-14 A | 100% | 2003-03-14 | 2004-09-14 | 393d? | finish no earlier than 2004-09-14 | R3 | 3144h | 3144h | RANimp-TiltAnt | Vodafone | Andreas.Hauser@vodafone.com | Rel-6 | Juha | 25.460, 25.461, 25.462, 25.463 |  |  |
| 838 | 332.4.2 | OAM&P impacts |  | 145d | 2004-02-27 A | 2004-09-16 A | 100% | 2004-02-27 | 2004-09-16 | 145d | finish no earlier than 2004-09-16 | S5 | 1160h | 1160h | RANimp-TiltAnt-OAM | Vodafone | Adrian.Neal@vodafone.com | Rel-6 | Dionisio | 32.804, 32.64x |  | SP-24 |
| 839 | 332.5 | Network Assisted Cell Change (NACC) from UTRAN to GERAN - network-side aspects |  | 462d? | 2002-09-09 A | 2004-06-15 A | 100% | 2002-09-09 | 2004-06-15 | 462d? | finish no earlier than 2004-06-15 | R3 | 3696h | 3696h | RANimp-NACC | Vodafone | Brendan.McWilliams@gb.vodafone.co.uk | Rel-6 | Juha |  |  |  |
| 840 | 12 | **Location Services enhancements 2** |  | 1024d? | 2001-01-15 A | 2004-12-16 A | 100% | 2001-01-15 | 2004-12-16 | 1024d? |  | S2,S5,N4,RP | 78152h | 78152h | LCS2 |  |  | Rel-6 | Maurice | 23.271 |  |  |
| 841 | 12.1 | **Improvement on Le interface** |  | 653d? | 2002-06-17 A | 2004-12-15 A | 100% | 2002-06-17 | 2004-12-15 | 653d? |  | S2 | 9872h | 9872h | LCS2 |  |  | Rel-6 | Maurice |  |  |  |
| 842 | 333.1.1 | Stage 2 |  | 331d? | 2002-06-17 A | 2003-09-22 A | 100% | 2002-06-17 | 2003-09-22 | 331d? | start no earlier than 2002-06-17 | S2 | 2648h | 2648h | LCS2 |  |  | Rel-6 | Maurice |  |  |  |
| 843 | 333.1.2 | Stage 3 - impacts MLP (Mobile Location Protocol) |  | 250d? | 2004-01-01 A | 2004-12-15 A | 100% | 2004-01-01 | 2004-12-15 | 250d? | finish no earlier than 2004-12-15 | OMA | 2000h | 2000h | LCS2 |  | OMA-LIAISON@mail.openmobilealliance.org | Rel-6 |  |  |  |  |
| 844 | 12.2 | **Enhanced support for anonymity and user privacy** |  | 638d? | 2002-07-08 A | 2004-12-15 A | 100% | 2002-07-08 | 2004-12-15 | 638d? |  | S2 | 9144h | 9144h | LCS2 |  |  | Rel-6 | Maurice |  |  |  |
| 845 | 333.2.1 | Stage 2 |  | 255d? | 2002-07-08 A | 2003-06-27 A | 100% | 2002-07-08 | 2003-06-27 | 255d? | finish no earlier than 2003-06-27 | S2 | 2040h | 2040h | LCS2 |  |  | Rel-6 | Maurice |  |  |  |
| 846 | 333.2.2 | Stage 3 - impacts MLP and RLP |  | 250d? | 2004-01-01 A | 2004-12-15 A | 100% | 2004-01-01 | 2004-12-15 | 250d? | finish no earlier than 2004-12-15 | OMA | 2000h | 2000h | LCS2 |  | OMA-LIAISON@mail.openmobilealliance.org | Rel-6 |  |  |  |  |
| 847 | 12.3 | **Enhanced inter-GMLC interface** |  | 648d? | 2002-06-24 A | 2004-12-15 A | 100% | 2002-06-24 | 2004-12-15 | 648d? |  | S2 | 9704h | 9704h | LCS2 |  |  | Rel-6 | Maurice |  |  |  |
| 848 | 333.3.1 | Stage 2 |  | 315d? | 2002-06-24 A | 2003-09-05 A | 100% | 2002-06-24 | 2003-09-05 | 315d? | finish no earlier than 2003-09-05 | S2 | 2520h | 2520h | LCS2 |  |  | Rel-6 | Maurice |  |  |  |
| 849 | 333.3.2 | Stage 3 - definition of RLP and PCP |  | 250d? | 2004-01-01 A | 2004-12-15 A | 100% | 2004-01-01 | 2004-12-15 | 250d? | finish no earlier than 2004-12-15 | OMA | 2000h | 2000h | LCS2 |  | OMA-LIAISON@mail.openmobilealliance.org | Rel-6 |  |  |  |  |
| 850 | 12.4 | **Location Services support for IMS public identities** |  | 473d? | 2003-02-24 A | 2004-12-15 A | 100% | 2003-02-24 | 2004-12-15 | 473d? |  | S2 | 7704h | 7704h | LCS2 |  |  | Rel-6 | Maurice |  |  |  |
| 851 | 333.4.1 | Stage 2 |  | 240d? | 2003-02-24 A | 2004-01-23 A | 100% | 2003-02-24 | 2004-01-23 | 240d? | finish no earlier than 2004-01-23 | S2 | 1920h | 1920h | LCS2 |  |  | Rel-6 | Maurice |  |  |  |
| 852 | 333.4.2 | Stage 3 - impacts MLP, RLP and PCP |  | 250d? | 2004-01-01 A | 2004-12-15 A | 100% | 2004-01-01 | 2004-12-15 | 250d? | finish no earlier than 2004-12-15 | OMA | 2000h | 2000h | LCS2 |  | OMA-LIAISON@mail.openmobilealliance.org | Rel-6 |  |  |  |  |
| 853 | 12.5 | **New area event for location service triggering reports** |  | 663d? | 2002-06-03 A | 2004-12-15 A | 100% | 2002-06-03 | 2004-12-15 | 663d? |  | S2 | 11416h | 11416h | LCS2 |  |  | Rel-6 | Maurice |  |  |  |
| 854 | 333.5.1 | Stage 2 |  | 280d? | 2002-06-03 A | 2003-06-27 A | 100% | 2002-06-03 | 2003-06-27 | 280d? | finish no earlier than 2003-06-27 | S2 | 2240h | 2240h | LCS2 |  |  | Rel-6 | Maurice |  |  |  |
| 855 | 333.5.2 | Stage 3 for UE-CN signalling |  | 234d? | 2003-10-09 A | 2004-08-31 A | 100% | 2003-10-09 | 2004-08-31 | 234d? | start no earlier than 2003-10-09 | N4 | 1872h | 1872h | LCS2 |  |  | Rel-6 | Kimmo |  |  |  |
| 856 | 333.5.3 | Stage 3 - impacts MLP, RLP and PCP |  | 250d? | 2004-01-01 A | 2004-12-15 A | 100% | 2004-01-01 | 2004-12-15 | 250d? | finish no earlier than 2004-12-15 | OMA | 2000h | 2000h | LCS2 |  | OMA-LIAISON@mail.openmobilealliance.org | Rel-6 |  |  |  |  |
| 857 | 12.7 | **UE positioning** |  | 957d? | 2001-01-15 A | 2004-09-14 A | 100% | 2001-01-15 | 2004-09-14 | 957d? |  | RP | 18480h | 18480h | LCS2-UEpos |  |  | Rel-6 | Issam |  |  |  |
| 858 | 12.8 | Open SMLC-SRNC Interface within the UTRAN to support UTRAN Rel4 positioning methods |  | 700d? | 2001-01-15 A | 2003-09-19 A | 100% | 2001-01-15 | 2003-09-19 | 700d? | finish no earlier than 2003-09-19 | R2 | 5600h | 5600h | LCS-Rel4Pos | Siemens | Meik.Kottkamp@siemens.com | Rel-6 | Joern | 25.305, 25.401, 25.450, 25.452, 25.453 |  |  |
| 859 | 333.6.2 | A-GPS minimum performance specification |  | 333d? | 2003-06-06 A | 2004-09-14 A | 100% | 2003-06-06 | 2004-09-14 | 333d? | finish no earlier than 2004-09-14 | R4 | 2664h | 2664h | LCS-UEPos-AGPSPerf | AT&T Wireless | donglin.shen@attws.com | Rel-6 | Issam | 25.171 |  |  |
| 860 | 12.7.2 | FS on Enhancements to OTDOA Positioning using advanced blanking methods |  | 320d | 2002-07-01 A | 2003-09-19 A | 100% | 2002-07-01 | 2003-09-19 | 320d | finish no earlier than 2003-09-19 | R2 | 2560h | 2560h | LCS2-UEpos-FSBlank | Cambridge Positioning Systems | david.bartlett@cursor-system.com | Rel-6 | Joern |  |  |  |
| 861 | 333.6.4 | Deleted - UE positioning enhancements - other methods | milestone | 0d? | 2003-09-26 A | 2003-09-26 A | 100% | 2003-09-26 | 2003-09-26 | 0d? | finish no earlier than 2003-09-26 | R2 |  |  | LCS2-UEpos-enh | Siemens | Meik.Kottkamp@siemens.com | Rel-6 | Joern |  | RP-24 |  |
| 862 | 333.7 | LCS charging |  | 455d? | 2003-03-21 A | 2004-12-16 A | 100% | 2003-03-21 | 2004-12-16 | 455d? | start no earlier than 2003-03-21 | S5 | 3640h | 3640h | LCS2-CH | France Telecom | alain.bibas@orange-ft.com | Rel-6 | Dionisio | 32.271 |  |  |

Notes:
- 834: -
- 835: -
- 836: -
- 837: Finished at RP#25
- 838: SP#25 09/2004 completed
- 839: -
- 840: -
- 841: -
- 842: -
- 843: Updated according to SP-040232
- 844: -
- 845: -
- 846: Updated according to SP-040232
- 847: -
- 848: -
- 849: Updated according to SP-040232
- 850: -
- 851: -
- 852: Updated according to SP-040232
- 853: -
- 854: -
- 855: 31/10/2003 work has started. Current stage 3 fullfills the requirements of stage 2. ......
- 856: Updated according to SP-040232
- 857: -
- 858: -
- 859: Finished at RP#25
- 860: -
- 861: building block without particular end date
- 862: SP#26 12/2004 completed

| ID | WBS | Task | Duration | Start | Finish | Complete | Baseline start | Baseline finish | Baseline duration | Constraint | Resources | Work | Actual work | Text1 | Text4 | Text5 | Text6 | Text8 | Text12 | Text10 |
| --- | --- | --- | --- | --- | --- | --- | --- | --- | --- | --- | --- | --- | --- | --- | --- | --- | --- | --- | --- | --- |
| 863 | 14 | **Rel-6 Security enhancements** | 1018d? | 2001-01-03 A | 2004-11-26 A | 100% | 2001-01-03 | 2004-11-26 | 1018d? |  | S3 | 28824h | 28824h | SEC1 | Vodafone | Peter.Howard@vodafone.com | Rel-6 | Dionisio |  |  |
| 864 | 14.1 | **Enhanced HE control of security (including positive authentication reporting)** | 712d | 2001-01-03 A | 2003-09-25 A | 100% | 2001-01-03 | 2003-09-25 | 712d |  | S3 | 14064h | 14064h | SEC1 | Vodafone | Peter.Howard@vodafone.com | Rel-6 | Dionisio |  |  |
| 865 | 14.1.1 | Deleted - SEC1 Stage 2 (Enhanced HE control of security) | 378d | 2001-01-03 A | 2002-06-14 A | 100% | 2001-01-03 | 2002-06-14 | 378d | finish no earlier than 2002-06-14 | S3 | 3024h | 3024h | SEC1 |  |  | Rel-6 | Dionisio | SP-16 |  |
| 866 | 14.1.3 | **Network domain security** | 334d | 2002-06-17 A | 2003-09-25 A | 100% | 2002-06-17 | 2003-09-25 | 334d |  | S3 | 5344h | 5344h | SEC1-NDS | Telenor | Geir-myrdahl.koien@telenor.com | Rel-6 | Dionisio |  |  |
| 867 | 14.1.3.1 | IP network layer security (NDS/IP) | 334d | 2002-06-17 A | 2003-09-25 A | 100% | 2002-06-17 | 2003-09-25 | 334d | finish no earlier than 2003-09-25 | S3 | 2672h | 2672h | SEC1-NDS-IP |  |  | Rel-6 | Dionisio |  |  |
| 868 | 334.2 | Network Domain Security; Authentication Framework (NDS/AF) | 521d? | 2002-02-15 A | 2004-02-13 A | 100% | 2002-02-15 | 2004-02-13 | 521d? | finish no earlier than 2004-02-13 | S3 | 4168h | 4168h | SEC1-NDS-AF | Nokia | tommi.viitanen@nokia.com | Rel-6 | Dionisio |  |  |
| 869 | 334.3 | Key Management of group keys for Voice Group Call Services | 306d | 2003-09-26 A | 2004-11-26 A | 100% | 2003-09-26 | 2004-11-26 | 306d | finish no earlier than 2004-11-26 | S3 | 2448h | 2448h | SECGKYV | Vodafone | benno.tietz@vodafone.com | Rel-6 | Dionisio |  |  |
| 870 | 335 | **3GPP Enablers for services like Push to Talk over Cellular (PoC)** | 459d? | 2003-09-08 A | 2005-06-09 A | 100% | 2003-09-08 | 2005-06-09 | 459d? |  | S2,S4,S5 | 10696h | 10696h | PoC | Ericsson | Shabnam Sultana | Rel-6 | Maurice |  |  |
| 871 | 335.1 | Feasibility Study | 322d? | 2003-09-08 A | 2004-11-30 A | 100% | 2003-09-08 | 2004-11-30 | 322d? | finish no earlier than 2004-11-30 | S2 | 2576h | 2576h | PoC | Ericsson | Shabnam Sultana | Rel-6 | Maurice |  | SP-24 |
| 872 | 335.2 | Dependencies on OMA PoC | 303d? | 2004-01-01 A | 2005-02-28 A | 100% | 2004-01-01 | 2005-02-28 | 303d? | finish no earlier than 2004-12-30 | OMA | 2424h | 2424h | PoC |  | OMA-LIAISON@mail.openmobilealliance.org | Rel-6 |  |  | SP-24 |
| 873 | 335.3 | Selection of one or more PoC codec(s) for PoC | 69d? | 2004-09-13 A | 2004-12-16 A | 100% | 2004-09-13 | 2004-12-16 | 69d? | start no earlier than 2004-09-13 | S4 | 552h | 552h | PoC |  |  | Rel-6 | Paolo |  | SP-25 |
| 874 | 335.4 | PoC charging | 184d? | 2004-09-27 A | 2005-06-09 A | 100% | 2004-09-27 | 2005-06-09 | 184d? | finish no earlier than 2005-06-09 | S5 | 1472h | 1472h | PoC-CH | Siemens | Gerald GÖRMER | Rel-6 | Dionisio |  |  |
| 875 | 336 | Study on Interworking aspects and migration scenarios for IPv4 based IMS Implementations | 210d? | 2003-09-08 A | 2004-06-25 A | 100% | 2003-09-08 | 2004-06-25 | 210d? | finish no earlier than 2004-06-25 | S2 | 1680h | 1680h | IPv4IMS | Siemens | Alexander Milinski | Rel-6 | Maurice |  |  |
| 876 | 16.3 | **Interoperability and Commonality between IMS using different "IP-connectivity Networks"** | 325d? | 2002-09-16 A | 2003-12-12 A | 100% | 2002-09-16 | 2003-12-12 | 325d? |  | S2 | 9176h | 9176h | IMSCOOP |  |  | Rel-6 | Maurice |  |  |
| 877 | 16.3.1 | Stage 2 for Interoperability | 272d | 2002-09-16 A | 2003-09-30 A | 100% | 2002-09-16 | 2003-09-30 | 272d | finish no earlier than 2003-09-30 | S2 | 2176h | 2176h | IMSCOOP | Nokia | balazs.bertenyi@nsn.com | Rel-6 | Maurice |  |  |
| 878 | 337.2 | Stage 2 for commonality | 265d? | 2002-09-16 A | 2003-09-19 A | 100% | 2002-09-16 | 2003-09-19 | 265d? | start no earlier than 2002-09-16 | S2 | 2120h | 2120h | IMSCOOP | Nokia | balazs.bertenyi@nsn.com | Rel-6 | Maurice |  |  |
| 879 | 16.3.2 | Stage 3 | 305d | 2002-10-14 A | 2003-12-12 A | 100% | 2002-10-14 | 2003-12-12 | 305d | finish no earlier than 2003-12-12 | N1 | 2440h | 2440h | IMSCOOP | Lucent | Keith Drage (drage@alcatel-lucent.com) | Rel-6 | Frederic |  |  |
| 880 | 19 | **Rel-6 MExE enhancements** | 326d | 2002-03-08 A | 2003-06-06 A | 100% | 2002-03-08 | 2003-06-06 | 326d |  | T2 | 7328h | 7328h | MEXE6 |  |  | Rel-6 | Kimmo |  |  |
| 881 | 19.1 | MExE Rel-6 Improvements and Investigations | 264d | 2002-03-08 A | 2003-03-12 A | 100% | 2002-03-08 | 2003-03-12 | 264d | finish no earlier than 2003-03-12 | T2 | 2112h | 2112h | MEXE6-ENHANC | TTPCom | Lars Brenk ( (lsb_ttpcom@HOTMAIL.COM) | Rel-6 |  |  |  |
| 882 | 19.2 | MExE Run-Time Independent Framework Feasibility Study | 326d | 2002-03-08 A | 2003-06-06 A | 100% | 2002-03-08 | 2003-06-06 | 326d | finish no earlier than 2003-06-06 | T2 | 2608h | 2608h | MEXE6-RTIF | Intel | Aaron.Cohen@intel.com | Rel-6 |  |  |  |
| 883 | 21 | Subscription Management | 650d | 2002-09-20 A | 2005-03-17 A | 100% | 2002-09-20 | 2005-03-17 | 650d | finish no earlier than 2005-03-17 | S5 | 5200h | 5200h | SuM | T-Mobile | istvan.aba@t-mobile.at | Rel-6 | Dionisio |  |  |
| 884 | 25 | **Enhanced A/Gb feasibility study** | 51d? | 2002-08-30 A | 2002-11-08 A | 100% | 2002-08-30 | 2002-11-08 | 51d? |  | GP | 3264h | 3264h | AGbEnFS | Vodafone | jose-luis.carrizo@vodafone.co.uk | Rel-6 | Paolo |  |  |
| 885 | 25.1 | **Feasibility study on A/Gb enhancements** | 51d? | 2002-08-30 A | 2002-11-08 A | 100% | 2002-08-30 | 2002-11-08 | 51d? |  | G2 | 2856h | 2856h | AGbEnFS-FS | Vodafone | jose-luis.carrizo@vodafone.co.uk | Rel-6 | Gert |  |  |
| 886 | 25.1.1 | Requirements for the support of conversational services | 51d | 2002-08-30 A | 2002-11-08 A | 100% | 2002-08-30 | 2002-11-08 | 51d | finish no earlier than 2002-11-08 | GP | 408h | 408h | AGbEnFS-FS |  |  | Rel-6 | Paolo |  |  |
| 887 | 340.1.2 | Identification of the different building blocks for the provision of conversational services on the existing A/Gb protocol stack | 51d? | 2002-08-30 A | 2002-11-08 A | 100% | 2002-08-30 | 2002-11-08 | 51d? | finish no earlier than 2002-11-08 | GP | 408h | 408h | AGbEnFS-FS |  |  | Rel-6 | Paolo |  |  |
| 888 | 340.1.3 | Outline of impact and feasibility of these building blocks and their different solutions | 51d? | 2002-08-30 A | 2002-11-08 A | 100% | 2002-08-30 | 2002-11-08 | 51d? | finish no earlier than 2002-11-08 | GP | 408h | 408h | AGbEnFS-FS |  |  | Rel-6 | Paolo |  |  |
| 889 | 25.1.4 | Impact on 3GPP architecture and requirement to co-ordinatge with other TSGs (CN, SA) | 51d | 2002-08-30 A | 2002-11-08 A | 100% | 2002-08-30 | 2002-11-08 | 51d | finish no earlier than 2002-11-08 | GP | 408h | 408h | AGbEnFS-FS |  |  | Rel-6 | Paolo |  |  |
| 890 | 25.1.5 | Standardisation effort | 51d | 2002-08-30 A | 2002-11-08 A | 100% | 2002-08-30 | 2002-11-08 | 51d | finish no earlier than 2002-11-08 | GP | 408h | 408h | AGbEnFS-FS |  |  | Rel-6 | Paolo |  |  |
| 891 | 25.1.6 | Dependency to other features | 51d | 2002-08-30 A | 2002-11-08 A | 100% | 2002-08-30 | 2002-11-08 | 51d | finish no earlier than 2002-11-08 | GP | 408h | 408h | AGbEnFS-FS |  |  | Rel-6 | Paolo |  |  |

Notes:
- 863: Added BB UE authentication and rapporteur added.
- 864: Added by SP-000575 without any dates. 18/10/00: Change of WI title, added hyperlink rapporteur new end date 03/01. New end date and correct Release to be decided S3#18
- 865: New end date and correct Release to be decided S3#18. Marked as stopped 12/2008
- 866: WID approved for Rel-6 at SP#17. Completed 2004-12
- 867: Should be complete after SA3#27. Completed 2004-12 / Text3: 33.210
- 868: WID approved SP#19. Work started after FS approved SP#18
- 869: Approved TSG#21. Completed 2004-12 / Text3: 42.068, 43.068, 44.068, 42.069, 43.069, 44.069, 31.102, 24.008, 48.008, 42.009, 43.020
- 870: -
- 871: - / Text3: 23.979
- 872: Updated according to SP-040232
- 873: Completed / Text3: 26.235, 26.236
- 874: SP#28 06/2005 completed / Text3: 32.272
- 875: - / Text3: 23.981
- 876: - / Text3: 23.864
- 877: No contributions assumed that no more will be done in 3GPP hence work may need to be done in 3GPP2 / Text3: 23.864
- 878: - / Text3: 23.864
- 879: -
- 880: -
- 881: -
- 882: - / Text3: 22.857
- 883: SP#27 03/2005 completed / Text3: 32.140/1, 32.171/2/5, 32.803
- 884: - / Text3: None
- 885: - / Text3: None
- 886: - / Text3: None
- 887: - / Text3: None
- 888: - / Text3: None
- 889: - / Text3: None
- 890: - / Text3: None
- 891: - / Text3: None

| ID | WBS | Task | Type | Duration | Start | Finish | Complete | Baseline start | Baseline finish | Baseline duration | Constraint | Resources | Work | Actual work | Text1 | Text4 | Text5 | Text6 | Text8 | Text12 | Text3 | Text10 |
| --- | --- | --- | --- | --- | --- | --- | --- | --- | --- | --- | --- | --- | --- | --- | --- | --- | --- | --- | --- | --- | --- | --- |
| 892 | 26 | **Flexible Layer One for GERAN** |  | 1171d | 2000-01-03 A | 2004-06-25 A | 100% | 2000-01-03 | 2004-06-25 | 1171d |  | GP | 71551h | 71551h | FLOGER | Nokia | benoist.sebire@nokia.com | Rel-6 | Paolo |  |  |  |
| 893 | 26.1 | **Realisation of a Flexible Layer One** |  | 1126d | 2000-01-03 A | 2004-04-23 A | 100% | 2000-01-03 | 2004-04-23 | 1126d |  | GP | 42816h | 42816h | FLOGER-Real | Nokia | benoist.sebire@nokia.com | Rel-6 | Paolo |  |  |  |
| 894 | 26.1.1 | Technical Report |  | 471d | 2002-04-19 A | 2004-02-06 A | 100% | 2002-04-19 | 2004-02-06 | 471d | finish no earlier than 2004-02-06 | GP | 3768h | 3768h | FLOGER-Real |  |  | Rel-6 | Paolo |  |  |  |
| 895 | 26.1.2 | Architecture in 45.001 and 43.051 |  | 526d | 2002-04-19 A | 2004-04-23 A | 100% | 2002-04-19 | 2004-04-23 | 526d | finish no earlier than 2004-04-23 | G1 | 4208h | 4208h | FLOGER-Real |  |  | Rel-6 |  |  |  |  |
| 896 | 26.1.3 | Multiplexing in 45.002 |  | 526d | 2002-04-19 A | 2004-04-23 A | 100% | 2002-04-19 | 2004-04-23 | 526d | finish no earlier than 2004-04-23 | G1 | 4208h | 4208h | FLOGER-Real |  |  | Rel-6 |  |  |  |  |
| 897 | 26.1.4 | Channel Coding in 45.003 |  | 526d | 2002-04-19 A | 2004-04-23 A | 100% | 2002-04-19 | 2004-04-23 | 526d | finish no earlier than 2004-04-23 | G1 | 4208h | 4208h | FLOGER-Real |  |  | Rel-6 |  |  |  |  |
| 898 | 26.1.5 | Performance Requirements in 45.005 |  | 1126d | 2000-01-03 A | 2004-04-23 A | 100% | 2000-01-03 | 2004-04-23 | 1126d | finish no earlier than 2004-04-23 | G1 | 9000h | 9000h | FLOGER-Real |  |  | Rel-6 |  |  |  |  |
| 899 | 26.1.6 | Radio subsystem link control in 45.008 |  | 526d | 2002-04-19 A | 2004-04-23 A | 100% | 2002-04-19 | 2004-04-23 | 526d | finish no earlier than 2004-04-23 | G1 | 4208h | 4208h | FLOGER-Real |  |  | Rel-6 |  |  |  |  |
| 900 | 26.1.7 | Requirements in 44.004 |  | 526d | 2002-04-19 A | 2004-04-23 A | 100% | 2002-04-19 | 2004-04-23 | 526d | finish no earlier than 2004-04-23 | G2 | 4208h | 4208h | FLOGER-Real |  |  | Rel-6 | Gert |  |  |  |
| 901 | 26.2 | **Signalling and protocol support for a Flexible Layer One** |  | 571d | 2002-04-19 A | 2004-06-25 A | 100% | 2002-04-19 | 2004-06-25 | 571d |  | G2 | 13704h | 13704h | FLOGER-SigPro | Nokia | benoist.sebire@nokia.com | Rel-6 | Gert |  |  |  |
| 902 | 26.2.1 | Modifications to RLC/MAC in 44.060 and 44.160 |  | 571d | 2002-04-19 A | 2004-06-25 A | 100% | 2002-04-19 | 2004-06-25 | 571d | finish no earlier than 2004-06-25 | G2 | 4568h | 4568h | FLOGER-SigPro |  |  | Rel-6 | Gert |  |  |  |
| 903 | 26.2.2 | Modifications to RRC in 44.118 and 44.018 |  | 571d | 2002-04-19 A | 2004-06-25 A | 100% | 2002-04-19 | 2004-06-25 | 571d | finish no earlier than 2004-06-25 | G2 | 4568h | 4568h | FLOGER-SigPro |  |  | Rel-6 | Gert |  |  |  |
| 904 | 26.3 | **Security for a Flexible Layer One** |  | 356d | 2002-04-19 A | 2003-08-29 A | 100% | 2002-04-19 | 2003-08-29 | 356d |  | S3, G2 | 5663.03h | 5663.03h | FLOGER-SecFLO | Nokia | benoist.sebire@nokia.com | Rel-6 | Dionisio |  |  |  |
| 905 | 26.3.1 | Ciphering in 44.160,44.118, 44.060 and 44.018 |  | 356d | 2002-04-19 A | 2003-08-29 A | 100% | 2002-04-19 | 2003-08-29 | 356d | finish no earlier than 2003-08-29 | S3, G2 | 2848h | 2848h | FLOGER-SecFLO |  |  | Rel-6 | Dionisio |  |  |  |
| 906 | 26.4 | **Deleted - GERAN MS Conformance test for the Flexible Layer One - DELETE** |  | 0d | 2004-02-06 A | 2004-02-06 A | 100% | 2004-02-06 | 2004-02-06 | 0d |  | G4,G5 |  |  | FLOGER-Msconf | Nokia | benoist.sebire@nokia.com | Rel-6 | Paolo | GP-27 |  |  |
| 907 | 26.4.1 | Deleted at TSG #27 - MS Test in 51.010 | milestone | 0d | 2004-02-06 A | 2004-02-06 A | 100% | 2004-02-06 | 2004-02-06 | 0d | finish no earlier than 2004-02-06 | G4,G5 |  |  | FLOGER-Msconf |  |  | Rel-6 | Paolo | GP-22 |  |  |
| 908 | 26.5 | **Deleted - GERAN BTS Conformance test for the Flexible Layer One - DELETE** |  | 0d | 2004-02-06 A | 2004-02-06 A | 100% | 2004-02-06 | 2004-02-06 | 0d |  | G3new |  |  | FLOGER-BTSconf | Nokia | benoist.sebire@nokia.com | Rel-6 | Ingbert | GP-27 |  |  |
| 909 | 26.5.1 | Deleted at TGS #27 - BTS Test in 51.021 - DELETE | milestone | 0d | 2004-02-06 A | 2004-02-06 A | 100% | 2004-02-06 | 2004-02-06 | 0d | finish no earlier than 2004-02-06 | G3new |  |  | FLOGER-BTSconf |  |  | Rel-6 | Ingbert | GP-22 |  |  |
| 910 | 27 | Uplink TDOA feasibility study |  | 151d | 2001-11-30 A | 2002-06-28 A | 100% | 2001-11-30 | 2002-06-28 | 151d | finish no earlier than 2002-06-28 | GP | 1208h | 1208h | TDOAF | TruePosition | Bob Gross (rlgross@trueposition.com) | Rel-6 | Paolo |  | 45.811 |  |
| 911 | 35 | **QoS Improvements** |  | 628d? | 2002-07-15 A | 2004-12-08 A | 100% | 2002-07-15 | 2004-12-08 | 628d? |  | S2,N3 | 13128h | 13128h | QoS1 | Nokia |  | Rel-6 | Maurice |  | 23.107, 23.207, 23.221 |  |
| 912 | 35.1 | FS on Dynamic Policy control enhancements for end-to-end QoS |  | 465d | 2002-07-15 A | 2004-04-23 A | 100% | 2002-07-15 | 2004-04-23 | 465d | finish no earlier than 2004-04-23 | S2 | 3720h | 3720h | QoS1 | Nortel | Claire Mousset | Rel-6 | Maurice |  | 23.917 withdrawn (Contents all in 23.207) |  |
| 913 | 343.2 | Definition of the Gq interface |  | 214d? | 2003-07-01 A | 2004-04-23 A | 100% | 2003-07-01 | 2004-04-23 | 214d? | finish no earlier than 2004-04-23 | S2 | 1712h | 1712h | QoS1 |  | Janne Rinne | Rel-6 |  |  | 23.207 |  |
| 914 | 343.3 | Gq interface specification for Dynamic Policy control enhancements – Stage 3 |  | 334d | 2003-08-29 A | 2004-12-08 A | 100% | 2003-08-29 | 2004-12-08 | 334d | finish no earlier than 2004-12-08 | N3 | 2672h | 2672h | QoS1 | Nokia | Anna.Sillanpaai@nokia.com | Rel-6 | Gwiho |  | 29.207, 29.208, 29.209 |  |
| 915 | 36 | **Subscriber certificates** |  | 728d? | 2002-02-25 A | 2004-12-08 A | 100% | 2002-02-25 | 2004-12-08 | 728d? |  | S3,S2,N1,N4,T3,OMA | 12888h | 12888h | SEC1-SC | Nokia | valtteri.niemi@nokia.com | Rel-6 | Dionisio |  |  |  |
| 916 | 36.1 | Stage 1 |  | 144d | 2002-02-25 A | 2002-09-12 A | 100% | 2002-02-25 | 2002-09-12 | 144d | finish no earlier than 2002-09-12 | S3 | 1152h | 1152h | SEC1-SC | Nokia | valtteri.niemi@nokia.com | Rel-6 | Dionisio |  | 33.220, 33.221, 33.222, 33.246 |  |
| 917 | 36.2 | Architecture review |  | 24d | 2002-10-14 A | 2002-11-14 A | 100% | 2002-10-14 | 2002-11-14 | 24d | finish no earlier than 2002-11-14 | S2 | 192h | 192h | SEC1-SC | Nokia |  | Rel-6 | Maurice |  |  |  |
| 918 | 344.3 | Stage 3 |  | 313d? | 2003-09-19 A | 2004-11-30 A | 100% | 2003-09-19 | 2004-11-30 | 313d? | finish no earlier than 2004-11-30 | N4,T3 | 2504h | 2504h | SEC1-SC | Nokia | Lauri Laitinen | Rel-6 | Kimmo |  | 23.003, 23.008, 29.109, 29.230, T3 31.102, 31.103, 31.111 |  |
| 919 | 344.4 | Stage 3 Ua & Ub interfaces |  | 288d? | 2003-11-03 A | 2004-12-08 A | 100% | 2003-11-03 | 2004-12-08 | 288d? | finish no earlier than 2004-12-08 | N1 | 2304h | 2304h | SEC1-SC | Nokia |  | Rel-6 | Frederic |  | 24.109 |  |
| 920 | 344.5 | OMA dependencies on Subscriber certificates |  | 114d? | 2004-01-01 A | 2004-06-08 A | 100% | 2004-01-01 | 2004-06-08 | 114d? | finish no earlier than 2004-06-08 | OMA | 912h | 912h | SEC1-SC | Nokia | OMA-LIAISON@mail.openmobilealliance.org | Rel-6 |  |  |  | SP-24 |

Notes:
- 892: -
- 893: -
- 894: -
- 895: -
- 896: -
- 897: -
- 898: -
- 899: -
- 900: -
- 901: -
- 902: -
- 903: -
- 904: -
- 905: -
- 906: -
- 907: -
- 908: -
- 909: -
- 910: -
- 911: -
- 912: -
- 913: -
- 914: [DAB - 25.05.04] - Delayed to Sept - possibly Dec 2004
- 915: Approved at SP#14. May require BBs from CN1, CN4, SA5 and T3
- 916: Contribution received S3#24, S3#25
- 917: -
- 918: Finished in CN4#26
- 919: -
- 920: Updated according to SP-040420

| ID | WBS | Task | Duration | Start | Finish | Complete | Baseline start | Baseline finish | Baseline duration | Constraint | Resources | Work | Actual work | Text1 | Text4 | Text5 | Text6 | Text8 | Text12 | Text3 |
| --- | --- | --- | --- | --- | --- | --- | --- | --- | --- | --- | --- | --- | --- | --- | --- | --- | --- | --- | --- | --- |
| 921 | 39 | **Addition of frequency bands to GSM (TAPS)** | 676d | 2002-06-28 A | 2005-01-28 A | 100% | 2002-06-28 | 2005-01-28 | 676d |  | GP | 16640h | 16640h | TAPS | Nokia | Torben Themsen | Rel-6 | Paolo |  |  |
| 922 | 39.1 | **Addition of frequency bands to GSM – Changes to core specs** | 26d | 2002-11-15 A | 2002-12-20 A | 100% | 2002-11-15 | 2002-12-20 | 26d |  | G1 | 416h | 416h | TAPS-Specs | Nokia | Torben Themsen | Rel-6 | Paolo |  |  |
| 923 | 39.1.1 | Changes to core specs | 26d | 2002-11-15 A | 2002-12-20 A | 100% | 2002-11-15 | 2002-12-20 | 26d | finish no earlier than 2002-12-20 | G1 | 208h | 208h | TAPS-Specs | Nokia | Torben Themsen | Rel-6 | Paolo |  |  |
| 924 | 39.2 | **Deleted - Addition of frequency bands to GSM – Changes for conformance tests** | 676d | 2002-06-28 A | 2005-01-28 A | 100% | 2002-06-28 | 2005-01-28 | 676d |  | G4 | 10816h | 10816h | TAPS-Conf | Nokia | Torben Themsen | Rel-6 | Paolo | GP-23 |  |
| 925 | 39.2.1 | Deleted - 51.010-1 Add testing | 676d | 2002-06-28 A | 2005-01-28 A | 100% | 2002-06-28 | 2005-01-28 | 676d | finish no earlier than 2005-01-28 | G4 | 5408h | 5408h | TAPS-Conf | Nokia | Torben Themsen | Rel-6 | Paolo | GP-23 |  |
| 926 | 40 | **Seamless support of streaming services in A/Gb mode** | 1426d? | 2000-01-03 A | 2005-06-17 A | 100% | 2000-01-03 | 2005-06-17 | 1426d? |  | GP | 53096h | 53096h | SSStrea | Vodafone | José Luis Carrizo Martínez | Rel-6 | Paolo |  |  |
| 927 | 40.1 | **Identification of requirements for streaming** | 46d? | 2003-06-27 A | 2003-08-29 A | 100% | 2003-06-27 | 2003-08-29 | 46d? |  | G1 | 736h | 736h | SSStrea | Vodafone | José Luis Carrizo Martínez | Rel-6 | Paolo |  |  |
| 928 | 346.1.1 | Requirements | 46d? | 2003-06-27 A | 2003-08-29 A | 100% | 2003-06-27 | 2003-08-29 | 46d? | finish no earlier than 2003-08-29 | G1 | 368h | 368h | SSStrea | Vodafone | José Luis Carrizo Martínez | Rel-6 | Paolo |  |  |
| 929 | 40.2 | **Performance study of cell change mechanisms** | 956d? | 2000-01-03 A | 2003-08-29 A | 100% | 2000-01-03 | 2003-08-29 | 956d? |  | G1 | 30568h | 30568h | SSStrea | Vodafone | José Luis Carrizo Martínez | Rel-6 | Paolo |  |  |
| 930 | 346.2.1 | Performance of NACC | 956d? | 2000-01-03 A | 2003-08-29 A | 100% | 2000-01-03 | 2003-08-29 | 956d? | finish no earlier than 2003-08-29 | G1 | 7640h | 7640h | SSStrea | Vodafone | José Luis Carrizo Martínez | Rel-6 | Paolo |  |  |
| 931 | 346.2.2 | Performance of cell change in DTM for the PS domain | 956d? | 2000-01-03 A | 2003-08-29 A | 100% | 2000-01-03 | 2003-08-29 | 956d? | finish no earlier than 2003-08-29 | G1 | 7640h | 7640h | SSStrea | Vodafone | José Luis Carrizo Martínez | Rel-6 | Paolo |  |  |
| 932 | 346.2.3 | Handover | 956d? | 2000-01-03 A | 2003-08-29 A | 100% | 2000-01-03 | 2003-08-29 | 956d? | finish no earlier than 2003-08-29 | G1 | 7640h | 7640h | SSStrea | Vodafone | José Luis Carrizo Martínez | Rel-6 | Paolo |  |  |
| 933 | 40.3 | **Reduction of service interruption times and packet loss during mobility procedures** | 516d? | 2003-06-27 A | 2005-06-17 A | 100% | 2003-06-27 | 2005-06-17 | 516d? |  | G2 | 10800h | 10800h | SSStrea | Vodafone | José Luis Carrizo Martínez | Rel-6 | Gert |  |  |
| 934 | 346.3.1 | optimizations of existing mechanisms/procedures | 106d? | 2003-06-27 A | 2003-11-21 A | 100% | 2003-06-27 | 2003-11-21 | 106d? | finish no earlier than 2003-11-21 | G2 | 848h | 848h | SSStrea | Vodafone | José Luis Carrizo Martínez | Rel-6 | Gert |  |  |
| 935 | 346.3.2 | Inter-system NACC | 106d? | 2003-06-27 A | 2003-11-21 A | 100% | 2003-06-27 | 2003-11-21 | 106d? | finish no earlier than 2003-11-21 | G2 | 848h | 848h | SSStrea | Vodafone | José Luis Carrizo Martínez | Rel-6 | Gert |  |  |
| 936 | 346.3.3 | PS Handover (within GERAN and between GERAN and UTRAN) | 516d? | 2003-06-27 A | 2005-06-17 A | 100% | 2003-06-27 | 2005-06-17 | 516d? | finish no earlier than 2003-11-21 | G2 | 4128h | 4128h | SSStrea | Vodafone | José Luis Carrizo Martínez | Rel-6 | Gert |  |  |
| 937 | 346.3.4 | Dependency to other features | 106d? | 2003-06-27 A | 2003-11-21 A | 100% | 2003-06-27 | 2003-11-21 | 106d? | finish no earlier than 2003-11-21 | G2 | 848h | 848h | SSStrea | Vodafone | José Luis Carrizo Martínez | Rel-6 | Gert |  |  |
| 938 | 40.5 | **Deleted - MS conformance testing** | 31d? | 2003-12-19 A | 2004-01-30 A | 100% | 2003-12-19 | 2004-01-30 | 31d? |  | G3new | 248h | 248h | SSStrea | Vodafone | José Luis Carrizo Martínez | Rel-6 | Ingbert | GP-27 |  |
| 939 | 346.4.1 | Deleted - MS conformance tests | 31d? | 2003-12-19 A | 2004-01-30 A | 100% | 2003-12-19 | 2004-01-30 | 31d? | finish no earlier than 2004-01-30 | G4,G5 | 248h | 248h | SSStrea | Vodafone | José Luis Carrizo Martínez | Rel-6 | Ingbert | GP-27 |  |
| 940 | 346.5 | GERAN A/Gb mode security enhancements | 612d? | 2002-09-26 A | 2005-01-28 A | 100% | 2002-09-26 | 2005-01-28 | 612d? | finish no earlier than 2005-01-28 | S3 | 4896h | 4896h | SSStrea | Vodafone | peter.howard@vodafone.com | Rel-6 | Dionisio |  | 33.102 |
| 941 | 41 | Performance characterisation of default codecs for PS conversational multimedia application | 455d | 2002-09-13 A | 2004-06-10 A | 100% | 2002-09-13 | 2004-06-10 | 455d | finish no earlier than 2004-06-10 | S4 | 3640h | 3640h | CODCAR | Nokia | pasi.s.ojala@nokia.com | Rel-6 | Paolo |  | 26.935 |
| 942 | 44 | **OAM&P Rel-6** | 652d? | 2002-09-12 A | 2005-03-11 A | 100% | 2002-09-12 | 2005-03-11 | 652d? |  | S5 | 30819.5h | 30819.5h | OAM | Motorola |  | Rel-6 | Dionisio |  |  |
| 943 | 44.1 | Principles, high level Requirements and Architecture | 526d | 2002-09-12 A | 2004-09-16 A | 100% | 2002-09-12 | 2004-09-16 | 526d | finish no earlier than 2004-09-16 | S5 | 4208h | 4208h | OAM-AR | Motorola |  | Rel-6 | Dionisio |  | 32.101, 32.102 |
| 944 | 44.2 | Performance Management | 591d | 2002-09-12 A | 2004-12-16 A | 100% | 2002-09-12 | 2004-12-16 | 591d | finish no earlier than 2004-12-16 | S5 | 4728h | 4728h | OAM-PM | Nortel |  | Rel-6 | Dionisio |  | 32.401/3, 52.402, 32.411/2/3, 32.432/5/6 |
| 945 | 44.4 | Network Infrastructure Management | 591d | 2002-09-12 A | 2004-12-16 A | 100% | 2002-09-12 | 2004-12-16 | 591d | finish no earlier than 2004-12-16 | S5 | 4728h | 4728h | OAM-NIM | Ericsson | thomas.tovinger@ericsson.com | Rel-6 | Dionisio |  | 32.15x, 32.3/6/7xy |

Notes:
- 921: -
- 922: -
- 923: -
- 924: -
- 925: -
- 926: -
- 927: -
- 928: -
- 929: -
- 930: -
- 931: -
- 932: -
- 933: Completed at GERP#17
- 934: -
- 935: -
- 936: -
- 937: -
- 938: Marked as stopped 10/2009
- 939: Marked as stopped 10/2009
- 940: Possible changes to 33.102 or new specification needed
- 941: -
- 942: SP#26: Updated WID SP-040766 was SP-020445. Completion delayed 12/04->03/05 due to OAM-Trace in CN1/4.
- 943: SP#25 09/2004 completed
- 944: SP#26 12/2004 completed
- 945: SP#26 12/2004 completed

| ID | WBS | Task | Duration | Start | Finish | Complete | Baseline start | Baseline finish | Baseline duration | Constraint | Resources | Work | Actual work | Text1 | Text3 | Text4 | Text5 | Text6 | Text8 | Text10 | Text12 |
| --- | --- | --- | --- | --- | --- | --- | --- | --- | --- | --- | --- | --- | --- | --- | --- | --- | --- | --- | --- | --- | --- |
| 946 | 44.5 | **Trace Management Rel-6** | 646d? | 2002-09-20 A | 2005-03-11 A | 100% | 2002-09-20 | 2005-03-11 | 646d? |  | S5 | 12061.9h | 12061.9h | OAM-Trace | 32.42x, 52.008 | Nokia | kari.t.ronka@nokia.com | Rel-6 | Dionisio |  |  |
| 947 | 348.4.1 | Subscriber and UE trace management | 585d | 2002-09-20 A | 2004-12-16 A | 100% | 2002-09-20 | 2004-12-16 | 585d | finish no earlier than 2004-12-16 | S5 | 4680h | 4680h | OAM-Trace | 32.421/2/3, 52.008 | Nokia | kari.t.ronka@nokia.com | Rel-6 | Dionisio |  |  |
| 948 | 348.4.2 | Subscriber and equipment trace in UTRAN | 268d? | 2003-06-06 A | 2004-06-15 A | 100% | 2003-06-06 | 2004-06-15 | 268d? | finish no earlier than 2004-06-15 | R3 | 2144h | 2144h | OAM-Trace-RAN | 25.413, 25.420, 25.423 | Nortel | Yann Sehedi (sehedic@nortelnetworks.com) | Rel-6 | Juha |  |  |
| 949 | 348.4.3 | Trace Management, Stage3 | 193.74d? | 2004-06-09 A | 2005-03-11 A | 100% | 2004-06-09 | 2005-03-11 | 193.74d? | finish no earlier than 2005-03-11 | N4 | 1549.92h | 1549.92h | OAM-Trace | 23.205, 29.232, 29.060, 29.002, 29.228 | Nokia | seppo.kauntola@nokia.com | Rel-6 | Kimmo |  |  |
| 950 | 349 | **Charging Management** | 666d? | 2002-11-21 A | 2005-06-09 A | 100% | 2002-11-21 | 2005-06-09 | 666d? |  | S5 | 55320h | 55320h | CH | 32.2xy | T-Mobile | karl-heinz.nenner@t-mobile.de | Rel-6 | Dionisio |  |  |
| 951 | 349.1 | Charging architecture and principles | 390d? | 2003-03-21 A | 2004-09-16 A | 100% | 2003-03-21 | 2004-09-16 | 390d? | start no earlier than 2003-03-21 | S5 | 3120h | 3120h | CH | 32.240 |  |  | Rel-6 | Dionisio |  |  |
| 952 | 349.2 | Charging Data Record (CDR) file format and transfer | 260d? | 2003-03-21 A | 2004-03-18 A | 100% | 2003-03-21 | 2004-03-18 | 260d? | start no earlier than 2003-03-21 | S5 | 2080h | 2080h | CH | 32.297 |  |  | Rel-6 | Dionisio |  |  |
| 953 | 349.3 | CDR parameter description | 580d? | 2003-03-21 A | 2005-06-09 A | 100% | 2003-03-21 | 2005-06-09 | 580d? | finish no earlier than 2005-06-09 | S5 | 4640h | 4640h | CH | 32.298 |  |  | Rel-6 | Dionisio |  |  |
| 954 | 349.4 | Diameter charging applications | 390d? | 2003-03-21 A | 2004-09-16 A | 100% | 2003-03-21 | 2004-09-16 | 390d? | start no earlier than 2003-03-21 | S5 | 3120h | 3120h | CH | 32.299 |  |  | Rel-6 | Dionisio |  |  |
| 955 | 349.5 | Online Charging System (OCS) architecture study | 130d? | 2003-03-21 A | 2003-09-18 A | 100% | 2003-03-21 | 2003-09-18 | 130d? | start no earlier than 2003-03-21 | S5 | 1040h | 1040h | CH | 32.815 |  |  | Rel-6 | Dionisio |  |  |
| 956 | 349.6 | OCS: Applications and interfaces | 455d? | 2003-03-21 A | 2004-12-16 A | 100% | 2003-03-21 | 2004-12-16 | 455d? | start no earlier than 2003-03-21 | S5 | 3640h | 3640h | CH | 32.296 |  |  | Rel-6 | Dionisio |  |  |
| 957 | 349.7 | **Charging Management for Bearer level** | 390d? | 2003-03-21 A | 2004-09-16 A | 100% | 2003-03-21 | 2004-09-16 | 390d? |  | S5 | 11440h | 11440h | CH-BC |  | Nokia | Benni ALEXANDER | Rel-6 | Dionisio |  |  |
| 958 | 349.7.1 | CS domain charging | 260d? | 2003-03-21 A | 2004-03-18 A | 100% | 2003-03-21 | 2004-03-18 | 260d? | start no earlier than 2003-03-21 | S5 | 2080h | 2080h | CH | 32.250 |  |  | Rel-6 | Dionisio |  |  |
| 959 | 349.7.2 | PS domain charging | 390d? | 2003-03-21 A | 2004-09-16 A | 100% | 2003-03-21 | 2004-09-16 | 390d? | start no earlier than 2003-03-21 | S5 | 3120h | 3120h | CH | 32.251 |  |  | Rel-6 | Dionisio |  |  |
| 960 | 349.7.3 | CDR transfer | 390d? | 2003-03-21 A | 2004-09-16 A | 100% | 2003-03-21 | 2004-09-16 | 390d? | start no earlier than 2003-03-21 | S5 | 3120h | 3120h | CH | 32.295 |  |  | Rel-6 | Dionisio |  |  |
| 961 | 349.8 | Charging Management for the IMS | 455d? | 2003-03-21 A | 2004-12-16 A | 100% | 2003-03-21 | 2004-12-16 | 455d? | finish no earlier than 2004-12-16 | S5 | 3640h | 3640h | IMS2-CH | 32.260 | Ericsson | Patrik TEPPO | Rel-6 | Dionisio |  |  |
| 962 | 349.9 | Charging Management for the Service domain | 580d? | 2003-03-21 A | 2005-06-09 A | 100% | 2003-03-21 | 2005-06-09 | 580d? | finish no earlier than 2005-06-09 | S5 | 4640h | 4640h | CH | 32.252, 32.270, 32.271, 32.272 | Siemens | Gerald GÖRMER | Rel-6 | Dionisio |  |  |
| 963 | 349.10 | **Overall architectural aspects of IP flow based bearer level charging** | 602d? | 2002-11-21 A | 2005-03-11 A | 100% | 2002-11-21 | 2005-03-11 | 602d? |  | S2 | 12632h | 12632h | CH-FBC | 23.125 |  |  | Rel-6 | Maurice |  |  |
| 964 | 349.10.1 | Overall definition of FBC architecture | 334d? | 2002-11-21 A | 2004-03-02 A | 100% | 2002-11-21 | 2004-03-02 | 334d? | start no earlier than 2002-11-21 | S2 | 2672h | 2672h | CH-FBC |  |  |  | Rel-6 | Maurice | SP-24 |  |
| 965 | 349.10.2 | Study on providing policy control with FBC | 130d? | 2004-02-02 A | 2004-07-30 A | 100% | 2004-02-02 | 2004-07-30 | 130d? | start no earlier than 2004-02-01 | S2 | 1040h | 1040h | CH-FBC |  |  |  | Rel-6 | Maurice | SP-24 |  |
| 966 | 349.10.3 | Gx interface for flow based charging | 223d? | 2004-02-02 A | 2004-12-08 A | 100% | 2004-02-02 | 2004-12-08 | 223d? | start no earlier than 2004-02-01 | N3 | 1784h | 1784h | CH-FBC | 29.210 | Nokia | juha.a.rasanen@nokia.com | Rel-6 | Gwiho | SP-25 |  |
| 967 | 349.10.4 | Rx interface for flow based charging | 290d? | 2004-02-02 A | 2005-03-11 A | 100% | 2004-02-02 | 2005-03-11 | 290d? | finish no earlier than 2005-03-11 | N3 | 2320h | 2320h | CH-FBC | 29.209 | Nortel | Javier Gonzalez Gallego | Rel-6 | Gwiho | SP-25 |  |
| 968 | 13 | **Rel-6 UICC/USIM enhancements and interworking** | 1164d? | 2000-09-25 A | 2005-03-10 A | 100% | 2000-09-25 | 2005-03-10 | 1164d? |  | T3 | 43088h | 43088h | USAT1 |  |  |  | Rel-6 | Xavier |  |  |
| 969 | 13.1 | **UICC API** | 777d | 2002-03-20 A | 2005-03-10 A | 100% | 2002-03-20 | 2005-03-10 | 777d |  | T3 | 15024h | 15024h | USAT1-API |  |  |  | Rel-6 | Xavier |  |  |
| 970 | 13.1.1 | Java API Test specification | 59d | 2002-03-20 A | 2002-06-10 A | 100% | 2002-03-20 | 2002-06-10 | 59d | finish no earlier than 2002-09-20 | T3 | 472h | 472h | USAT1-API |  | Microelectrónica Española | Mario Pérez | Rel-6 | Xavier |  |  |
| 971 | 350.1.2 | 2G/3G Java Card™ API based applet interworking | 255d | 2003-03-17 A | 2004-03-05 A | 100% | 2003-03-17 | 2004-03-05 | 255d | finish no earlier than 2004-02-19 | T3 | 2040h | 2040h | USAT1-API |  | Oberthur Card Systems | Stéphane Andrau | Rel-6 | Xavier |  |  |
| 972 | 350.1.3 | (U)SIM API for Java Card Testing | 519d | 2003-03-17 A | 2005-03-10 A | 100% | 2003-03-17 | 2005-03-10 | 519d | finish no earlier than 2005-03-10 | T3 | 4152h | 4152h | USAT1-API | 31.213 | Axalto | Christophe Begassat (cbegassat@axalto.com) | Rel-6 | Xavier |  |  |
| 973 | 13.1.2 | Deleted - Java API Test specification (TS 43.019 Rel-5) | 268d | 2002-05-30 A | 2003-06-09 A | 100% | 2002-05-30 | 2003-06-09 | 268d | finish no earlier than 2003-09-17 | T3 | 2144h | 2144h | USAT1-API |  | Microelectrónica Española | Mario Pérez | Rel-6 | Xavier |  | TP-20 |

Notes:
- 946: SP#26 12/2004 SA5 completed 12/04. Signalling Based Trace Activation for IMS (SIP) moved to Rel-7. Reason: CN1 cannot complete 24.229 trace without IETF dependency => estimate 05/2005.
- 947: SP#26 12/2004 completed
- 948: -
- 949: -
- 950: SP#28 Target 09/2005 for WLAN Charging 32.252
- 951: SP#25 09/2004 completed
- 952: SP#23 03/2004 completed
- 953: SP#28 06/2005 completed
- 954: SP#25 09/2004 completed
- 955: SP#21 09/2003 completed
- 956: SP#26 12/2004 completed
- 957: SP#28 Target 09/2005 for WLAN Charging 32.252
- 958: SP#23 03/2004 completed
- 959: SP#25 09/2004 completed
- 960: SP#25 09/2004 completed
- 961: SP#26 12/2004 completed
- 962: SP#26: Updated WID SP-040778 was SP-030050. Target completion 06/2005. Consisting of MMS-CH, LCS-CH, WLAN-CH, POC-CH, MBMS-CH
- 963: -
- 964: -
- 965: -
- 966: -
- 967: -
- 968: -
- 969: 8/3/2001: test spec is based on R99 core spec, so deleted from Workplan
- 970: -
- 971: -
- 972: -
- 973: MOVED to Rel-5 WP

| ID | WBS | Task | Type | Duration | Start | Finish | Complete | Baseline start | Baseline finish | Baseline duration | Constraint | Resources | Work | Actual work | Text1 | Text4 | Text5 | Text6 | Text8 | Text3 | Text12 |
| --- | --- | --- | --- | --- | --- | --- | --- | --- | --- | --- | --- | --- | --- | --- | --- | --- | --- | --- | --- | --- | --- |
| 974 | 350.2 | **Rel-6 USIM toolkit enhancements** |  | 1160d? | 2000-09-25 A | 2005-03-04 A | 100% | 2000-09-25 | 2005-03-04 | 1160d? |  | T3 | 21848h | 21848h | USAT1-API-MULTOS | Aspects Software | Neil Livingston | Rel-6 | Xavier |  |  |
| 975 | 350.2.1 | **C SIM API** |  | 525d | 2000-09-25 A | 2002-09-27 A | 100% | 2000-09-25 | 2002-09-27 | 525d |  | T3 | 9960h | 9960h | USAT1-API-MULTOS | Aspects Software | Neil Livingston | Rel-6 | Xavier | 31.101, 31.102, 31.103, 31.111, 31.113, new 31.115, 31.116 |  |
| 976 | 350.2.1.1 | Specification |  | 525d | 2000-09-25 A | 2002-09-27 A | 100% | 2000-09-25 | 2002-09-27 | 525d | finish no earlier than 2002-09-27 | T3 | 4200h | 4200h | USAT1-API-MULTOS | Aspects Software | Neil Livingston | Rel-6 | Xavier |  |  |
| 977 | 350.2.1.2 | Test specification |  | 195d | 2001-01-01 A | 2001-09-28 A | 100% | 2001-01-01 | 2001-09-28 | 195d | finish no earlier than 2001-09-28 | T3 | 1560h | 1560h | USAT1-API-MULTOS | Aspects Software | Neil Livingston | Rel-6 | Xavier |  |  |
| 978 | 350.2.2 | USIM application toolkit Conformance Test Specification for Mobile Equipments |  | 326d? | 2003-12-05 A | 2005-03-04 A | 100% | 2003-12-05 | 2005-03-04 | 326d? | start no earlier than 2003-12-05 | T3 | 2608h | 2608h | USAT1-API-MULTOS | Gemplus | Eric.laffont@gemplus.com | Rel-6 | Xavier | 31.124 |  |
| 979 | 351 | AMR-WB extension for high audio quality |  | 779d | 2002-12-13 A | 2005-12-07 A | 100% | 2002-12-13 | 2005-12-07 | 779d | finish no earlier than 2005-12-07 | S4 | 6232h | 6232h | AMRWB+ | Nokia | janne.m.vainio@nokia.com | Rel-6 | Paolo | 26.290, 26.304, 26.273, 26.274, 26.412, 26.936 |  |
| 980 | 352 | Codec Enhancements for Packet Switched Conversational Multimedia Applications |  | 198d? | 2004-03-16 A | 2004-12-16 A | 100% | 2004-03-16 | 2004-12-16 | 198d? | finish no earlier than 2004-12-16 | S4 | 1584h | 1584h | CEPSCM | Nokia | miska.hannuksela@nokia.com | Rel-6 | Paolo | 26.235, 26.236 |  |
| 981 | 353 | 3G-324M Improvements |  | 198d? | 2004-03-16 A | 2004-12-16 A | 100% | 2004-03-16 | 2004-12-16 | 198d? | finish no earlier than 2004-12-16 | S4 | 1584h | 1584h | 3G-324MI | Ericsson | bo.burman@ericsson.com | Rel-6 | Paolo | 26.111, 26.911 |  |
| 982 | 354 | Single Antenna Receiver Interference Cancellation (SAIC) |  | 420.92d? | 2002-11-15 A | 2004-06-25 A | 100% | 2002-11-15 | 2004-06-25 | 420.92d? | finish no earlier than 2004-08-27 | GP,G1 | 3367.36h | 3367.36h | SAIC | Cingular | Marc Grant | Rel-6 | Paolo | 45.903 |  |
| 983 | 355 | Study on Bandwidth and resource savings in CS networks |  | 273d? | 2003-06-01 A | 2004-06-16 A | 100% | 2003-06-01 | 2004-06-16 | 273d? | finish no earlier than 2004-06-16 | S2 | 2184h | 2184h | BARS |  |  | Rel-6 | Maurice | 23.977 |  |
| 984 | 356 | FS on (U)SIM Security Reuse by Peripheral Devices on Local Interfaces |  | 127d? | 2003-07-03 A | 2003-12-26 A | 100% | 2003-07-03 | 2003-12-26 | 127d? | finish no earlier than 2003-12-26 | S3 | 1016h | 1016h |  | Toshiba | Raziq Yaqub (ryaqub@tari.toshiba.com) | Rel-6 | Dionisio | 33.817 |  |
| 985 | 357 | **Multiple TBF in A/Gb mode** |  | 736d? | 2002-04-05 A | 2005-01-28 A | 100% | 2002-04-05 | 2005-01-28 | 736d? |  | GP,G2 | 17600h | 17600h | MULTBF | Ericsson | gunnar.mildh@era.ericsson.se | Rel-6 | Paolo |  |  |
| 986 | 357.1 | **Multiple TBF in A/Gb mode** |  | 366d? | 2002-04-05 A | 2003-08-29 A | 100% | 2002-04-05 | 2003-08-29 | 366d? |  | GP,G2 | 11712h | 11712h | MULTBF-Agbmode | Ericsson | gunnar.mildh@era.ericsson.se | Rel-6 | Paolo |  |  |
| 987 | 357.1.1 | Multiple TBF Concept paper |  | 366d? | 2002-04-05 A | 2003-08-29 A | 100% | 2002-04-05 | 2003-08-29 | 366d? | finish no earlier than 2003-08-29 | GP,G2 | 2928h | 2928h | MULTBF-Agbmode |  |  | Rel-6 | Paolo |  |  |
| 988 | 357.1.2 | Multiple TBF Stage 2 (43.064) CRs |  | 366d? | 2002-04-05 A | 2003-08-29 A | 100% | 2002-04-05 | 2003-08-29 | 366d? | finish no earlier than 2003-08-29 | GP,G2 | 2928h | 2928h | MULTBF-Agbmode |  |  | Rel-6 | Paolo |  |  |
| 989 | 357.1.3 | Multiple TBF Stage 3 (44.060) CRs |  | 366d? | 2002-04-05 A | 2003-08-29 A | 100% | 2002-04-05 | 2003-08-29 | 366d? | finish no earlier than 2003-08-29 | GP,G2 | 2928h | 2928h | MULTBF-Agbmode |  |  | Rel-6 | Paolo |  |  |
| 990 | 357.2 | Deleted - Multiple TBF in A/Gb mode – MS testing | milestone | 0d? | 2005-01-28 A | 2005-01-28 A | 100% | 2005-01-28 | 2005-01-28 | 0d? | start no earlier than 2005-01-28 | G3new |  |  | MULTBF-Testing | Ericsson | gunnar.mildh@era.ericsson.se | Rel-6 | Paolo |  | GP-27 |
| 991 | 358 | **Alignment between the test-regimes for GERAN capable MS** |  | 526d? | 2003-08-29 A | 2005-09-02 A | 100% | 2003-08-29 | 2005-09-02 | 526d? |  | G3new | 4208h | 4208h | ALTERE | Ericsson | Toubassi | Rel-6 | Ingbert |  |  |
| 992 | 358.1 | Determine the controversial test cases in the different test regimes and align them with 3GPP GERAN test specifications. Such test cases to be added to TS 51.010. |  | 526d? | 2003-08-29 A | 2005-09-02 A | 100% | 2003-08-29 | 2005-09-02 | 526d? | finish no earlier than 2005-09-02 | G3new | 4208h | 4208h | ALTERE-TC |  |  | Rel-6 | Ingbert |  |  |
| 993 | 359 | Addition of U-TDOA in the CS domain |  | 111d? | 2003-11-21 A | 2004-04-23 A | 100% | 2003-11-21 | 2004-04-23 | 111d? | finish no earlier than 2004-04-23 | GP | 888h | 888h | UTDOACS | TruePosition | Bob Gross, Rhys Robinson (rlgross@trueposition.com) | Rel-6 | Paolo |  |  |
| 994 | 360 | Addition of U-TDOA in the PS domain |  | 361d? | 2003-06-27 A | 2004-11-12 A | 100% | 2003-06-27 | 2004-11-12 | 361d? | finish no earlier than 2004-11-12 | GP | 2888h | 2888h | UTDOAPS | TruePosition | Bob Gross, Rhys Robinson (rlgross@trueposition.com) | Rel-6 | Paolo |  |  |
| 995 | 361 | **Downlink Advanced Receiver Performance** |  | 466d? | 2003-11-21 A | 2005-09-02 A | 100% | 2003-11-21 | 2005-09-02 | 466d? |  | GP | 19160h | 19160h | DARP | Nokia | tommy.bysted@nokia.com | Rel-6 | Paolo |  |  |
| 996 | 361.1 | DARP test scenarios |  | 201d? | 2003-11-21 A | 2004-08-27 A | 100% | 2003-11-21 | 2004-08-27 | 201d? | finish no earlier than 2004-08-27 | GP | 1608h | 1608h | DARP-TS | Nokia | tommy.bysted@nokia.com | Rel-6 | Paolo |  |  |
| 997 | 361.2 | **DARP for GMSK modulated voice services** |  | 201d? | 2004-02-06 A | 2004-11-12 A | 100% | 2004-02-06 | 2004-11-12 | 201d? |  | GP | 4824h | 4824h | DARP-GMSK | Nokia | tommy.bysted@nokia.com | Rel-6 | Paolo |  |  |
| 998 | 361.2.1 | Performance requirements in 45.005 |  | 201d? | 2004-02-06 A | 2004-11-12 A | 100% | 2004-02-06 | 2004-11-12 | 201d? | finish no earlier than 2004-11-12 | GP | 1608h | 1608h | DARP-GMSK-Perf |  |  | Rel-6 | Paolo |  |  |
| 999 | 361.2.2 | Radio subsystem link control in 45.008 |  | 201d? | 2004-02-06 A | 2004-11-12 A | 100% | 2004-02-06 | 2004-11-12 | 201d? | finish no earlier than 2004-11-12 | GP | 1608h | 1608h | DARP-GMSK-LC |  |  | Rel-6 | Paolo |  |  |

Notes:
- 974: -
- 975: -
- 976: -
- 977: -
- 978: -
- 979: TR tbc by Sept. 05
- 980: -
- 981: -
- 982: -
- 983: -
- 984: Approved TSG#20
- 985: GP#17 Nov 2003 Moved from Rel-5 UID_50058 MULTBF (Only Multiple TBF Concept paper produced in Rel-5)
- 986: -
- 987: -
- 988: -
- 989: -
- 990: -
- 991: -
- 992: -
- 993: Completed, except for potential LMU performance specs
- 994: -
- 995: -
- 996: -
- 997: -
- 998: -
- 999: -

| ID | WBS | Task | Type | Duration | Start | Finish | Complete | Baseline start | Baseline finish | Baseline duration | Constraint | Resources | Work | Actual work | Text1 | Text4 | Text5 | Text6 | Text8 | Text12 | Text3 |
| --- | --- | --- | --- | --- | --- | --- | --- | --- | --- | --- | --- | --- | --- | --- | --- | --- | --- | --- | --- | --- | --- |
| 1000 | 361.3 | **DARP for GPRS and EGPRS MCS1-MCS4** |  | 201d? | 2004-02-06 A | 2004-11-12 A | 100% | 2004-02-06 | 2004-11-12 | 201d? |  | GP | 4824h | 4824h | DARP-GPRSE | Nokia | tommy.bysted@nokia.com | Rel-6 | Paolo |  |  |
| 1001 | 361.3.1 | Performance requirements in 45.005 |  | 201d? | 2004-02-06 A | 2004-11-12 A | 100% | 2004-02-06 | 2004-11-12 | 201d? | finish no earlier than 2004-11-12 | GP | 1608h | 1608h | DARP-GPRSE-Perf |  |  | Rel-6 | Paolo |  |  |
| 1002 | 361.3.2 | Radio subsystem link control in 45.008 |  | 201d? | 2004-02-06 A | 2004-11-12 A | 100% | 2004-02-06 | 2004-11-12 | 201d? | finish no earlier than 2004-11-12 | GP | 1608h | 1608h | DARP-GPRSE-LC |  |  | Rel-6 | Paolo |  |  |
| 1003 | 361.4 | DARP Capability signalling |  | 256d? | 2003-11-21 A | 2004-11-12 A | 100% | 2003-11-21 | 2004-11-12 | 256d? | finish no earlier than 2004-11-12 | GP | 2048h | 2048h | DARP-CAPSIG | Nokia | tommy.bysted@nokia.com | Rel-6 | Paolo |  |  |
| 1004 | 361.5 | GERAN MS Conformance test for DARP |  | 266d? | 2004-08-27 A | 2005-09-02 A | 100% | 2004-08-27 | 2005-09-02 | 266d? | finish no earlier than 2005-06-24 | G3new | 2128h | 2128h | ARP-ConfTest | Nokia | tommy.bysted@nokia.com | Rel-6 | Ingbert |  |  |
| 1005 | 362 | **Reduction of PS service interruption in Dual Transfer Mode** |  | 416d? | 2003-11-21 A | 2005-06-24 A | 100% | 2003-11-21 | 2005-06-24 | 416d? |  | G2 | 8360h | 8360h | PSintDTM | Siemens | toby.proctor@roke.co.uk | Rel-6 | Gert |  |  |
| 1006 | 362.1 | Use case and requirement definition |  | 111d? | 2003-11-21 A | 2004-04-23 A | 100% | 2003-11-21 | 2004-04-23 | 111d? | finish no earlier than 2004-04-23 | G2 | 888h | 888h | PSintDTM-Req | Siemens | toby.proctor@roke.co.uk | Rel-6 | Gert |  |  |
| 1007 | 362.2 | Performance Study of Current Procedures |  | 111d? | 2003-11-21 A | 2004-04-23 A | 100% | 2003-11-21 | 2004-04-23 | 111d? | start no earlier than 2003-11-21 | G2 | 888h | 888h | PSintDTM-Perf | Siemens | toby.proctor@roke.co.uk | Rel-6 | Gert |  |  |
| 1008 | 362.3 | Reduction of service interruption times and packet loss during Dual Transfer Mode and mobility procedures |  | 146d? | 2004-04-23 A | 2004-11-12 A | 100% | 2004-04-23 | 2004-11-12 | 146d? | finish no earlier than 2004-11-12 | G2 | 1168h | 1168h | PSintDTM-Reduct | Siemens | toby.proctor@roke.co.uk | Rel-6 | Gert |  |  |
| 1009 | 362.4 | Deleted - MS Conformance testing - Reduction of PS service interruption in DTM |  | 261d? | 2004-06-25 A | 2005-06-24 A | 100% | 2004-06-25 | 2005-06-24 | 261d? | finish no earlier than 2005-06-24 | G3new | 2088h | 2088h | PSintDTM-ConfMS |  |  | Rel-6 | Ingbert | GP-25 |  |
| 1010 | 362.5 | Deleted - BTS Conformance testing - Reduction of PS service interruption in DTM | milestone | 0d? | 2005-06-24 A | 2005-06-24 A | 100% | 2005-06-24 | 2005-06-24 | 0d? | finish no earlier than 2005-06-24 | G3new |  |  | PSintDTM-ConfBTS |  |  | Rel-6 | Ingbert | GP-25 |  |
| 1011 | 363 | Network Domain Security; MAP application layer security (NDS/MAPsec) |  | 127d? | 2004-07-06 A | 2004-12-29 A | 100% | 2004-07-06 | 2004-12-29 | 127d? | finish no earlier than 2003-12-26 | S3 | 1016h | 1016h | MAPSEC | Vodafone | Peter.Howard@vodafone.com | Rel-6 | Dionisio |  |  |
| 1012 | 364 | FS on Security for early IMS |  | 127d? | 2004-10-01 A | 2005-03-28 A | 100% | 2004-10-01 | 2005-03-28 | 127d? | finish no earlier than 2003-12-26 | S3 | 1016h | 1016h | SEC-IMS | Vodafone | Peter.Howard@vodafone.com | Rel-6 | Dionisio |  | 33.978 |
| 1013 | 365 | Reorganisation of CS Data Specifications |  | 14d? | 2004-11-19 A | 2004-12-08 A | 100% | 2004-11-19 | 2004-12-08 | 14d? | finish no earlier than 2004-12-24 | N3 | 112h | 112h | CS Data | Siemens | Thomas.Belling@nsn.com | Rel-6 | Gwiho |  | 23.910, 29.007, new 23.202 |
| 1014 | 366 | **Generic Access to A/Gb Interface (GAAI)** |  | 411d? | 2004-06-25 A | 2006-01-20 A | 100% | 2004-06-25 | 2006-01-20 | 411d? |  | GP | 9160h | 9160h | GAAI | Motorola |  | Rel-6 | Paolo |  |  |
| 1015 | 366.1 | FS on GAAI |  | 46d? | 2004-06-25 A | 2004-08-27 A | 100% | 2004-06-25 | 2004-08-27 | 46d? | finish no earlier than 2004-08-27 | GP | 368h | 368h | GAAG | Motorola |  | Rel-6 | Paolo |  | 43.901 |
| 1016 | 366.2 | GAAI – Stage 2 |  | 161d? | 2004-08-27 A | 2005-04-08 A | 100% | 2004-08-27 | 2005-04-08 | 161d? | finish no earlier than 2005-04-08 | GP | 1288h | 1288h | GAAI-Stage2 | Ericsson | jari.vikberg@ericsson.com | Rel-6 | Paolo |  | 43.318 |
| 1017 | 366.3 | GAAI – Stage 3 |  | 161d? | 2004-08-27 A | 2005-04-08 A | 100% | 2004-08-27 | 2005-04-08 | 161d? | finish no earlier than 2005-04-08 | GP | 1288h | 1288h | GAAI-Stage3 |  |  | Rel-6 | Paolo |  | 44.318 |
| 1018 | 366.4 | MS Conformance Test for GAAI |  | 366d? | 2004-08-27 A | 2006-01-20 A | 100% | 2004-08-27 | 2006-01-20 | 366d? | finish no earlier than 2006-01-20 | GP | 2928h | 2928h | GAAI-CT |  |  | Rel-6 | Ingbert |  |  |
| 1019 | 367 | **Support of PS Handover for GERAN A/Gb mode** |  | 473d? | 2003-11-03 A | 2005-08-24 A | 100% | 2003-11-03 | 2005-08-24 | 473d? |  | GP,G2 | 11352h | 11352h | SPSHAGB | Ericsson | gunnar.hedby@ericsson.com | Rel-6 | Paolo |  |  |
| 1020 | 367.1 | Stage 2 |  | 473d? | 2003-11-03 A | 2005-08-24 A | 100% | 2003-11-03 | 2005-08-24 | 473d? | finish no earlier than 2005-09-02 | GP,G2 | 3784h | 3784h | SPSHAGB-Stage2 | Ericsson | gunnar.hedby@ericsson.com | Rel-6 | Paolo |  | 43.129 |
| 1021 | 367.2 | PS handover |  | 473d? | 2003-11-03 A | 2005-08-24 A | 100% | 2003-11-03 | 2005-08-24 | 473d? | finish no earlier than 2005-09-02 | GP,G2 | 3784h | 3784h | SPSHAGB-PSHO | Ericsson | gunnar.hedby@ericsson.com | Rel-6 | Paolo |  |  |
| 1022 | 367.3 | Definition of radio resource management functionality |  | 473d? | 2003-11-03 A | 2005-08-24 A | 100% | 2003-11-03 | 2005-08-24 | 473d? | finish no earlier than 2005-09-02 | GP,G2 | 3784h | 3784h | SPSHAGB-RRM | Ericsson | gunnar.hedby@ericsson.com | Rel-6 | Paolo |  |  |
| 1023 | 368 | **small Technical Enhancements and Improvements for Rel-6** |  | 503d? | 2006-06-02 A | 2008-05-06 A | 100% | 2006-06-02 | 2008-05-06 | 503d? |  | All | 4024h | 4024h | TEI6 |  |  | Rel-6 |  |  |  |
| 1024 | 368.1 | Small Technical Enhancements and Improvements for Rel-6 Conformance Testing |  | 503d? | 2006-06-02 A | 2008-05-06 A | 100% | 2006-06-02 | 2008-05-06 | 503d? | start no earlier than 2006-06-02 | R5,T1 | 4024h | 4024h | TEI6_Test |  |  | Rel-6 | Ingbert |  | 34.108,34.121-1/2,34.122,34.123-1/2/3 |
| 1025 | 369 | Deleted - Enhancements of VGCS in public networks for communication of public authority officials |  | 7d? | 2005-08-24 A | 2005-09-02 A | 100% | 2005-08-24 | 2005-09-02 | 7d? | start no earlier than 2005-08-24 | GP,G2 | 56h | 56h | EVGCS | Siemens | kenneth.isaacs@roke.co.uk | Rel-6 | Paolo | GP-26 | 44.018, 44.068, 48.008 |

Notes:
- 1000: -
- 1001: -
- 1002: -
- 1003: -
- 1004: -
- 1005: -
- 1006: -
- 1007: -
- 1008: -
- 1009: -
- 1010: -
- 1011: Approved TSG#24. Marked as closed 12/2008 (was marked 20% complete)
- 1012: SP#24 approved WID. SP#27 completed. SP#46 TR 33.978 withdrawn from Rel-8 onwards
- 1013: Created at TSG#27 as 100 % complete
- 1014: -
- 1015: Feasibility Study
- 1016: -
- 1017: -
- 1018: Marked as closed 12/2008 (was marked 90% complete)
- 1019: Replaces SCSAGB- Originally Started Nov 2003 as GP-030443
- 1020: Replaces SCSAGB-Stage2
- 1021: Replaces SCSAGB-PSH
- 1022: Replaces SCSAGB-RRM
- 1023: "Joker" WI, to be used for a Rel 6 CR not related to any feature and with very limited impact on the system. Moved in from Stoyan/Testing WP
- 1024: "Joker" WI, to be used for small modifications applicable to Rel 4 conformance testing
- 1025: GP#26 moved to Rel-7 as UID_11045 Enhancements of VGCS in public networks for communication of public authority officials

| ID | WBS | Task | Type | Duration | Start | Finish | Complete | Baseline start | Baseline finish | Baseline duration | Total slack | Constraint | Resources | Work | Actual work | Text1 | Text4 | Text5 | Text6 | Text8 | Text12 |
| --- | --- | --- | --- | --- | --- | --- | --- | --- | --- | --- | --- | --- | --- | --- | --- | --- | --- | --- | --- | --- | --- |
| 1026 | 370 | **Deleted - Support of Conversational Services in A/Gb mode via the PS domain** |  | 64d? | 2003-11-21 A | 2004-02-19 A | 100% | 2003-11-21 | 2004-02-19 | 64d? |  |  | GP | 512h | 512h | SCSAGB | Ericsson | David Bladsjö (david.bladsjo@ericsson.com) | Rel-6 | Paolo |  |
| 1027 | 370.1 | Deleted - Creation of a TR | milestone | 0d? | 2003-11-21 A | 2003-11-21 A | 100% | 2003-11-21 | 2003-11-21 | 0d? |  | start no earlier than 2003-11-21 | GP |  |  | SCSAGB-TR | Ericsson | David Bladsjö (david.bladsjo@ericsson.com) | Rel-6 | Paolo | GP-17 |
| 1028 | 370.2 | Deleted - Stage 2 | milestone | 0d? | 2003-11-21 A | 2003-11-21 A | 100% | 2003-11-21 | 2003-11-21 | 0d? |  | finish no earlier than 2003-11-21 | GP |  |  | SCSAGB-Stage2 | Ericsson | David Bladsjö (david.bladsjo@ericsson.com) | Rel-6 | Paolo | GP-17 |
| 1029 | 370.3 | Deleted - Radio Channel Support | milestone | 0d? | 2003-11-21 A | 2003-11-21 A | 100% | 2003-11-21 | 2003-11-21 | 0d? |  | finish no earlier than 2003-11-21 | GP |  |  | SCSAGB-RCS | Ericsson | David Bladsjö (david.bladsjo@ericsson.com) | Rel-6 | Paolo | GP-17 |
| 1030 | 370.4 | Deleted - Definition of radio resource management functionality | milestone | 0d? | 2003-11-21 A | 2003-11-21 A | 100% | 2003-11-21 | 2003-11-21 | 0d? |  | finish no earlier than 2003-11-21 | GP,G2 |  |  | SCSAGB-RRM | Ericsson | David Bladsjö (david.bladsjo@ericsson.com) | Rel-6 | Paolo | GP-17 |
| 1031 | 370.5 | Deleted - replaced by 50561 - PS Handover |  | 64d | 2003-11-21 A | 2004-02-19 A | 100% | 2003-11-21 | 2004-02-19 | 64d |  | start no earlier than 2003-11-21 | GP,GP, N1 | 512h | 512h | SCSAGB-PSH | Ericsson | David Bladsjö (david.bladsjo@ericsson.com) | Rel-6 | Paolo | GP-18 |
| 1032 | 370.6 | Deleted - Modifications to FLO | milestone | 0d? | 2003-11-21 A | 2003-11-21 A | 100% | 2003-11-21 | 2003-11-21 | 0d? |  | finish no earlier than 2003-11-21 | GP,G2 |  |  | SCSAGB-FLO | Ericsson | David Bladsjö (david.bladsjo@ericsson.com) | Rel-6 | Paolo | RP-29 |
| 1033 | 371 | Deleted - Rel-6 Evolutions of the transport in the UTRAN | milestone | 0d | 2003-12-31 A | 2003-12-31 A | 100% | 2003-12-31 | 2003-12-31 | 0d |  | start no earlier than 2003-12-31 | RP |  |  | ETRAN | Alcatel | Francois Courau | Rel-6 | Issam | RP-22 |
| 1034 | 372 | Release 5 Features |  | 1d? | 2000-01-03 | 2000-01-03 |  | 2000-01-03 | 2000-01-03 | 1d? | 3056d |  | NP,GP, RP,SP,TP | 8h |  |  |  |  | Rel-5 |  |  |
| 1035 | 75 | IP transport in the UTRAN |  | 445d | 2000-07-17 A | 2002-03-29 A | 100% | 2000-07-17 | 2002-03-29 | 445d |  | finish no earlier than 2002-03-29 | R3 | 3560h | 3560h | ETRAN-IPtrans | Alcatel | Nicolas Drevon | Rel-5 | Juha |  |
| 1036 | 76 | FS on Usage of SUA |  | 205d | 2001-03-12 A | 2001-12-21 A | 100% | 2001-03-12 | 2001-12-21 | 205d |  | finish no earlier than 2001-12-21 | N4 | 1640h | 1640h | SS7IP |  |  | Rel-5 | Kimmo |  |
| 1037 | 77 | **High Speed Downlink Packet Access** |  | 570d | 2001-04-02 A | 2003-06-06 A | 100% | 2001-04-02 | 2003-06-06 | 570d |  |  | R2 | 15272h | 15272h | HSDPA | Motorola | Ravi Kuchibhotla | Rel-5 | Joern |  |
| 1038 | 77.1 | Physical Layer |  | 257d | 2001-04-05 A | 2002-03-29 A | 100% | 2001-04-05 | 2002-03-29 | 257d |  | finish no earlier than 2002-03-29 | R1 | 2056h | 2056h | HSDPA-Phys | Motorola | Amitava Ghosh | Rel-5 | Patrick |  |
| 1039 | 77.2 | Layer 2 and 3 aspects |  | 257d | 2001-04-05 A | 2002-03-29 A | 100% | 2001-04-05 | 2002-03-29 | 257d |  | finish no earlier than 2002-03-29 | R2 | 2056h | 2056h | HSDPA-L23 | Motorola | Ravi Kuchibhotla | Rel-5 | Joern |  |
| 1040 | 77.3 | Iub/Iur protocol aspects |  | 260d | 2001-04-02 A | 2002-03-29 A | 100% | 2001-04-02 | 2002-03-29 | 260d |  | finish no earlier than 2002-03-29 | R3 | 2080h | 2080h | HSDPA-IubIur | Motorola | Mike Diesen | Rel-5 | Juha |  |
| 1041 | 77.4 | RF Radio Transmission/ Reception, System Performance Requirements and Conformance Testing |  | 565d | 2001-04-09 A | 2003-06-06 A | 100% | 2001-04-09 | 2003-06-06 | 565d |  | finish no earlier than 2003-06-06 | R4 | 4520h | 4520h | HSDPA-RF | Motorola | Howard Benn | Rel-5 | Issam |  |
| 1042 | 78 | **Rel-5 Improvements of Radio Interface** |  | 535d | 2000-08-14 A | 2002-08-30 A | 100% | 2000-08-14 | 2002-08-30 | 535d |  |  | RP | 30376h | 30376h | RInImp |  |  | Rel-5 |  |  |
| 1043 | 78.1 | **Base station classification** |  | 480d | 2000-08-14 A | 2002-06-14 A | 100% | 2000-08-14 | 2002-06-14 | 480d |  |  | R4 | 9208h | 9208h | RInImp-BSClass | Nokia | antti.toskala@nokia.com | Rel-5 | Issam |  |
| 1044 | 78.1.1 | TDD Base station classification |  | 410d | 2000-08-14 A | 2002-03-08 A | 100% | 2000-08-14 | 2002-03-08 | 410d |  | finish no earlier than 2002-03-08 | R4 | 3280h | 3280h | RInImp-BSClass-TDD | Nokia | antti.toskala@nokia.com | Rel-5 | Issam |  |
| 1045 | 78.1.2 | Base Station Classification for 1.28 Mcps TDD option |  | 261d | 2001-06-15 A | 2002-06-14 A | 100% | 2001-06-15 | 2002-06-14 | 261d |  | finish no earlier than 2002-06-14 | R4 | 2088h | 2088h | RInImp-BSClass-LCRTDD | Siemens | Meik.Kottkamp@siemens.com | Rel-5 | Issam |  |
| 1046 | 78.2 | Enhancement on the DSCH hard split mode |  | 271d | 2001-03-16 A | 2002-03-29 A | 100% | 2001-03-16 | 2002-03-29 | 271d |  | finish no earlier than 2002-03-29 | R1 | 2168h | 2168h | RInImp-DSCHhsp | Samsung | Jaeyoel KIM | Rel-5 | Patrick |  |
| 1047 | 78.3 | Hybrid ARQ II/III |  | 355d | 2000-08-21 A | 2001-12-28 A | 100% | 2000-08-21 | 2001-12-28 | 355d |  | finish no earlier than 2001-12-28 | R2 | 2840h | 2840h | RInImp-HARQ | Siemens | A. Sitte | Rel-5 | Joern | RP-14 |
| 1048 | 78.4 | FS on USTS |  | 355d | 2000-08-14 A | 2001-12-21 A | 100% | 2000-08-14 | 2001-12-21 | 355d |  | finish no earlier than 2001-12-21 | R1 | 2840h | 2840h | RInImp-USTS | SK Telecom | D. Kim | Rel-5 | Patrick |  |
| 1049 | 78.5 | FS on UE antenna efficiency test method performance requirements |  | 255d | 2000-09-25 A | 2001-09-14 A | 100% | 2000-09-25 | 2001-09-14 | 255d |  | finish no earlier than 2001-09-14 | R4 | 2040h | 2040h | RInImp-UEAnTM | Allgon | O. Edvardsson | Rel-5 | Issam |  |
| 1050 | 78.6 | FS on the re-introduction of the downlink SIR measurement |  | 200d | 2001-03-12 A | 2001-12-14 A | 100% | 2001-03-12 | 2001-12-14 | 200d |  | finish no earlier than 2001-12-14 | R4 | 1600h | 1600h | RInImp-SIR | Ericsson | Torgny.Palenius@ericsson.com | Rel-5 | Issam |  |
| 1051 | 78.7 | FS on mitigating the effect of CPICH interference at the UE |  | 255d | 2001-03-19 A | 2002-03-08 A | 100% | 2001-03-19 | 2002-03-08 | 255d |  | finish no earlier than 2002-03-08 | R4 | 2040h | 2040h | RInImp-CPICH_Intf | Intel | shimon.moshavi@INTEL.COM | Rel-5 | Issam |  |

Notes:
- 1026: -
- 1027: -
- 1028: Started
- 1029: Not started
- 1030: Not started
- 1031: Started
- 1032: Not started
- 1033: Generic feature
- 1034: -
- 1035: -
- 1036: -
- 1037: -
- 1038: -
- 1039: -
- 1040: -
- 1041: -
- 1042: -
- 1043: -
- 1044: -
- 1045: -
- 1046: -
- 1047: Stopped at RP#14; work on this task was performed as part of High Speed Downlink Packet Access feature
- 1048: -
- 1049: -
- 1050: -
- 1051: -

| ID | WBS | Task | Duration | Start | Finish | Complete | Baseline start | Baseline finish | Baseline duration | Constraint | Resources | Work | Actual work | Text6 | Text8 | Text12 | Text1 | Text4 | Text5 | Text3 |
| --- | --- | --- | --- | --- | --- | --- | --- | --- | --- | --- | --- | --- | --- | --- | --- | --- | --- | --- | --- | --- |
| 1052 | 78.8 | **Deleted - Conformance Test Spec. improvements in Radio Interface** | 140d | 2002-02-18 A | 2002-08-30 A | 100% | 2002-02-18 | 2002-08-30 | 140d |  | T1 | 3360h | 3360h | Rel-5 | Ingbert | TP-22 |  |  |  |  |
| 1053 | 78.8.1 | Deleted - Testing improvement of inter-frequency and inter-system measurement | 140d | 2002-02-18 A | 2002-08-30 A | 100% | 2002-02-18 | 2002-08-30 | 140d | finish no earlier than 2002-08-30 | T1 | 1120h | 1120h | Rel-5 | Ingbert | TP-22 |  |  |  |  |
| 1054 | 78.8.2 | Deleted - Testing Hybrid ARQ II/III | 140d | 2002-02-18 A | 2002-08-30 A | 100% | 2002-02-18 | 2002-08-30 | 140d | finish no earlier than 2002-08-30 | T1 | 1120h | 1120h | Rel-5 | Ingbert | TP-22 |  |  |  |  |
| 1055 | 79 | **Rel-5 RAN improvements** | 772d? | 2001-03-16 A | 2004-03-01 A | 100% | 2001-03-16 | 2004-03-01 | 772d? |  | RP | 39984h | 39984h | Rel-5 |  |  | RANimp |  |  |  |
| 1056 | 79.1 | **RRM optimization for Iur and Iub** | 318d | 2001-03-16 A | 2002-06-04 A | 100% | 2001-03-16 | 2002-06-04 | 318d |  | R3 | 8904h | 8904h | Rel-5 | Juha |  | RANimp-RRMopt | Ericsson | Gert-Jan.van.Lieshout@eln.ericsson.se |  |
| 1057 | 79.1.1 | Iur common transport channel efficiency optimization | 271d | 2001-03-16 A | 2002-03-29 A | 100% | 2001-03-16 | 2002-03-29 | 271d | finish no earlier than 2002-03-29 | R3 | 2168h | 2168h | Rel-5 | Juha |  | RANimp-RRMopt-ctc | Ericsson | Shahrokh Amirijoo |  |
| 1058 | 79.1.2 | Iur neighbouring cell reporting efficiency optimization | 271d | 2001-03-16 A | 2002-03-29 A | 100% | 2001-03-16 | 2002-03-29 | 271d | finish no earlier than 2002-03-29 | R3 | 2168h | 2168h | Rel-5 | Juha |  | RANimp-RRMopt-ncr | Ericsson | Shahrokh Amirijoo |  |
| 1059 | 79.1.3 | FS Introduction of direct transport bearers between SRNC and Node-B | 253d | 2001-06-15 A | 2002-06-04 A | 100% | 2001-06-15 | 2002-06-04 | 253d | finish no earlier than 2002-06-28 | R3 | 2024h | 2024h | Rel-5 | Juha |  | RAN-imp-RRMopt-DTB | Ericsson | Risto Sepponen |  |
| 1060 | 79.2 | RL Timing Adjustment | 271d | 2001-03-16 A | 2002-03-29 A | 100% | 2001-03-16 | 2002-03-29 | 271d | finish no earlier than 2002-03-29 | R3 | 2168h | 2168h | Rel-5 | Juha |  | RANimp-RLTA | Ericsson | Elena Voltolina |  |
| 1061 | 79.3 | Separation of resource reservation and radio link activation | 271d | 2001-03-16 A | 2002-03-29 A | 100% | 2001-03-16 | 2002-03-29 | 271d | finish no earlier than 2002-03-29 | R3 | 2168h | 2168h | Rel-5 | Juha |  | RANimp-SepRR | Ericsson | Gert-Jan.van.Lieshout@eln.ericsson.se |  |
| 1062 | 79.4 | FS SRNS Relocation Procedure Enhancement | 318d | 2001-06-15 A | 2002-09-03 A | 100% | 2001-06-15 | 2002-09-03 | 318d | finish no earlier than 2002-09-06 | R3 | 2544h | 2544h | Rel-5 | Juha |  | RANimp-SRNS | Nokia | Olivier Guyot |  |
| 1063 | 79.5 | FS Improvement of Radio Resource Management across RNS and RNS/PSS | 201d | 2001-03-16 A | 2001-12-21 A | 100% | 2001-03-16 | 2001-12-21 | 201d | finish no earlier than 2001-12-21 | R3 | 1608h | 1608h | Rel-5 | Juha |  | RANimp-ImpRRM | Nokia | antti.toskala@nokia.com |  |
| 1064 | 79.6 | Re-arrangements of Iub transport bearers | 271d | 2001-03-16 A | 2002-03-29 A | 100% | 2001-03-16 | 2002-03-29 | 271d | finish no earlier than 2002-03-29 | R3 | 2168h | 2168h | Rel-5 | Juha |  | RANimp-TTPS | Nokia | antti.toskala@nokia.com |  |
| 1065 | 79.7 | RAB support enhancement for Rel-5 | 325d | 2001-04-02 A | 2002-06-28 A | 100% | 2001-04-02 | 2002-06-28 | 325d | finish no earlier than 2002-06-28 | R2 | 2600h | 2600h | Rel-5 | Joern |  | RANimp-RABSE5 | Nokia | Juha Mikola |  |
| 1066 | 79.8 | Beamforming requirements for UE | 61d | 2001-09-21 A | 2001-12-14 A | 100% | 2001-09-21 | 2001-12-14 | 61d | finish no earlier than 2001-12-14 | R1 | 488h | 488h | Rel-5 | Patrick |  | RANimp-BFR-UE | Nokia | Jussi Kähtävä (juha.mikola@nokia.com) |  |
| 1067 | 79.9 | Support of Site Selection Diversity Transmission in UTRAN | 123d | 2001-12-14 A | 2002-06-04 A | 100% | 2001-12-14 | 2002-06-04 | 123d | finish no earlier than 2002-06-04 | R1 | 984h | 984h | Rel-5 | Patrick |  | RANimp-SSDT | NEC |  |  |
| 1068 | 79.10 | Node B Synchronisation for 1.28 Mcps TDD | 271d | 2001-03-16 A | 2002-03-29 A | 100% | 2001-03-16 | 2002-03-29 | 271d | finish no earlier than 2002-03-29 | R1 | 2168h | 2168h | Rel-5 | Patrick |  | RANimp-NBSLCR | CATT | Jinling HU |  |
| 1069 | 79.12 | **Deleted - Conformance Test Aspects - RAN Improvements** | 565d? | 2002-01-01 A | 2004-03-01 A | 100% | 2002-01-01 | 2004-03-01 | 565d? |  | T1 | 8008h | 8008h | Rel-5 | Ingbert |  |  |  |  | 0% |
| 1070 | 79.12.1 | Deleted - Testing Radio access bearer support enhancements | 175d | 2002-01-01 A | 2002-09-02 A | 100% | 2002-01-01 | 2002-09-02 | 175d | finish no earlier than 2002-09-02 | T1 | 1400h | 1400h | Rel-5 | Ingbert | TP-22 |  |  |  |  |
| 1071 | 377.11.2 | Deleted - General changes to TS34.121 and TS34.122 corresponding to release 5 | 261d? | 2003-03-03 A | 2004-03-01 A | 100% | 2003-03-03 | 2004-03-01 | 261d? | finish no earlier than 2004-03-01 | T1 | 2088h | 2088h | Rel-5 | Ingbert |  | RANimp-test |  |  | 34.108, 34.121, 34.122 |
| 1072 | 80 | UTRAN Sharing in Connected Mode | 197d | 2001-12-03 A | 2002-09-03 A | 100% | 2001-12-03 | 2002-09-03 | 197d | finish no earlier than 2002-09-06 | R3 | 1576h | 1576h | Rel-5 | Juha |  | NETSHARE | Ericsson | Martin Israelsson |  |
| 1073 | 85 | **Rel-5 MExE enhancements** | 250d | 2001-03-26 A | 2002-03-08 A | 100% | 2001-03-26 | 2002-03-08 | 250d |  | T2 | 2880h | 2880h | Rel-5 | Kimmo |  | MEXE5 |  |  |  |
| 1074 | 85.1 | MExE Rel-5 Improvements and Investigations | 110d | 2001-03-26 A | 2002-03-08 A | 100% | 2001-03-26 | 2002-03-08 | 110d | finish no earlier than 2001-12-17 | T2 | 880h | 880h | Rel-5 |  |  | MEXE5-ENHANC | Motorola | Mark Cataldo | 22.057, 23.057 |
| 1075 | 11 | **Terminal interfaces** | 223d | 2001-05-14 A | 2002-03-20 A | 100% | 2001-05-14 | 2002-03-20 | 223d |  | T2 | 3568h | 3568h | Rel-5 | Kimmo |  | TI |  |  |  |
| 1076 | 87 | Terminal local model enhancements | 223d | 2001-05-14 A | 2002-03-20 A | 100% | 2001-05-14 | 2002-03-20 | 223d | finish no earlier than 2002-03-20 | T2 | 1784h | 1784h | Rel-5 |  |  | TLM5 |  |  | 23.227 |

Notes:
- 1052: Marked as stopped 12/2008
- 1053: start/finish dates set...Marked as stopped 12/2008
- 1054: start/finish dates set...Marked as stopped 12/2008
- 1055: -
- 1056: -
- 1057: -
- 1058: -
- 1059: FS was closed and introduction of WI not agreed at RAN #16
- 1060: -
- 1061: -
- 1062: -
- 1063: FS was closed and WI was introduced at RAN #14
- 1064: -
- 1065: RFC 3095 context relocation
- 1066: -
- 1067: RP-020356
- 1068: -
- 1069: Marked as stopped 12/2008
- 1070: duration set to 6 months (was 0)...Marked as stopped 12/2008
- 1071: Marked as stopped 12/2008
- 1072: Formerly 'Shared Network support in connected mode', renamed at RAN #16.
- 1073: -
- 1074: -
- 1075: -
- 1076: -

| ID | WBS | Task | Duration | Start | Finish | Predecessors | Complete | Baseline start | Baseline finish | Baseline duration | Constraint | Resources | Work | Actual work | Text4 | Text5 | Text6 | Text8 | Text1 | Text12 | Text3 |
| --- | --- | --- | --- | --- | --- | --- | --- | --- | --- | --- | --- | --- | --- | --- | --- | --- | --- | --- | --- | --- | --- |
| 1077 | 89 | **Rel-5 Security enhancements** | 615d | 2000-02-21 A | 2002-06-28 A |  | 100% | 2000-02-21 | 2002-06-28 | 615d |  | S3 | 29974.9h | 29974.9h | Vodafone | Peter.Howard@vodafone.com | Rel-5 | Dionisio |  |  |  |
| 1078 | 89.1 | **Network domain security** | 615d | 2000-02-21 A | 2002-06-28 A |  | 100% | 2000-02-21 | 2002-06-28 | 615d |  | S3 | 25054.9h | 25054.9h | Telenor | Geir-myrdahl.koien@telenor.com | Rel-5 | Dionisio | SEC1-NDS |  |  |
| 1079 | 89.1.1 | **Deleted -Control plane protection in core network (e.g., GTP, CAP, MAP/IP, provided by IPsec)** | 541d | 2000-05-12 A | 2002-06-07 A |  | 100% | 2000-05-12 | 2002-06-07 | 541d |  | S3 | 7118.9h | 7118.9h |  |  | Rel-5 | Dionisio |  | SP-16 |  |
| 1080 | 89.1.1.1 | Deleted - Main aspects | 290d | 2000-05-12 A | 2001-06-21 A |  | 100% | 2000-05-12 | 2001-06-21 | 290d | finish no earlier than 2001-06-21 | S3 | 2320h | 2320h |  |  | Rel-5 | Dionisio |  | SP-12 |  |
| 1081 | 89.1.1.2 | Deleted -Integration of GTP signalling security architecture | 191d | 2001-09-14 A | 2002-06-07 A |  | 100% | 2001-09-14 | 2002-06-07 | 191d | finish no earlier than 2002-06-07 | N4 | 1528h | 1528h |  |  | Rel-5 | Kimmo |  | NP-16 |  |
| 1082 | 89.1.2 | **Deleted -User plane protection in core network (e.g., provided by IPsec)** | 615d | 2000-02-21 A | 2002-06-28 A |  | 100% | 2000-02-21 | 2002-06-28 | 615d |  | S3 | 9360h | 9360h |  |  | Rel-5 | Dionisio |  | SP-16 |  |
| 1083 | 89.1.2.1 | Deleted -Main aspects | 349d | 2000-02-21 A | 2001-06-21 A |  | 100% | 2000-02-21 | 2001-06-21 | 349d | finish no earlier than 2001-06-21 | S3 | 2792h | 2792h |  |  | Rel-5 | Dionisio |  | SP-12 |  |
| 1084 | 89.1.2.2 | Deleted -Integration of GTP signalling security architecture | 206d | 2001-09-14 A | 2002-06-28 A |  | 100% | 2001-09-14 | 2002-06-28 | 206d | finish no earlier than 2002-06-28 | N4 | 1648h | 1648h |  |  | Rel-5 | Kimmo |  | NP-16 |  |
| 1085 | 89.1.3 | IP network layer security (NDS/IP) | 457d | 2000-06-15 A | 2002-03-15 A |  | 100% | 2000-06-15 | 2002-03-15 | 457d | finish no earlier than 2002-03-15 | S3 | 3656h | 3656h | Telenor | Geir-myrdahl.koien@telenor.com | Rel-5 | Dionisio | SEC1-NDS-IP |  | 33.210 |
| 1086 | 90 | **Intra Domain Connection of RAN Nodes to Multiple CN Nodes** | 455d | 2000-10-02 A | 2002-06-28 A |  | 100% | 2000-10-02 | 2002-06-28 | 455d |  | S2 | 15136h | 15136h | Ericsson | stephen.terrill@ericsson.com | Rel-5 | Alain | IUFLEX |  | 23.236 |
| 1087 | 90.1 | Overall System Architecture | 188d | 2001-01-03 A | 2001-09-21 A |  | 100% | 2001-01-03 | 2001-09-21 | 188d | finish no earlier than 2001-06-01 | S2 | 1504h | 1504h |  |  | Rel-5 | Maurice |  |  |  |
| 1088 | 90.2 | Stage 3: RAN node selecting CN node | 130d | 2001-09-24 A | 2002-03-22 A | 1087 | 100% | 2001-09-24 | 2002-03-22 | 130d | finish no earlier than 2002-03-22 | R3 | 1040h | 1040h | Vodafone | Brendan.McWilliams@gb.vodafone.co.uk | Rel-5 | Juha |  |  |  |
| 1089 | 90.3 | N1 work | 205d | 2001-09-17 A | 2002-06-28 A |  | 100% | 2001-09-17 | 2002-06-28 | 205d | start no earlier than 2001-09-17 | N1 | 1640h | 1640h |  |  | Rel-5 | Frederic |  |  | 24.008 and check 29.018 |
| 1090 | 90.4 | N4 work | 375d | 2000-10-02 A | 2002-03-08 A |  | 100% | 2000-10-02 | 2002-03-08 | 375d | finish no earlier than 2002-03-15 | N4 | 3000h | 3000h |  |  | Rel-5 | Kimmo |  |  |  |
| 1091 | 90.5 | **GERAN work for Intra Domain Connection of RAN Nodes to Multiple CN Nodes** | 101d | 2002-02-08 A | 2002-06-28 A |  | 100% | 2002-02-08 | 2002-06-28 | 101d |  | GP | 4848h | 4848h | Ericsson | ingemar.backlund@era.ericsson.se | Rel-5 | Paolo | IDCRAN-GERAN |  |  |
| 1092 | 90.5.1 | Stage 2 (changes to ) | 101d | 2002-02-08 A | 2002-06-28 A |  | 100% | 2002-02-08 | 2002-06-28 | 101d | finish no earlier than 2002-06-28 | G1 | 808h | 808h |  |  | Rel-5 |  |  |  |  |
| 1093 | 90.5.2 | 43.051 Introduction of support for IDNNS in GERAN Iu mode | 101d | 2002-02-08 A | 2002-06-28 A |  | 100% | 2002-02-08 | 2002-06-28 | 101d | finish no earlier than 2002-06-28 | G1 | 808h | 808h |  |  | Rel-5 |  |  |  |  |
| 1094 | 90.5.3 | Stage 3 (changes to ) | 101d | 2002-02-08 A | 2002-06-28 A |  | 100% | 2002-02-08 | 2002-06-28 | 101d | finish no earlier than 2002-06-28 | G2 | 808h | 808h |  |  | Rel-5 | Gert |  |  |  |
| 1095 | 90.5.4 | 48.016 Use of Gb interface concepts when a network applies IDNNS | 101d | 2002-02-08 A | 2002-06-28 A |  | 100% | 2002-02-08 | 2002-06-28 | 101d | finish no earlier than 2002-06-28 | G2 | 808h | 808h |  |  | Rel-5 | Gert |  |  |  |
| 1096 | 90.5.5 | 48.018 Include MSC/VLR identity in CS IMSI paging | 101d | 2002-02-08 A | 2002-06-28 A |  | 100% | 2002-02-08 | 2002-06-28 | 101d | finish no earlier than 2002-06-28 | G2 | 808h | 808h |  |  | Rel-5 | Gert |  |  |  |
| 1097 | 91 | **Deleted - GERAN improvements 3 (new transport layer on interface A)** | 446d | 2001-04-06 A | 2002-12-20 A |  | 100% | 2001-04-06 | 2002-12-20 | 446d |  | GP | 14272h | 14272h |  |  | Rel-5 | Paolo | GEIMP3 |  |  |
| 1098 | 91.1 | **Deleted - Evolution of the transport for A** | 446d | 2001-04-06 A | 2002-12-20 A |  | 100% | 2001-04-06 | 2002-12-20 | 446d |  | GP | 10704h | 10704h |  |  | Rel-5 | Paolo | GEIMP3-EtA | GP-12 |  |
| 1099 | 91.1.1 | Deleted - Definition of a new A/Ater interface Transport Layer option based on the Iu Interface Transport Layer | 446d | 2001-04-06 A | 2002-12-20 A |  | 100% | 2001-04-06 | 2002-12-20 | 446d | finish no earlier than 2002-12-20 | GP | 3568h | 3568h |  |  | Rel-5 | Paolo |  | GP-12 |  |
| 1100 | 91.1.2 | Deleted - Adaptation of the Layer 3 BSSMAP procedures as required | 446d | 2001-04-06 A | 2002-12-20 A |  | 100% | 2001-04-06 | 2002-12-20 | 446d | finish no earlier than 2002-12-20 | GP | 3568h | 3568h |  |  | Rel-5 | Paolo |  | GP-12 |  |

Notes:
- 1077: Added BB UE authentication and rapporteur added. TO BE DELETED
- 1078: S3#17: All due in Rel5. (WI Update at S3#18). Replaced by NDS-IP and NDS-MAP. TO BE DELETED OR MOVED TO HISTORY FILE
- 1079: Marked as stopped 12/2008
- 1080: TO BE DELETED. Marked as stopped 12/2008
- 1081: Waiting for input from SA3!.... Marked as stopped 12/2008
- 1082: TO BE DELETED. Marked as stopped 12/2008
- 1083: -
- 1084: 14/02/2002 requirements are not clear/not received...Marked as closed 12/2008 (was marked 95 complete)
- 1085: 2002/12: All IPsec RFCs are stable STD Track RFCs. WID updated SP#17
- 1086: No clear indication on the end date. Put to Rel5 by AS.
- 1087: -
- 1088: Not identified
- 1089: -
- 1090: DAB 12.12.01 - % complete to 66% / 14/02/02 Work completed
- 1091: Accept changes Gb over IP
- 1092: -
- 1093: -
- 1094: -
- 1095: Closed, accept changes for Gb over IP
- 1096: -
- 1097: Terminated - not standardized. Marked as stopped 12/2008
- 1098: TERMINATED - NOT STANDARDIZED. Marked as stopped 12/2008
- 1099: TERMINATED - NOT STANDARDIZED. Marked as stopped 12/2008
- 1100: TERMINATED - NOT STANDARDIZED. Marked as stopped 12/2008

| ID | WBS | Task | Duration | Start | Finish | Predecessors | Complete | Baseline start | Baseline finish | Baseline duration | Constraint | Resources | Work | Actual work | Text1 | Text4 | Text6 | Text8 | Text5 |
| --- | --- | --- | --- | --- | --- | --- | --- | --- | --- | --- | --- | --- | --- | --- | --- | --- | --- | --- | --- |
| 1101 | 92 | **Rel-5 Charging and OAM&P** | 264d | 2001-09-10 A | 2002-09-12 A |  | 100% | 2001-09-10 | 2002-09-12 | 264d |  | S5 | 9976h | 9976h | OAM | VoiceStream, Motorola | Rel-5 | Dionisio |  |
| 1102 | 92.1 | Rel5 Principles, high level Requirements and Architecture | 205d | 2001-09-17 A | 2002-06-28 A |  | 100% | 2001-09-17 | 2002-06-28 | 205d | finish no earlier than 2002-06-28 | S5 | 1640h | 1640h | OAM-AR/PR | Motorola | Rel-5 | Dionisio |  |
| 1103 | 92.2 | Rel5 Performance Management | 259d | 2001-09-17 A | 2002-09-12 A |  | 100% | 2001-09-17 | 2002-09-12 | 259d | finish no earlier than 2002-09-12 | S5 | 2072h | 2072h | OAM-PM | Nortel | Rel-5 | Dionisio |  |
| 1104 | 92.3 | Rel5 Charging Management | 264d | 2001-09-10 A | 2002-09-12 A |  | 100% | 2001-09-10 | 2002-09-12 | 264d | finish no earlier than 2002-09-12 | S5 | 2112h | 2112h | OAM-CH | T-Mobile | Rel-5 | Dionisio | Karl-Heinz.Nenner@T-MOBILE.DE |
| 1105 | 92.4 | Rel5 Network Infrastructure Management | 255d | 2001-09-21 A | 2002-09-12 A |  | 100% | 2001-09-21 | 2002-09-12 | 255d | finish no earlier than 2002-09-12 | S5 | 2040h | 2040h | OAM-NIM | Ericsson | Rel-5 | Dionisio | thomas.tovinger@ericsson.com |
| 1106 | 93 | **GERAN enhancements for streaming services 1 (RLC enhancements)** | 430d | 2000-11-06 A | 2002-06-28 A |  | 100% | 2000-11-06 | 2002-06-28 | 430d |  | GP | 8944h | 8944h |  |  | Rel-5 | Paolo |  |
| 1107 | 93.1 | Concept | 258d | 2000-11-06 A | 2001-10-31 A |  | 100% | 2000-11-06 | 2001-10-31 | 258d | finish no earlier than 2001-10-31 | GP | 2064h | 2064h |  |  | Rel-5 | Paolo |  |
| 1108 | 93.2 | RLC protocol enhancement (SDU Discard) | 430d | 2000-11-06 A | 2002-06-28 A |  | 100% | 2000-11-06 | 2002-06-28 | 430d | finish no earlier than 2002-06-28 | GP | 3440h | 3440h |  |  | Rel-5 | Paolo |  |
| 1109 | 94 | **GERAN enhancements for streaming services 2 (usage of ECSD)** | 430d | 2000-11-06 A | 2002-06-28 A |  | 100% | 2000-11-06 | 2002-06-28 | 430d |  | GP | 19840h | 19840h |  | Ericsson | Rel-5 | Paolo | Frank Muller |
| 1110 | 94.1 | Usage of ECSD Concept | 380d | 2000-11-06 A | 2002-04-19 A |  | 100% | 2000-11-06 | 2002-04-19 | 380d | finish no earlier than 2002-04-19 | GP | 3040h | 3040h |  |  | Rel-5 | Paolo |  |
| 1111 | 94.2 | Stage 2 | 380d | 2000-11-06 A | 2002-04-19 A |  | 100% | 2000-11-06 | 2002-04-19 | 380d | finish no earlier than 2002-04-19 | GP | 3040h | 3040h |  |  | Rel-5 | Paolo |  |
| 1112 | 94.3 | Stage 3 | 430d | 2000-11-06 A | 2002-06-28 A |  | 100% | 2000-11-06 | 2002-06-28 | 430d | finish no earlier than 2002-06-28 | GP | 3440h | 3440h |  |  | Rel-5 | Paolo |  |
| 1113 | 94.4 | RLC PDU formats | 430d | 2000-11-06 A | 2002-06-28 A |  | 100% | 2000-11-06 | 2002-06-28 | 430d | finish no earlier than 2002-06-28 | GP | 3440h | 3440h |  |  | Rel-5 | Paolo |  |
| 1114 | 94.5 | MAC header | 430d | 2000-11-06 A | 2002-06-28 A |  | 100% | 2000-11-06 | 2002-06-28 | 430d | finish no earlier than 2002-06-28 | GP | 3440h | 3440h |  |  | Rel-5 | Paolo |  |
| 1115 | 95 | **GERAN/UTRAN interface evolution 1 (evolution of Iu PS)** | 476d | 2000-09-01 A | 2002-06-28 A |  | 100% | 2000-09-01 | 2002-06-28 | 476d |  | GP,R3 | 10688h | 10688h | GERUEV1 | SBC | Rel-5 | Paolo | Marc Grant |
| 1116 | 95.1 | **Evolution of Iu ps** | 476d | 2000-09-01 A | 2002-06-28 A |  | 100% | 2000-09-01 | 2002-06-28 | 476d |  | GP,R3 | 7248h | 7248h | GERUEV1-IuPS |  | Rel-5 | Paolo |  |
| 1117 | 95.1.1 | Identification of GERAN requirements on Iu ps | 326d | 2000-09-01 A | 2001-11-30 A |  | 100% | 2000-09-01 | 2001-11-30 | 326d | finish no earlier than 2001-11-30 | GP,R3 | 2608h | 2608h |  |  | Rel-5 | Paolo |  |
| 1118 | 95.1.2 | Update of specifications | 150d | 2001-12-03 A | 2002-06-28 A | 1117 | 100% | 2001-12-03 | 2002-06-28 | 150d | finish no earlier than 2002-06-28 | GP,R3 | 1200h | 1200h |  |  | Rel-5 | Paolo |  |
| 1119 | 96 | **GERAN/UTRAN interface evolution 2 (evolution of Iu CS)** | 476d | 2000-09-01 A | 2002-06-28 A |  | 100% | 2000-09-01 | 2002-06-28 | 476d |  | GP,R3 | 12816h | 12816h | GERUEV2 |  | Rel-5 | Paolo |  |
| 1120 | 96.1 | **Evolution of Iu cs** | 476d | 2000-09-01 A | 2002-06-28 A |  | 100% | 2000-09-01 | 2002-06-28 | 476d |  | GP,R3 | 10016h | 10016h | GERUEV2-IuCS | Lucent | Rel-5 | Paolo | Krishna Balachandran |
| 1121 | 96.1.1 | Identification of GERAN requirements on Iu cs | 426d | 2000-09-01 A | 2002-06-24 A |  | 100% | 2000-09-01 | 2002-06-24 | 426d | finish no earlier than 2002-04-19 | GP,R3 | 3408h | 3408h |  |  | Rel-5 | Paolo |  |
| 1122 | 96.1.2 | Update of specifications | 476d | 2000-09-01 A | 2002-06-28 A |  | 100% | 2000-09-01 | 2002-06-28 | 476d | finish no earlier than 2002-06-28 | GP,R3 | 3808h | 3808h |  |  | Rel-5 | Paolo |  |
| 1123 | 97 | **End to End QoS for PS Domain including IMS** | 480d | 2000-08-28 A | 2002-06-28 A |  | 100% | 2000-08-28 | 2002-06-28 | 480d |  | S2 | 9856h | 9856h | E2EQoS | Ericsson | Rel-5 | Maurice | Johnson.oyama@era.ericcson.se |
| 1124 | 97.1 | E2E QoSConcept and Architecture | 178d | 2001-01-03 A | 2001-09-07 A |  | 100% | 2001-01-03 | 2001-09-07 | 178d | finish no earlier than 2001-09-07 | S2 | 1424h | 1424h |  |  | Rel-5 | Maurice |  |
| 1125 | 97.2 | E2E QoS interworking | 465d | 2000-08-28 A | 2002-06-07 A |  | 100% | 2000-08-28 | 2002-06-07 | 465d | finish no earlier than 2002-06-07 | N3 | 3720h | 3720h | E2EQoS-IW | Lucent | Rel-5 | Gwiho | Daisuke Yokota (yokota@lucent.com) |
| 1126 | 97.3 | QoS Management (Provisioning and Monitoring) | 201d | 2001-09-21 A | 2002-06-28 A |  | 100% | 2001-09-21 | 2002-06-28 | 201d | finish no earlier than 2002-06-28 | S5 | 1608h | 1608h | E2EQoS-OAM | VoiceStream, Motorola | Rel-5 | Dionisio |  |

Notes:
- 1101: -
- 1102: - / Text3: 32.101, 32.102
- 1103: - / Text3: 32.4xy, 52.402
- 1104: - / Text3: 32.200, 32.205, 32.215, 32.225, 32.235
- 1105: - / Text3: 32.6xy, 32.3xy
- 1106: -
- 1107: -
- 1108: -
- 1109: AWS, Nokia, Ericsson, Nortel, Siemens, Motorola, Vodafone
- 1110: -
- 1111: -
- 1112: -
- 1113: -
- 1114: -
- 1115: SBC, Motorola, Nokia, Ericsson, Nortel
- 1116: -
- 1117: -
- 1118: -
- 1119: -
- 1120: Lucent, Ericsson, AWS, Nortel
- 1121: -
- 1122: -
- 1123: -
- 1124: - / Text3: 23.207
- 1125: [DAB - 30/07/02] - % complete to 95% (if we exclude Diffserv). Marked as closed 12/2008 (was marked 95% complete) / Text3: 29.208, 29.207, 27.060, 29.061, 24.008, 24.228, , 24.229, 29.060, 29.163
- 1126: - / Text3: 32-series

| ID | WBS | Task | Duration | Start | Finish | Complete | Baseline start | Baseline finish | Baseline duration | Constraint | Resources | Work | Actual work | Text1 | Text6 | Text8 | Text12 | Text3 | Text4 | Text5 |
| --- | --- | --- | --- | --- | --- | --- | --- | --- | --- | --- | --- | --- | --- | --- | --- | --- | --- | --- | --- | --- |
| 1127 | 99 | **GERAN Inter BSC NACC improvements over the Gb Interface** | 215d | 2001-09-03 A | 2002-06-28 A | 100% | 2001-09-03 | 2002-06-28 | 215d |  | GP | 8200h | 8200h | GERNACC | Rel-5 | Paolo |  |  |  |  |
| 1128 | 99.1 | **Modification of core network protocols for GERAN Inter BSC NACC over Gb Interface** | 165d | 2001-09-03 A | 2002-04-19 A | 100% | 2001-09-03 | 2002-04-19 | 165d |  | N4,S2 | 4064h | 4064h | GERNACC-Cnmod | Rel-5 | Kimmo |  |  |  |  |
| 1129 | 99.1.1 | Stage 2 - Concept | 43d | 2001-09-03 A | 2001-10-31 A | 100% | 2001-09-03 | 2001-10-31 | 43d | finish no earlier than 2001-10-31 | N4,S2 | 344h | 344h |  | Rel-5 | Kimmo |  |  |  |  |
| 1130 | 99.1.2 | Stage 2 - 23.060 change - Definition of Inter BSC NACC | 165d | 2001-09-03 A | 2002-04-19 A | 100% | 2001-09-03 | 2002-04-19 | 165d | finish no earlier than 2002-04-19 | N4,S2 | 1320h | 1320h |  | Rel-5 | Kimmo |  |  |  |  |
| 1131 | 99.1.3 | Stage 3 (changes to TS 29.060) | 135d | 2001-09-03 A | 2002-03-08 A | 100% | 2001-09-03 | 2002-03-08 | 135d | finish no earlier than 2002-03-08 | N4 | 1080h | 1080h |  | Rel-5 | Kimmo |  |  |  |  |
| 1132 | 99.2 | **Modification of Gb protocols for GERAN Inter BSC NACC over Gb Interface** | 151d | 2001-11-30 A | 2002-06-28 A | 100% | 2001-11-30 | 2002-06-28 | 151d |  | GP | 2416h | 2416h | GERNACC-Gbmod | Rel-5 | Paolo |  |  |  |  |
| 1133 | 99.2.1 | Stage 3 (changes to TS 48.018) | 151d | 2001-11-30 A | 2002-06-28 A | 100% | 2001-11-30 | 2002-06-28 | 151d | finish no earlier than 2002-06-28 | GP | 1208h | 1208h |  | Rel-5 | Paolo |  |  |  |  |
| 1134 | 100 | **Enhanced Power Control** | 540d | 2001-11-26 A | 2003-12-19 A | 100% | 2001-11-26 | 2003-12-19 | 540d |  | GP | 12840h | 12840h | EPC | Rel-5 | Paolo |  |  |  |  |
| 1135 | 100.1 | Realization of Enhanced power control and signalling support | 5d | 2001-11-26 A | 2001-11-30 A | 100% | 2001-11-26 | 2001-11-30 | 5d | finish no earlier than 2001-11-30 | GP | 40h | 40h |  | Rel-5 | Paolo |  |  |  |  |
| 1136 | 100.2 | Deleted - GERAN MS Conformance test for Enhanced Power Control | 530d | 2001-12-10 A | 2003-12-19 A | 100% | 2001-12-10 | 2003-12-19 | 530d | finish no earlier than 2003-12-19 | GP | 4240h | 4240h |  | Rel-5 | Paolo | GP-17 |  |  |  |
| 1137 | 100.3 | Deleted - GERAN BTS Conformance test for Enhanced Power Control | 530d | 2001-12-10 A | 2003-12-19 A | 100% | 2001-12-10 | 2003-12-19 | 530d | finish no earlier than 2003-12-19 | GP | 4240h | 4240h |  | Rel-5 | Paolo | GP-17 |  |  |  |
| 1138 | 101 | **8PSK AMR HR** | 530d | 2001-12-10 A | 2003-12-19 A | 100% | 2001-12-10 | 2003-12-19 | 530d |  | GP | 21080h | 21080h | 8PSK-AH | Rel-5 | Paolo |  |  |  |  |
| 1139 | 101.1 | **Definition of channel coding, performance requirements and signalling support** | 145d | 2001-12-10 A | 2002-06-28 A | 100% | 2001-12-10 | 2002-06-28 | 145d |  | GP | 10440h | 10440h |  | Rel-5 | Paolo |  |  |  |  |
| 1140 | 101.1.1 | Concept | 145d | 2001-12-10 A | 2002-06-28 A | 100% | 2001-12-10 | 2002-06-28 | 145d | finish no earlier than 2002-06-28 | GP | 1160h | 1160h |  | Rel-5 | Paolo |  |  |  |  |
| 1141 | 101.1.2 | Changes to 44.018 | 145d | 2001-12-10 A | 2002-06-28 A | 100% | 2001-12-10 | 2002-06-28 | 145d | finish no earlier than 2002-06-28 | G2 | 1160h | 1160h |  | Rel-5 | Gert |  |  |  |  |
| 1142 | 101.1.3 | Changes to 45.001 | 145d | 2001-12-10 A | 2002-06-28 A | 100% | 2001-12-10 | 2002-06-28 | 145d | finish no earlier than 2002-06-28 | G1 | 1160h | 1160h |  | Rel-5 |  |  |  |  |  |
| 1143 | 101.1.4 | Changes to 45.002 | 145d | 2001-12-10 A | 2002-06-28 A | 100% | 2001-12-10 | 2002-06-28 | 145d | finish no earlier than 2002-06-28 | G1 | 1160h | 1160h |  | Rel-5 |  |  |  |  |  |
| 1144 | 101.1.5 | Changes to 45.003 | 145d | 2001-12-10 A | 2002-06-28 A | 100% | 2001-12-10 | 2002-06-28 | 145d | finish no earlier than 2002-06-28 | G1 | 1160h | 1160h |  | Rel-5 |  |  |  |  |  |
| 1145 | 101.1.6 | Changes to 45.005 | 145d | 2001-12-10 A | 2002-06-28 A | 100% | 2001-12-10 | 2002-06-28 | 145d | finish no earlier than 2002-06-28 | G1 | 1160h | 1160h |  | Rel-5 |  |  |  |  |  |
| 1146 | 101.1.7 | Changes to 24.008 | 145d | 2001-12-10 A | 2002-06-28 A | 100% | 2001-12-10 | 2002-06-28 | 145d | finish no earlier than 2002-06-28 | G2 | 1160h | 1160h |  | Rel-5 | Gert |  |  |  |  |
| 1147 | 101.1.8 | Changes to 48.058 | 145d | 2001-12-10 A | 2002-06-28 A | 100% | 2001-12-10 | 2002-06-28 | 145d | finish no earlier than 2002-06-28 | G2 | 1160h | 1160h |  | Rel-5 | Gert |  |  |  |  |
| 1148 | 101.2 | Deleted - GERAN MS Conformance test for 8PSK HR | 530d | 2001-12-10 A | 2003-12-19 A | 100% | 2001-12-10 | 2003-12-19 | 530d | finish no earlier than 2003-12-19 | GP | 4240h | 4240h |  | Rel-5 | Paolo |  |  |  |  |
| 1149 | 101.3 | GERAN BTS Conformance test for 8PSK HR | 270d | 2001-12-10 A | 2002-12-20 A | 100% | 2001-12-10 | 2002-12-20 | 270d | finish no earlier than 2002-12-20 | GP | 2160h | 2160h |  | Rel-5 | Paolo |  |  |  |  |
| 1150 | 102 | Service Change and UDI Fallback | 175d | 2001-10-08 A | 2002-06-07 A | 100% | 2001-10-08 | 2002-06-07 | 175d | finish no earlier than 2002-06-07 | N3 | 1400h | 1400h | SCUDIF | Rel-5 | Gwiho |  | 29.007, 27.001, 24.008 | Ericsson | Rune.Werner.Wiik@ericsson.no |

Notes:
- 1127: -
- 1128: -
- 1129: -
- 1130: -
- 1131: IP 30/11/01: Input awaited from GERAN2 to CN4 / 17 May Work complete 100%
- 1132: -
- 1133: -
- 1134: -
- 1135: Completed 11/2001
- 1136: Not started. Marked as stopped 12/2008
- 1137: Not started. Marked as stopped 12/2008
- 1138: Completed for Rel-5
- 1139: -
- 1140: -
- 1141: -
- 1142: -
- 1143: -
- 1144: -
- 1145: -
- 1146: -
- 1147: -
- 1148: Marked as stopped 12/2008
- 1149: -
- 1150: -

| ID | WBS | Task | Duration | Start | Finish | Complete | Baseline start | Baseline finish | Baseline duration | Constraint | Resources | Work | Actual work | Text1 | Text4 | Text5 | Text6 | Text8 | Text12 |
| --- | --- | --- | --- | --- | --- | --- | --- | --- | --- | --- | --- | --- | --- | --- | --- | --- | --- | --- | --- |
| 1151 | 103 | **Rel-5 USIM toolkit enhancements** | 865d | 2000-06-05 A | 2003-09-26 A | 100% | 2000-06-05 | 2003-09-26 | 865d |  | T3 | 24352h | 24352h | USAT1-Interpr | G & D | Michael Meyer | Rel-5 | Xavier |  |
| 1152 | 103.1 | Deleted - Test specification for USIM toolkit security mechanisms | 349d | 2002-05-28 A | 2003-09-26 A | 100% | 2002-05-28 | 2003-09-26 | 349d | finish no earlier than 2003-09-26 | T3 | 2792h | 2792h |  | Gemplus | Sophie Viallet | Rel-5 |  | TP-21 |
| 1153 | 103.2 | **Protocol Standardisation of a SIM Toolkit Interpreter** | 688d | 2000-06-05 A | 2003-01-22 A | 100% | 2000-06-05 | 2003-01-22 | 688d |  | T3 | 12512h | 12512h | USAT1-Interpr | G & D | Michael Meyer | Rel-5 | Xavier |  |
| 1154 | 103.2.1 | Stage 1 | 205d | 2000-06-05 A | 2001-03-16 A | 100% | 2000-06-05 | 2001-03-16 | 205d | finish no earlier than 2001-03-16 | T3 | 1640h | 1640h | USAT1-Interpr |  |  | Rel-5 | Xavier |  |
| 1155 | 103.2.2 | Stage 2 and 3 | 308d | 2001-01-03 A | 2002-03-08 A | 100% | 2001-01-03 | 2002-03-08 | 308d | finish no earlier than 2002-03-08 | T3 | 2464h | 2464h | USAT1-Interpr |  |  | Rel-5 | Xavier |  |
| 1156 | 103.2.3 | Test specification | 363d | 2001-09-03 A | 2003-01-22 A | 100% | 2001-09-03 | 2003-01-22 | 363d | finish no earlier than 2003-01-22 | T3 | 2904h | 2904h | USAT1-Interpr | Gemplus | Gérald MAUNIER | Rel-5 | Xavier |  |
| 1157 | 103.4 | **(U)SIM API** | 133d | 2002-03-20 A | 2002-09-20 A | 100% | 2002-03-20 | 2002-09-20 | 133d |  | T3 | 2128h | 2128h | USAT1-API | Microelectrónica Española | Mario Pérez | Rel-5 | Xavier |  |
| 1158 | 103.4.1 | Java API Test specification | 133d | 2002-03-20 A | 2002-09-20 A | 100% | 2002-03-20 | 2002-09-20 | 133d | finish no earlier than 2002-09-20 | T3 | 1064h | 1064h | USAT1-API | Microelectrónica Española | Mario Pérez | Rel-5 | Xavier |  |
| 1159 | 104 | **small Technical Enhancements and Improvements for Rel5** | 2349d? | 2000-01-03 A | 2008-12-31 A | 100% | 2000-01-03 | 2008-12-31 | 2349d? |  | All | 18792h | 18792h | TEI5 |  |  | Rel-5 |  |  |
| 1160 | 395.1 | Small Technical Enhancements and Improvements for Rel-5 Conformance Testing | 2349d? | 2000-01-03 A | 2008-12-31 A | 100% | 2000-01-03 | 2008-12-31 | 2349d? | finish no earlier than 2008-12-31 | R5,T1 | 18792h | 18792h | TEI5_Test |  |  | Rel-5 | Ingbert |  |
| 1161 | 106 | **User Equipment Management** | 267d | 2001-06-21 A | 2002-06-28 A | 100% | 2001-06-21 | 2002-06-28 | 267d |  | S5 | 3752h | 3752h | UEM | Vodafone | john.mudge@vf.vodafone.co.uk | Rel-5 | Dionisio |  |
| 1162 | 106.1 | FS on User Equipment (UE) Management | 267d | 2001-06-21 A | 2002-06-28 A | 100% | 2001-06-21 | 2002-06-28 | 267d | finish no earlier than 2002-06-28 | S5 | 2136h | 2136h | OAM-UEM | Vodafone | john.mudge@vf.vodafone.co.uk | Rel-5 | Dionisio |  |
| 1163 | 107 | **Flow control supporting an MS with multiple data flows with different QoS over the Gb interface** | 50d | 2002-06-24 A | 2002-08-30 A | 100% | 2002-06-24 | 2002-08-30 | 50d |  | GP | 1288h | 1288h | FlowCon | Ericsson | ingemar.backlund@era.ericsson.se | Rel-5 | Paolo |  |
| 1164 | 107.1 | **Update of stage 2 specifications** | 50d | 2002-06-24 A | 2002-08-30 A | 100% | 2002-06-24 | 2002-08-30 | 50d |  | GP | 808h | 808h |  |  |  | Rel-5 | Paolo |  |
| 1165 | 107.1.1 | Concept document 23.060 (changes to) | 46d | 2002-06-28 A | 2002-08-30 A | 100% | 2002-06-28 | 2002-08-30 | 46d | finish no earlier than 2002-08-30 | S2 | 368h | 368h |  |  |  | Rel-5 | Maurice |  |
| 1166 | 107.1.2 | Flow Control | 5d | 2002-06-24 A | 2002-06-28 A | 100% | 2002-06-24 | 2002-06-28 | 5d | finish no earlier than 2002-06-28 | GP | 40h | 40h |  |  |  | Rel-5 | Paolo |  |
| 1167 | 107.2 | **Modification of BSSGP protocol** | 5d | 2002-06-24 A | 2002-06-28 A | 100% | 2002-06-24 | 2002-06-28 | 5d |  | GP | 80h | 80h |  | Ericsson | ingemar.backlund@era.ericsson.se | Rel-5 | Paolo |  |
| 1168 | 107.2.1 | Stage 3 (changes to 48.018) | 5d | 2002-06-24 A | 2002-06-28 A | 100% | 2002-06-24 | 2002-06-28 | 5d | finish no earlier than 2002-06-28 | G2 | 40h | 40h |  |  |  | Rel-5 | Gert |  |
| 1169 | 108 | **Deleted - Multiple TBF in A/Gb mode - Phase 1** | 421d | 2002-04-19 A | 2003-11-28 A | 100% | 2002-04-19 | 2003-11-28 | 421d |  | GP | 17480h | 17480h | MULTBF | Ericsson | gunnar.mildh@era.ericsson.se | Rel-5 | Paolo | GP-17 |
| 1170 | 108.1 | **Deleted - Multiple TBF in A/Gb mode - Phase 1** | 351d | 2002-04-19 A | 2003-08-22 A | 100% | 2002-04-19 | 2003-08-22 | 351d |  | GP | 8112h | 8112h | MULTBF-Agbmode |  |  | Rel-5 | Paolo | GP-17 |
| 1171 | 108.1.1 | Deleted - Multiple TBF Concept paper | 351d | 2002-04-19 A | 2003-08-22 A | 100% | 2002-04-19 | 2003-08-22 | 351d | finish no earlier than 2003-08-22 | GP | 2808h | 2808h | MULTBF-Agbmode |  |  | Rel-5 | Paolo | GP-17 |
| 1172 | 108.1.2 | Deleted - Multiple TBF Stage 2 (43.064) CRs | 156d | 2002-04-19 A | 2002-11-22 A | 100% | 2002-04-19 | 2002-11-22 | 156d | finish no earlier than 2002-11-22 | G1 | 1248h | 1248h | MULTBF-Agbmode |  |  | Rel-5 | Paolo | GP-12 |
| 1173 | 108.1.3 | Deleted - Multiple TBF Stage 3 (44.060) CRs | 156d | 2002-04-19 A | 2002-11-22 A | 100% | 2002-04-19 | 2002-11-22 | 156d | finish no earlier than 2002-11-22 | G2 | 1248h | 1248h | MULTBF-Agbmode |  |  | Rel-5 | Gert | GP-12 |
| 1174 | 108.2 | **Deleted - Multiple TBF in A/Gb mode – MS testing** | 375d | 2002-06-24 A | 2003-11-28 A | 100% | 2002-06-24 | 2003-11-28 | 375d |  | GP | 6000h | 6000h |  | Ericsson | ingemar.backlund@era.ericsson.se | Rel-5 | Paolo | GP-17 |
| 1175 | 108.2.1 | Deleted - MS conformance tests | 375d | 2002-06-24 A | 2003-11-28 A | 100% | 2002-06-24 | 2003-11-28 | 375d | finish no earlier than 2003-11-28 | G4 | 3000h | 3000h |  |  |  | Rel-5 | Paolo | GP-17 |

Notes:
- 1151: -
- 1152: Marked as stopped 12/2008
- 1153: 28/5/2001: T3-19 proposed that since the stage 2 and 3 will not be presented to TP-12 for approval as expected, the WI will be moved to rel-5, with completion expected at TP-13. / Text3: 27.103
- 1154: 5/10/2001: Stage one comepeted at TP-12.
- 1155: 5/10/2001: TS 31.112 and 31.113 approved at TP-13. TS 31.114 to be presented to TP-14.
- 1156: 5/10/2001: Work started on test specification. Marked as closed 12/2008 (was marked 12% complete)
- 1157: 8/3/2001: test spec is based on R99 core spec, so deleted from Workplan
- 1158: -
- 1159: "Joker" WI, to be used for a Rel 5 CR not related to any feature and with very limited impact on the system
- 1160: "Joker" WI, to be used for small modifications applicable to Rel 5 conformance testing. Moved in from Stoyan/testing WP. / Text3: 34.108, 34.109, 34.121-1, 34.121-2, 34.122, 34.123-1, 34.123-2, 34.123-3, 34.171, 34.229-1, 34.229-2, 34.229-3
- 1161: - / Text3: 32.802
- 1162: - / Text3: 32.802
- 1163: 50101 -> 50201
- 1164: 50102 -> 50202
- 1165: -
- 1166: 50103 -> 50203
- 1167: -
- 1168: -
- 1169: GP#17 Nov 2003 Moved to Rel-6 as UID_50600 MULTBF (Only Multiple TBF Concept paper produced in Rel-5)
- 1170: Marked as closed 12/2008 (was marked 26% complete)
- 1171: Marked as closed 12/2008 (was marked 50% complete)
- 1172: Marked as stopped 12/2008
- 1173: Marked as stopped 12/2008
- 1174: 08/08: duplicate UID_50106=-> 50206. Marked as stopped 12/2008
- 1175: Not started. Marked as stopped 12/2008

| ID | WBS | Task | Duration | Start | Finish | Complete | Baseline start | Baseline finish | Baseline duration | Constraint | Resources | Work | Actual work | Text1 | Text4 | Text5 | Text6 | Text8 |
| --- | --- | --- | --- | --- | --- | --- | --- | --- | --- | --- | --- | --- | --- | --- | --- | --- | --- | --- |
| 1176 | 109 | **Alignment of 3G functional split and Iu** | 922d | 2000-06-08 A | 2003-12-19 A | 100% | 2000-06-08 | 2003-12-19 | 922d |  | GP | 126664h | 126664h | GER3GAL | Ericsson | Frank Muller | Rel-5 | Paolo |
| 1177 | 109.1 | **GERAN user / control plane** | 540d | 2000-08-07 A | 2002-08-30 A | 100% | 2000-08-07 | 2002-08-30 | 540d |  | GP | 36232h | 36232h | GER3GAL-GUCOPL | Ericsson | Frank Muller | Rel-5 | Paolo |
| 1178 | 109.1.1 | **Alignment with UMTS bearer concept** | 540d | 2000-08-07 A | 2002-08-30 A | 100% | 2000-08-07 | 2002-08-30 | 540d |  | GP | 24952h | 24952h |  |  |  | Rel-5 | Paolo |
| 1179 | 109.1.1.1 | Enhanced power control | 1d | 2001-08-31 A | 2001-08-31 A | 100% | 2001-08-31 | 2001-08-31 | 1d | finish no earlier than 2001-08-31 | GP | 8h | 8h |  |  |  | Rel-5 | Paolo |
| 1180 | 109.1.1.2 | Stage 2 | 235d | 2000-08-07 A | 2001-06-29 A | 100% | 2000-08-07 | 2001-06-29 | 235d | finish no earlier than 2001-06-29 | GP | 1880h | 1880h |  |  |  | Rel-5 | Paolo |
| 1181 | 109.1.1.3 | Adoption of the UTRAN PDCP | 295d | 2000-11-06 A | 2001-12-21 A | 100% | 2000-11-06 | 2001-12-21 | 295d | finish no earlier than 2001-12-21 | GP | 2360h | 2360h |  |  |  | Rel-5 | Paolo |
| 1182 | 109.1.1.4 | Development of RLC / MAC | 261d | 2001-08-31 A | 2002-08-30 A | 100% | 2001-08-31 | 2002-08-30 | 261d | finish no earlier than 2002-08-30 | GP | 2088h | 2088h |  |  |  | Rel-5 | Paolo |
| 1183 | 109.1.1.5 | Development of GERAN RRC | 266d | 2001-06-22 A | 2002-06-28 A | 100% | 2001-06-22 | 2002-06-28 | 266d | finish no earlier than 2002-06-28 | GP | 2128h | 2128h |  |  |  | Rel-5 | Paolo |
| 1184 | 109.1.1.6 | Ciphering and integrity protection concept paper | 166d | 2001-08-31 A | 2002-04-19 A | 100% | 2001-08-31 | 2002-04-19 | 166d | finish no earlier than 2002-04-19 | GP | 1328h | 1328h |  |  |  | Rel-5 | Paolo |
| 1185 | 109.1.1.7 | Multiple TBF or equivalent Concept paper | 116d | 2001-08-31 A | 2002-02-08 A | 100% | 2001-08-31 | 2002-02-08 | 116d | finish no earlier than 2002-02-08 | GP | 928h | 928h |  |  |  | Rel-5 | Paolo |
| 1186 | 109.1.1.8 | Paging concept | 166d | 2001-08-31 A | 2002-04-19 A | 100% | 2001-08-31 | 2002-04-19 | 166d | finish no earlier than 2002-04-19 | GP | 1328h | 1328h |  |  |  | Rel-5 | Paolo |
| 1187 | 109.1.1.9 | Dedicated Physical subchannels, includes traffic and control channels | 66d | 2001-08-31 A | 2001-11-30 A | 100% | 2001-08-31 | 2001-11-30 | 66d | finish no earlier than 2001-11-30 | GP | 528h | 528h |  |  |  | Rel-5 | Paolo |
| 1188 | 109.1.1.10 | Iu support and broadcast concept | 166d | 2001-08-31 A | 2002-04-19 A | 100% | 2001-08-31 | 2002-04-19 | 166d | finish no earlier than 2002-04-19 | GP | 1328h | 1328h |  |  |  | Rel-5 | Paolo |
| 1189 | 109.1.1.11 | Impact of using RLC instead of LAPDm concept | 116d | 2001-08-31 A | 2002-02-08 A | 100% | 2001-08-31 | 2002-02-08 | 116d | finish no earlier than 2002-02-08 | GP | 928h | 928h |  |  |  | Rel-5 | Paolo |
| 1190 | 109.1.1.12 | Contention resolution, mobile station identity, and access concept | 66d | 2001-08-31 A | 2001-11-30 A | 100% | 2001-08-31 | 2001-11-30 | 66d | finish no earlier than 2001-11-30 | GP | 528h | 528h |  |  |  | Rel-5 | Paolo |
| 1191 | 109.1.1.13 | PDCP concept | 166d | 2001-08-31 A | 2002-04-19 A | 100% | 2001-08-31 | 2002-04-19 | 166d | finish no earlier than 2002-04-19 | GP | 1328h | 1328h |  |  |  | Rel-5 | Paolo |
| 1192 | 109.1.1.14 | Downlink delayed TBF release | 261d | 2001-08-31 A | 2002-08-30 A | 100% | 2001-08-31 | 2002-08-30 | 261d | finish no earlier than 2002-08-30 | GP | 2088h | 2088h |  |  |  | Rel-5 | Paolo |
| 1193 | 109.1.1.15 | Add transparent RLC Concept | 116d | 2001-08-31 A | 2002-02-08 A | 100% | 2001-08-31 | 2002-02-08 | 116d | finish no earlier than 2002-02-08 | GP | 928h | 928h |  |  |  | Rel-5 | Paolo |
| 1194 | 109.1.1.16 | Handover concept | 116d | 2001-08-31 A | 2002-02-08 A | 100% | 2001-08-31 | 2002-02-08 | 116d | finish no earlier than 2002-02-08 | GP | 928h | 928h |  |  |  | Rel-5 | Paolo |
| 1195 | 109.1.2 | **Physical layer alignment with UMTS bearer concept** | 280d | 2000-11-06 A | 2001-11-30 A | 100% | 2000-11-06 | 2001-11-30 | 280d |  | GP | 6960h | 6960h |  |  |  | Rel-5 | Paolo |
| 1196 | 109.1.2.1 | PDTCH/TCH in 45.003 | 155d | 2000-11-06 A | 2001-06-08 A | 100% | 2000-11-06 | 2001-06-08 | 155d | finish no earlier than 2001-06-08 | GP | 1240h | 1240h |  |  |  | Rel-5 | Paolo |
| 1197 | 109.1.2.2 | Control channels in 45.003 | 155d | 2000-11-06 A | 2001-06-08 A | 100% | 2000-11-06 | 2001-06-08 | 155d | finish no earlier than 2001-06-08 | GP | 1240h | 1240h |  |  |  | Rel-5 | Paolo |
| 1198 | 109.1.2.3 | Receiver performance in 45.005 for PDTCH/TCH and control channels | 280d | 2000-11-06 A | 2001-11-30 A | 100% | 2000-11-06 | 2001-11-30 | 280d | finish no earlier than 2001-11-30 | GP | 2240h | 2240h |  |  |  | Rel-5 | Paolo |
| 1199 | 109.2 | **Iu rg interface** | 430d | 2000-11-06 A | 2002-06-28 A | 100% | 2000-11-06 | 2002-06-28 | 430d |  | GP,RP | 39560h | 39560h | GER3GAL-Iurg | Ericsson | Frank Muller | Rel-5 | Paolo |
| 1200 | 109.2.1 | **Inter BSS interface** | 430d | 2000-11-06 A | 2002-06-28 A | 100% | 2000-11-06 | 2002-06-28 | 430d |  | GP,RP | 20640h | 20640h |  |  |  | Rel-5 | Paolo |
| 1201 | 109.2.1.1 | Identification of requirements | 430d | 2000-11-06 A | 2002-06-28 A | 100% | 2000-11-06 | 2002-06-28 | 430d | finish no earlier than 2002-06-28 | GP | 3440h | 3440h |  |  |  | Rel-5 | Paolo |
| 1202 | 109.2.1.2 | Stage 2 | 430d | 2000-11-06 A | 2002-06-28 A | 100% | 2000-11-06 | 2002-06-28 | 430d | finish no earlier than 2002-06-28 | GP | 3440h | 3440h |  |  |  | Rel-5 | Paolo |
| 1203 | 109.2.1.3 | Adoption of relevant parts from Iur | 430d | 2000-11-06 A | 2002-06-28 A | 100% | 2000-11-06 | 2002-06-28 | 430d | finish no earlier than 2002-06-28 | GP | 3440h | 3440h |  |  |  | Rel-5 | Paolo |
| 1204 | 109.2.1.4 | Complementation with GERAN specifics | 430d | 2000-11-06 A | 2002-06-28 A | 100% | 2000-11-06 | 2002-06-28 | 430d | finish no earlier than 2002-06-28 | GP | 3440h | 3440h |  |  |  | Rel-5 | Paolo |
| 1205 | 109.2.1.5 | Stage 3 | 430d | 2000-11-06 A | 2002-06-28 A | 100% | 2000-11-06 | 2002-06-28 | 430d | finish no earlier than 2002-06-28 | GP | 3440h | 3440h |  |  |  | Rel-5 | Paolo |

Notes:
- 1176: AWS, Nokia, Ericsson, Nortel, Siemens, Vodafone
- 1177: AWS, Nokia, Ericsson, Nortel, Siemens, Vodafone
- 1178: -
- 1179: -
- 1180: -
- 1181: Responsible is GERAN; RAN WG2 help may be needed.
- 1182: -
- 1183: -
- 1184: -
- 1185: -
- 1186: -
- 1187: -
- 1188: -
- 1189: -
- 1190: -
- 1191: -
- 1192: -
- 1193: -
- 1194: -
- 1195: -
- 1196: -
- 1197: -
- 1198: -
- 1199: AWS, Nokia, Ericsson, Nortel, Siemens, Vodafone
- 1200: -
- 1201: -
- 1202: -
- 1203: -
- 1204: -
- 1205: -

| ID | WBS | Task | Duration | Start | Finish | Complete | Baseline start | Baseline finish | Baseline duration | Constraint | Resources | Work | Actual work | Text6 | Text8 | Text12 | Text1 | Text4 | Text5 |
| --- | --- | --- | --- | --- | --- | --- | --- | --- | --- | --- | --- | --- | --- | --- | --- | --- | --- | --- | --- |
| 1206 | 109.2.2 | **Inter BSS-RNS interface** | 430d | 2000-11-06 A | 2002-06-28 A | 100% | 2000-11-06 | 2002-06-28 | 430d |  | GP,RP | 15480h | 15480h | Rel-5 | Paolo |  |  |  |  |
| 1207 | 109.2.2.1 | Identification of requirements | 430d | 2000-11-06 A | 2002-06-28 A | 100% | 2000-11-06 | 2002-06-28 | 430d | start no earlier than 2000-11-06 | GP,R3 | 3440h | 3440h | Rel-5 | Paolo |  |  |  |  |
| 1208 | 109.2.2.2 | Stage 2 | 430d | 2000-11-06 A | 2002-06-28 A | 100% | 2000-11-06 | 2002-06-28 | 430d | finish no earlier than 2002-06-28 | GP,R3 | 3440h | 3440h | Rel-5 | Paolo |  |  |  |  |
| 1209 | 109.2.2.3 | Adoption of relevant parts from Iur | 430d | 2000-11-06 A | 2002-06-28 A | 100% | 2000-11-06 | 2002-06-28 | 430d | finish no earlier than 2002-06-28 | GP,R3 | 3440h | 3440h | Rel-5 | Paolo |  |  |  |  |
| 1210 | 109.2.2.4 | Complementation with GERAN specifics | 107.5d | 2002-01-30 A | 2002-06-28 A | 100% | 2002-01-30 | 2002-06-28 | 107.5d | finish no earlier than 2002-06-28 | GP,R3 | 860h | 860h | Rel-5 | Paolo |  |  |  |  |
| 1211 | 109.2.2.5 | Stage 3 | 107.5d | 2002-01-30 A | 2002-06-28 A | 100% | 2002-01-30 | 2002-06-28 | 107.5d | finish no earlier than 2002-06-28 | GP,R3 | 860h | 860h | Rel-5 | Paolo |  |  |  |  |
| 1212 | 109.3 | **Voice over GERAN PS and CS concept** | 430d | 2000-11-06 A | 2002-06-28 A | 100% | 2000-11-06 | 2002-06-28 | 430d |  | GP,R3 | 18520h | 18520h | Rel-5 | Paolo |  |  |  |  |
| 1213 | 109.3.1 | Architecture for A, Iu cs and Iu ps | 430d | 2000-11-06 A | 2002-06-28 A | 100% | 2000-11-06 | 2002-06-28 | 430d | finish no earlier than 2002-06-28 | GP,R3 | 3440h | 3440h | Rel-5 | Paolo |  |  |  |  |
| 1214 | 109.3.2 | Transcoder position/operation | 115d | 2000-11-06 A | 2001-04-13 A | 100% | 2000-11-06 | 2001-04-13 | 115d | finish no earlier than 2001-04-13 | GP | 920h | 920h | Rel-5 | Paolo |  |  |  |  |
| 1215 | 109.3.3 | Handover | 430d | 2000-11-06 A | 2002-06-28 A | 100% | 2000-11-06 | 2002-06-28 | 430d | finish no earlier than 2002-06-28 | GP,R3 | 3440h | 3440h | Rel-5 | Paolo |  |  |  |  |
| 1216 | 109.3.4 | RTP payload | 430d | 2000-11-06 A | 2002-06-28 A | 100% | 2000-11-06 | 2002-06-28 | 430d | finish no earlier than 2002-06-28 | GP,R3 | 3440h | 3440h | Rel-5 | Paolo |  |  |  |  |
| 1217 | 109.3.5 | Codec renegotiation concept | 365d | 2000-11-06 A | 2002-03-29 A | 100% | 2000-11-06 | 2002-03-29 | 365d | finish no earlier than 2002-03-29 | GP,R3 | 2920h | 2920h | Rel-5 | Paolo |  |  |  |  |
| 1218 | 109.3.6 | LA | 115d | 2000-11-06 A | 2001-04-13 A | 100% | 2000-11-06 | 2001-04-13 | 115d | finish no earlier than 2001-04-13 | GP | 920h | 920h | Rel-5 | Paolo |  |  |  |  |
| 1219 | 109.4 | **Deleted - GERAN MS Conformance test for GERAN interface evolution** | 660d | 2001-06-11 A | 2003-12-19 A | 100% | 2001-06-11 | 2003-12-19 | 660d |  | GP | 10560h | 10560h | Rel-5 | Paolo | GP-17 |  |  |  |
| 1220 | 109.4.1 | Deleted - MS test | 660d | 2001-06-11 A | 2003-12-19 A | 100% | 2001-06-11 | 2003-12-19 | 660d | finish no earlier than 2003-12-19 | GP | 5280h | 5280h | Rel-5 | Paolo | GP-17 |  |  |  |
| 1221 | 109.5 | **GERAN BSS Conformance test for GERAN interface evolution** | 922d | 2000-06-08 A | 2003-12-19 A | 100% | 2000-06-08 | 2003-12-19 | 922d |  | GP | 14752h | 14752h | Rel-5 | Paolo |  |  |  |  |
| 1222 | 109.5.1 | Deleted - BSS test | 922d | 2000-06-08 A | 2003-12-19 A | 100% | 2000-06-08 | 2003-12-19 | 922d | finish no earlier than 2003-12-19 | GP | 7376h | 7376h | Rel-5 | Paolo | GP-17 |  |  |  |
| 1223 | 110 | **GERAN support for IMS** | 690d | 2000-05-01 A | 2002-12-20 A | 100% | 2000-05-01 | 2002-12-20 | 690d |  | GP | 39198.4h | 39198.4h | Rel-5 | Paolo |  | GERIMS | Nokia | Shkumbin Hamiti |
| 1224 | 110.1 | **GERAN Header adaptation** | 690d | 2000-05-01 A | 2002-12-20 A | 100% | 2000-05-01 | 2002-12-20 | 690d |  | GP,S2,RP | 12302.8h | 12302.8h | Rel-5 | Paolo |  | GERIMS-HEADAPT | Nokia | Shkumbin Hamiti |
| 1225 | 110.1.1 | Definition of compression and removal modes for PDCP protocol | 15.05d | 2000-05-01 A | 2000-06-09 A | 100% | 2000-05-01 | 2000-06-09 | 15.05d | finish no earlier than 2000-09-01 | GP,S2,RP | 120.4h | 120.4h | Rel-5 | Paolo |  |  |  |  |
| 1226 | 110.1.2 | Conceptual description in stage 2 | 393d | 2000-05-01 A | 2001-10-31 A | 100% | 2000-05-01 | 2001-10-31 | 393d | finish no earlier than 2001-10-31 | GP,S2,RP | 3144h | 3144h | Rel-5 | Paolo |  |  |  |  |
| 1227 | 110.1.3 | Necessary changes on stage 3 regarding header removal | 439.8d | 2000-11-06 A | 2002-12-20 A | 100% | 2000-11-06 | 2002-12-20 | 439.8d | finish no earlier than 2002-12-20 | GP,S2,RP | 3518.4h | 3518.4h | Rel-5 | Paolo |  |  |  |  |
| 1228 | 110.2 | **Deleted - GERAN Radio access bearer design for IMS** | 430d | 2000-11-06 A | 2002-06-28 A | 100% | 2000-11-06 | 2002-06-28 | 430d |  | GP,S2,RP | 9287.6h | 9287.6h | Rel-5 | Paolo | GP-10 | GERIMS-RABDES | Nokia | Shkumbin Hamiti |
| 1229 | 110.2.1 | **Deleted - MuM control signalling for conversational multimedia services** | 430d | 2000-11-06 A | 2002-06-28 A | 100% | 2000-11-06 | 2002-06-28 | 430d |  | GP,S2,RP | 5847.6h | 5847.6h | Rel-5 | Paolo | GP-10 |  |  |  |
| 1230 | 110.2.1.1 | Deleted - Identification of requirements | 330d | 2000-11-06 A | 2002-02-08 A | 100% | 2000-11-06 | 2002-02-08 | 330d | finish no earlier than 2002-02-08 | GP,S2,RP | 2640h | 2640h | Rel-5 | Paolo | GP-08 |  |  |  |
| 1231 | 110.2.1.2 | Deleted - Necessary modifications due to SIP | 40d | 2002-05-06 A | 2002-06-28 A | 100% | 2002-05-06 | 2002-06-28 | 40d | finish no earlier than 2002-06-28 | GP,S2,RP | 320h | 320h | Rel-5 | Paolo | GP-10 |  |  |  |

Notes:
- 1206: -
- 1207: -
- 1208: -
- 1209: -
- 1210: -
- 1211: -
- 1212: -
- 1213: -
- 1214: -
- 1215: -
- 1216: -
- 1217: -
- 1218: -
- 1219: Not started. Marked as stopped 12/2008
- 1220: Not started. Marked as stopped 12/2008
- 1221: Not started. Marked as stopped 12/2008
- 1222: Not started. Marked as stopped 12/2008
- 1223: AWS, Nokia, Ericsson, Nortel, Siemens, Motorola
- 1224: AWS, Nokia, Ericsson, Nortel, Siemens, Motorola
- 1225: -
- 1226: -
- 1227: -
- 1228: TERMINATED - NOT STANDARDIZED. Marked as stopped 12/2008
- 1229: TERMINATED - NOT STANDARDIZED. Marked as stopped 12/2008
- 1230: TERMINATED - NOT STANDARDIZED
- 1231: TERMINATED - NOT STANDARDIZED

| ID | WBS | Task | Duration | Start | Finish | Complete | Baseline start | Baseline finish | Baseline duration | Total slack | Constraint | Resources | Work | Actual work | Text1 | Text4 | Text5 | Text6 | Text8 | Text12 | Text3 |
| --- | --- | --- | --- | --- | --- | --- | --- | --- | --- | --- | --- | --- | --- | --- | --- | --- | --- | --- | --- | --- | --- |
| 1232 | 110.3 | **Deleted - GERAN MS Conformance test for support of IMS** | 400d | 2001-06-11 A | 2002-12-20 A | 100% | 2001-06-11 | 2002-12-20 | 400d |  |  | GP | 6400h | 6400h | GERIMS-MSconf | Nokia | Shkumbin Hamiti | Rel-5 | Paolo | GP-12 |  |
| 1233 | 110.3.1 | Deleted - MS test | 400d | 2001-06-11 A | 2002-12-20 A | 100% | 2001-06-11 | 2002-12-20 | 400d |  | finish no earlier than 2002-12-20 | G4 | 3200h | 3200h |  |  |  | Rel-5 | Paolo | GP-12 |  |
| 1234 | 110.4 | **Deleted - GERAN BTS Conformance test for support of IMS** | 400d | 2001-06-11 A | 2002-12-20 A | 100% | 2001-06-11 | 2002-12-20 | 400d |  |  | GP | 6400h | 6400h | GERIMS-BTSconf | Nokia | Shkumbin Hamiti | Rel-5 | Paolo | GP-12 |  |
| 1235 | 110.4.1 | Deleted - BTS test | 400d | 2001-06-11 A | 2002-12-20 A | 100% | 2001-06-11 | 2002-12-20 | 400d |  | finish no earlier than 2002-12-20 | G3new | 3200h | 3200h |  |  |  | Rel-5 | Ingbert | GP-12 |  |
| 1236 | 401 | MS Conformance Testing of Dual Transfer Mode | 65d? | 2002-11-11 A | 2003-02-07 A | 100% | 2002-11-11 | 2003-02-07 | 65d? |  | finish no earlier than 2003-02-07 | G4,G5 | 520h | 520h | MSCTDTM | Vodafone | Dave Fox | Rel-5 | Paolo |  |  |
| 1237 | 402 | **Handling of early UEs** | 911d? | 2000-01-03 A | 2003-06-27 A | 100% | 2000-01-03 | 2003-06-27 | 911d? |  |  | S2 | 4488h | 4488h | LATE_UE |  |  | Rel-5 | Maurice |  |  |
| 1238 | 402.1 | Feasibility Study | 50d? | 2002-10-07 A | 2002-12-13 A | 100% | 2002-10-07 | 2002-12-13 | 50d? |  | finish no earlier than 2002-12-13 | S2 | 400h | 400h |  |  |  | Rel-5 | Maurice |  |  |
| 1239 | 402.2 | Stage 2 | 125d? | 2003-01-06 A | 2003-06-27 A | 100% | 2003-01-06 | 2003-06-27 | 125d? |  | start no earlier than 2003-01-06 | S2 | 1000h | 1000h |  |  |  | Rel-5 | Maurice |  |  |
| 1240 | 402.3 | FS for the Early Mobile Handling in UTRAN | 195d | 2002-09-09 A | 2003-06-06 A | 100% | 2002-09-09 | 2003-06-06 | 195d |  | finish no earlier than 2003-06-06 | R2 | 1560h | 1560h | FSEarlyUE | Vodafone | Alan Law | Rel-5 | Joern |  |  |
| 1241 | 402.4 | Note: Stage 3 RAN part not shown | 1d | 2000-01-03 A | 2000-01-03 A | 100% | 2000-01-03 | 2000-01-03 | 1d |  |  | RP | 8h | 8h |  |  |  | Rel-5 |  |  |  |
| 1242 | 403 | Release 4 Features | 1d? | 2000-01-03 | 2000-01-03 |  | 2000-01-03 | 2000-01-03 | 1d? | 3056d |  | NP,GP, RP,SP,TP | 8h |  |  |  |  | Rel-4 |  |  |  |
| 1243 | 15 | **Miscellaneous UE Conformance Testing Activities** | 958d | 2001-04-02 A | 2004-12-01 A | 100% | 2001-04-02 | 2004-12-01 | 958d |  |  | T1 | 36360h | 36360h | MISTST1 |  |  | Rel-4 | Ingbert |  |  |
| 1244 | 15.1 | Optimization of Test Time, RF Aspects (FDD) | 508d | 2001-09-24 A | 2003-09-03 A | 100% | 2001-09-24 | 2003-09-03 | 508d |  | finish no earlier than 2003-09-03 | T1 | 4064h | 4064h | MISTST1-OpFDD |  |  | Rel-4 | Ingbert |  | 34.121 |
| 1245 | 15.2 | Optimization of Test Time, RF Aspects (TDD) | 508d | 2001-09-24 A | 2003-09-03 A | 100% | 2001-09-24 | 2003-09-03 | 508d |  | finish no earlier than 2003-09-03 | T1 | 4064h | 4064h | MISTST1-OpTDD |  |  | Rel-4 | Ingbert |  | 34.122 |
| 1246 | 15.3 | Extensions to R99 Test cases | 139.4w | 2001-04-02 A | 2003-12-02 A | 100% | 2001-04-02 | 2003-12-02 | 139.4w |  | finish no earlier than 2003-12-02 | T1 | 5576h | 5576h | MISTST1-Ext |  |  | Rel-4 | Ingbert |  | 34.123 p 1,2 |
| 1247 | 15.4 | Extension to R99 Test cases - TTCN | 439d | 2002-06-28 A | 2004-03-03 A | 100% | 2002-06-28 | 2004-03-03 | 439d |  | finish no earlier than 2004-03-03 | T1 | 3512h | 3512h |  |  |  | Rel-4 | Ingbert |  |  |
| 1248 | 15.5 | Creation of R99 TCs for TDD - prose | 719d | 2001-10-01 A | 2004-07-01 A | 100% | 2001-10-01 | 2004-07-01 | 719d |  | finish no earlier than 2004-07-01 | T1 | 5752h | 5752h | MISTST1-TDD |  |  | Rel-4 | Ingbert |  | 34.123-1 |
| 1249 | 15.6 | Deleted - Creation of R99 TCs for TDD - TTCN | 587d | 2002-09-03 A | 2004-12-01 A | 100% | 2002-09-03 | 2004-12-01 | 587d |  | finish no earlier than 2004-12-01 | T1 | 4696h | 4696h |  |  |  | Rel-4 | Ingbert | TP-26 |  |
| 1250 | 15.7 | Deleted - Review all other work items for impact on new or exiting 34 series specs. | 25.8w | 2002-07-02 A | 2002-12-27 A | 100% | 2002-07-02 | 2002-12-27 | 25.8w |  | finish no earlier than 2002-12-27 | T1 | 1032h | 1032h | MISTST1 |  |  | Rel-4 | Ingbert | TP-18 | 34.121,122,123,125 |
| 1251 | 47 | Transparent End-to-End PS mobile streaming application | 253d | 2000-04-03 A | 2001-03-21 A | 100% | 2000-04-03 | 2001-03-21 | 253d |  | finish no earlier than 2000-12-29 | S4 | 2024h | 2024h | PSTREAM |  |  | Rel-4 | Paolo |  | 26.233, 26.234 |
| 1252 | 49 | **Transcoder-Free Operation** | 326d | 2000-01-03 A | 2001-03-30 A | 100% | 2000-01-03 | 2001-03-30 | 326d |  |  | N4,S2,N1 | 10448h | 10448h | TrFO |  |  | Rel-4 | Kimmo |  |  |
| 1253 | 49.1 | **Out-of-Band Transcoder Control solution** | 326d | 2000-01-03 A | 2001-03-30 A | 100% | 2000-01-03 | 2001-03-30 | 326d |  |  | N4 | 8448h | 8448h | TrFO-OoBTC | NEC | Toshiyuki Tamura (tamurato@aj.jp.nec.com) | Rel-4 | Kimmo |  |  |
| 1254 | 49.1.1 | implementation in UTRAN | 145d | 2000-09-11 A | 2001-03-30 A | 100% | 2000-09-11 | 2001-03-30 | 145d |  | finish no earlier than 2001-03-30 | R3 | 1160h | 1160h | TrFO-OoBTC-UTRAN | Siemens | Alexander Vesely | Rel-4 | Juha |  | 25.401, 25.410, 25.413, 25.415, 23.153 |
| 1255 | 49.1.2 | Impact on architecture, Principles and Terminology | 211d | 2000-01-03 A | 2000-10-20 A | 100% | 2000-01-03 | 2000-10-20 | 211d |  | finish no earlier than 2000-10-20 | S2 | 1680h | 1680h | TrFO-OoBTC |  |  | Rel-4 | Maurice |  |  |
| 1256 | 49.1.3 | Codec Negotiation between UE and MSC | 125d | 2000-08-14 A | 2001-02-02 A | 100% | 2000-08-14 | 2001-02-02 | 125d |  | finish no earlier than 2001-02-02 | N1 | 1000h | 1000h | TrFO-OoBTC | Motorola | Andrew Howell | Rel-4 | Frederic |  | 24.008, 23.009, 23.108, (29.002) |
| 1257 | 49.1.4 | Codec Negotiation inter MSC | 125d | 2000-07-03 A | 2000-12-22 A | 100% | 2000-07-03 | 2000-12-22 | 125d |  | finish no earlier than 2000-12-22 | N4 | 1000h | 1000h | TrFO-OoBTC |  |  | Rel-4 | Kimmo |  |  |
| 1258 | 49.1.5 | Bearer establishment inter MSC | 125d | 2000-07-03 A | 2000-12-22 A | 100% | 2000-07-03 | 2000-12-22 | 125d |  | finish no earlier than 2000-12-22 | N4 | 1000h | 1000h | TrFO-OoBTC |  |  | Rel-4 | Kimmo |  | 23.153 |

Notes:
- 1232: TERMINATED - NOT STANDARDIZED. Marked as stopped 12/2008
- 1233: TERMINATED - NOT STANDARDIZED. Marked as stopped 12/2008
- 1234: TERMINATED - NOT STANDARDIZED. Marked as stopped 12/2008
- 1235: TERMINATED - NOT STANDARDIZED. Marked as stopped 12/2008
- 1236: Needed to complete DTM (R99)
- 1237: -
- 1238: -
- 1239: -
- 1240: -
- 1241: -
- 1242: -
- 1243: -
- 1244: It is believed that the current R99 test spec. can be optimised for faster overall test times. Marked as stopped 12/2008 (was 70% complete)
- 1245: It is believed that the current R99 test spec. can be optimised for faster overall test times
- 1246: Further test coverage of the R99 specification to cover supplementry services. Marked as stopped 12/2008 (was 70% complete)
- 1247: Marked as closed 12/2008 (was marked 50% complete)
- 1248: Marked as closed 12/2008 (was marked 50% complete)
- 1249: Marked as stopped 12/2008
- 1250: Marked as stopped 12/2008
- 1251: -
- 1252: Lead given to CN4 from CN / [DAB 28/11/00]
- 1253: -
- 1254: moved according to NP-000575
- 1255: e.g. study cascading TrFO/TFO/TrFO
- 1256: the link to NP-000085has been deleted because refering to a R99 status sheet / One common set of codec negotiation procedures will be specified as in ID1656.
- 1257: Bearer establishment inter MSC. TS 23.153 R99 part complete. capabilities moved to annex + list of open issues
- 1258: Bearer establishment inter MSC. TS 23.153 R99 part complete. capabilities moved to annex. / See NP-000127 / Open issues: / Handling of Conference Calls; / Handling of Multi Party Supplementary Services; / Handling of Handover UMTS to GSM; / Handling of Sending a ...

| ID | WBS | Task | Duration | Start | Finish | Complete | Baseline start | Baseline finish | Baseline duration | Constraint | Resources | Work | Actual work | Text1 | Text6 | Text8 | Text4 | Text5 |
| --- | --- | --- | --- | --- | --- | --- | --- | --- | --- | --- | --- | --- | --- | --- | --- | --- | --- | --- |
| 1259 | 49.2 | **Speech Transcoder: Location and Control at the UMTS Core Network Border** | 125d | 2000-04-10 A | 2000-09-29 A | 100% | 2000-04-10 | 2000-09-29 | 125d |  | S2 | 2000h | 2000h | TrFO-STLC | Rel-4 | Maurice |  |  |
| 1260 | 49.2.1 | Transcoder at Edge | 125d | 2000-04-10 A | 2000-09-29 A | 100% | 2000-04-10 | 2000-09-29 | 125d | finish no earlier than 2000-09-29 | NP | 1000h | 1000h | TrFO-STLC | Rel-4 |  |  |  |
| 1261 | 50 | **GERAN improvements 1 (Gb over IP)** | 225d | 2000-05-09 A | 2001-03-19 A | 100% | 2000-05-09 | 2001-03-19 | 225d |  | GP | 6472h | 6472h | GEIMP1 | Rel-4 | Paolo |  |  |
| 1262 | 50.1 | **Gb over IP (Ip-fication of Gb)** | 225d | 2000-05-09 A | 2001-03-19 A | 100% | 2000-05-09 | 2001-03-19 | 225d |  | GP | 4672h | 4672h | GbIP | Rel-4 | Paolo |  |  |
| 1263 | 50.1.1 | Concept | 134d | 2000-05-09 A | 2000-11-10 A | 100% | 2000-05-09 | 2000-11-10 | 134d |  | GP | 1072h | 1072h |  | Rel-4 | Paolo |  |  |
| 1264 | 50.1.2 | Changes to 08.16, 08.18 | 225d | 2000-05-09 A | 2001-03-19 A | 100% | 2000-05-09 | 2001-03-19 | 225d |  | GP | 1800h | 1800h |  | Rel-4 | Paolo |  |  |
| 1265 | 51 | **GERAN improvements 2 (NACC)** | 677d | 2000-11-06 A | 2003-06-10 A | 100% | 2000-11-06 | 2003-06-10 | 677d |  | GP | 19224h | 19224h | GEIMP2 | Rel-4 | Paolo |  |  |
| 1266 | 51.1 | **Gb enhancements** | 155d | 2000-11-06 A | 2001-06-08 A | 100% | 2000-11-06 | 2001-06-08 | 155d |  | GP | 7440h | 7440h | Gben | Rel-4 | Paolo |  |  |
| 1267 | 51.1.1 | **Intra BSC NACC (Network Assisted Cell Change)** | 155d | 2000-11-06 A | 2001-06-08 A | 100% | 2000-11-06 | 2001-06-08 | 155d |  | GP | 6200h | 6200h |  | Rel-4 | Paolo |  |  |
| 1268 | 51.1.1.1 | Concept | 155d | 2000-11-06 A | 2001-06-08 A | 100% | 2000-11-06 | 2001-06-08 | 155d | finish no earlier than 2001-06-08 | GP | 1240h | 1240h |  | Rel-4 | Paolo |  |  |
| 1269 | 51.1.1.2 | Changes in 03.64 | 155d | 2000-11-06 A | 2001-06-08 A | 100% | 2000-11-06 | 2001-06-08 | 155d | finish no earlier than 2001-06-08 | GP | 1240h | 1240h |  | Rel-4 | Paolo |  |  |
| 1270 | 51.1.1.3 | Changes in 04.60 | 155d | 2000-11-06 A | 2001-06-08 A | 100% | 2000-11-06 | 2001-06-08 | 155d | finish no earlier than 2001-06-08 | GP | 1240h | 1240h |  | Rel-4 | Paolo |  |  |
| 1271 | 51.1.1.4 | Changes in 44.008 | 155d | 2000-11-06 A | 2001-06-08 A | 100% | 2000-11-06 | 2001-06-08 | 155d | finish no earlier than 2001-06-08 | GP | 1240h | 1240h |  | Rel-4 | Paolo |  |  |
| 1272 | 51.3 | **MS conformance test for Intra BSC NACC** | 398d | 2001-11-30 A | 2003-06-10 A | 100% | 2001-11-30 | 2003-06-10 | 398d |  | GP | 6368h | 6368h | GEIMP2-Msconf | Rel-4 | Paolo |  |  |
| 1273 | 51.3.1 | Changes in 51.010 | 398d | 2001-11-30 A | 2003-06-10 A | 100% | 2001-11-30 | 2003-06-10 | 398d | finish no earlier than 2003-12-19 | G5,G4 | 3184h | 3184h |  | Rel-4 | Paolo |  |  |
| 1274 | 52 | **GERAN improvements 4 (Delayed TBF)** | 105d | 2001-01-15 A | 2001-06-08 A | 100% | 2001-01-15 | 2001-06-08 | 105d |  | GP | 3960h | 3960h | GEIMP4 | Rel-4 | Paolo |  |  |
| 1275 | 52.1 | **Gb enhancements 2** | 105d | 2001-01-15 A | 2001-06-08 A | 100% | 2001-01-15 | 2001-06-08 | 105d |  | GP | 3120h | 3120h | GEIMP4-Gben2 | Rel-4 | Paolo |  |  |
| 1276 | 52.1.1 | stage 2 | 105d | 2001-01-15 A | 2001-06-08 A | 100% | 2001-01-15 | 2001-06-08 | 105d | finish no earlier than 2001-06-08 | GP | 840h | 840h |  | Rel-4 | Paolo |  |  |
| 1277 | 52.1.2 | **Stage 3 (changes in 44.060)** | 60d | 2001-01-15 A | 2001-04-06 A | 100% | 2001-01-15 | 2001-04-06 | 60d |  | G2 | 1440h | 1440h |  | Rel-4 | Gert |  |  |
| 1278 | 52.1.2.1 | Definition of enhanced countdown procedure | 60d | 2001-01-15 A | 2001-04-06 A | 100% | 2001-01-15 | 2001-04-06 | 60d | finish no earlier than 2001-04-06 | G2 | 480h | 480h |  | Rel-4 | Gert |  |  |
| 1279 | 52.1.2.2 | Definition of enhanced TBF release procedure | 60d | 2001-01-15 A | 2001-04-06 A | 100% | 2001-01-15 | 2001-04-06 | 60d | finish no earlier than 2001-04-06 | G2 | 480h | 480h |  | Rel-4 | Gert |  |  |
| 1280 | 52.1.2.3 | Definition of USF=FREE type polling mechanism on PDCH | 60d | 2001-01-15 A | 2001-04-06 A | 100% | 2001-01-15 | 2001-04-06 | 60d | finish no earlier than 2001-04-06 | G2 | 480h | 480h |  | Rel-4 | Gert |  |  |
| 1281 | 53 | **Low Chip Rate TDD option** | 880d | 2000-07-19 A | 2003-12-02 A | 100% | 2000-07-19 | 2003-12-02 | 880d |  | R1 | 27488h | 27488h | LCRTDD | Rel-4 | Patrick | CWTS | G. Yang |
| 1282 | 53.1 | Physical layer | 183d | 2000-07-19 A | 2001-03-30 A | 100% | 2000-07-19 | 2001-03-30 | 183d | finish no earlier than 2001-03-30 | R1 | 1464h | 1464h | LCRTDD-Phys | Rel-4 | Patrick | CWTS | G. Yang |
| 1283 | 53.2 | Layer 2 and layer 3 protocol aspects | 183d | 2000-07-19 A | 2001-03-30 A | 100% | 2000-07-19 | 2001-03-30 | 183d | finish no earlier than 2001-03-30 | R2 | 1464h | 1464h | LCRTDD-L23 | Rel-4 | Joern | CWTS | Y. Liu |
| 1284 | 53.3 | RF radio transmission/reception, system performance requirements and conformance testing | 165d | 2000-08-14 A | 2001-03-30 A | 100% | 2000-08-14 | 2001-03-30 | 165d | finish no earlier than 2001-03-30 | R4 | 1320h | 1320h | LCRTDD-RF | Rel-4 | Issam | CWTS | D. Zhang |
| 1285 | 53.4 | UE radio access capability | 165d | 2000-08-14 A | 2001-03-30 A | 100% | 2000-08-14 | 2001-03-30 | 165d | finish no earlier than 2001-03-30 | R2 | 1320h | 1320h | LCRTDD-UErac | Rel-4 | Joern | CWTS | Y. Liu |
| 1286 | 53.5 | Iub/Iur protocol aspects | 165d | 2000-08-14 A | 2001-03-30 A | 100% | 2000-08-14 | 2001-03-30 | 165d | finish no earlier than 2001-03-30 | R3 | 1320h | 1320h | LCRTDD-IubIur | Rel-4 | Juha | CWTS | Y. Liu |

Notes:
- 1259: WI description and Tdoc S2-99352 / Speech Transcoder: Location and Control at the UMTS Core Network Border
- 1260: WI description and Tdoc S2-99352...
- 1261: -
- 1262: -
- 1263: -
- 1264: -
- 1265: -
- 1266: -
- 1267: -
- 1268: -
- 1269: -
- 1270: -
- 1271: -
- 1272: -
- 1273: az 05/08: duplicated UID_50099 => 50299. Marked as closed 12/2008 (was marked 50% complete)
- 1274: -
- 1275: -
- 1276: -
- 1277: -
- 1278: -
- 1279: -
- 1280: -
- 1281: -
- 1282: -
- 1283: -
- 1284: -
- 1285: -
- 1286: -

| ID | WBS | Task | Duration | Start | Finish | Predecessors | Complete | Baseline start | Baseline finish | Baseline duration | Constraint | Resources | Work | Actual work | Text6 | Text8 | Text3 | Text12 | Text1 | Text4 | Text5 |
| --- | --- | --- | --- | --- | --- | --- | --- | --- | --- | --- | --- | --- | --- | --- | --- | --- | --- | --- | --- | --- | --- |
| 1287 | 53.6 | **Low chiprate TDD interworking with GERAN** | 101d | 2000-09-01 A | 2001-01-19 A | 1286 | 100% | 2000-09-01 | 2001-01-19 | 101d |  | GP | 1616h | 1616h | Rel-4 | Paolo |  |  |  |  |  |
| 1288 | 53.6.1 | Handover and Cell Selection / Reselection to UTRA 1.28 Mcps TDD | 101d | 2000-09-01 A | 2001-01-19 A |  | 100% | 2000-09-01 | 2001-01-19 | 101d | finish no earlier than 2001-01-19 | GP | 808h | 808h | Rel-4 |  |  |  |  |  |  |
| 1289 | 53.8 | **Conformance Test Aspects - Low Chip Rate TDD** | 577d | 2001-09-17 A | 2003-12-02 A | 1287 | 100% | 2001-09-17 | 2003-12-02 | 577d |  | T1 | 12088h | 12088h | Rel-4 | Ingbert |  |  |  |  |  |
| 1290 | 53.8.1 | Testing Layer 2 and layer 3 protocol aspects | 468d | 2001-09-17 A | 2003-07-02 A |  | 100% | 2001-09-17 | 2003-07-02 | 468d | finish no earlier than 2003-07-02 | T1 | 3744h | 3744h | Rel-4 | Ingbert | 34.123-1, 34.123-2 |  |  |  |  |
| 1291 | 53.8.2 | Deleted - Testing Layer 2 and layer 3 protocol aspects - TTCN | 261d | 2002-12-03 A | 2003-12-02 A |  | 100% | 2002-12-03 | 2003-12-02 | 261d | finish no earlier than 2003-12-02 | T1 | 2088h | 2088h | Rel-4 | Ingbert | 34.123-3 | TP-22 |  |  |  |
| 1292 | 53.8.3 | Testing RF Radio Transmission and Reception | 205d | 2001-09-17 A | 2002-06-28 A |  | 100% | 2001-09-17 | 2002-06-28 | 205d | finish no earlier than 2002-06-28 | T1 | 1640h | 1640h | Rel-4 | Ingbert |  |  |  |  |  |
| 1293 | 54 | **Enable bearer independent CS architecture** | 566d | 2000-01-03 A | 2002-03-01 A |  | 100% | 2000-01-03 | 2002-03-01 | 566d |  | S2 | 20192h | 20192h | Rel-4 | Maurice |  |  | CSSPLIT | Siemens | Alexander Milinski |
| 1294 | 54.1 | **Enable bearer-independent call control** | 425d | 2000-01-03 A | 2001-08-16 A |  | 100% | 2000-01-03 | 2001-08-16 | 425d |  | N4 | 12344h | 12344h | Rel-4 | Kimmo |  |  |  | Ericsson | Heinz-Peter.Keutmann@eed.ericsson.se |
| 1295 | 54.1.1 | Architecture and Stage 2 description | 181d | 2000-01-03 A | 2000-09-08 A |  | 100% | 2000-01-03 | 2000-09-08 | 181d | finish no earlier than 2000-09-08 | S2 | 1440h | 1440h | Rel-4 | Maurice | 23.002 |  |  |  |  |
| 1296 | 54.1.2 | Standardisation of protocols (control & user planes) over Nb interface | 64d | 2001-01-02 A | 2001-03-30 A |  | 100% | 2001-01-02 | 2001-03-30 | 64d | finish no earlier than 2001-03-30 | N3 | 512h | 512h | Rel-4 | Gwiho |  |  |  |  |  |
| 1297 | 54.1.3 | Standardisation of protocols over reference points between MSC server and Gateway MSC server | 130d | 2000-09-25 A | 2001-03-23 A |  | 100% | 2000-09-25 | 2001-03-23 | 130d | finish no earlier than 2001-03-23 | N4 | 1040h | 1040h | Rel-4 | Kimmo |  |  |  |  |  |
| 1298 | 54.1.4 | Standardisation of detailed stage 2 description | 180d | 2000-07-17 A | 2001-03-23 A |  | 100% | 2000-07-17 | 2001-03-23 | 180d | finish no earlier than 2001-03-23 | N4 | 1440h | 1440h | Rel-4 | Kimmo |  |  |  |  |  |
| 1299 | 54.1.5 | **Bearer control between MSC server and MGW** | 250d | 2000-09-01 A | 2001-08-16 A |  | 100% | 2000-09-01 | 2001-08-16 | 250d |  | N4 | 4512h | 4512h | Rel-4 | Kimmo |  |  |  |  |  |
| 1300 | 54.1.5.1 | stage 3 - protocol issues | 250d | 2000-09-01 A | 2001-08-16 A |  | 100% | 2000-09-01 | 2001-08-16 | 250d | finish no earlier than 2001-08-16 | N4 | 2000h | 2000h | Rel-4 | Kimmo |  |  |  |  |  |
| 1301 | 54.1.5.2 | stage 3 - parameter value issues | 64d | 2001-01-02 A | 2001-03-30 A |  | 100% | 2001-01-02 | 2001-03-30 | 64d | finish no earlier than 2001-03-30 | N3 | 512h | 512h | Rel-4 | Gwiho |  |  |  |  |  |
| 1302 | 54.2 | Lawful interception | 155d | 2000-08-21 A | 2001-03-23 A |  | 100% | 2000-08-21 | 2001-03-23 | 155d | finish no earlier than 2001-03-23 | S3 | 1240h | 1240h | Rel-4 | Dionisio |  |  |  |  |  |
| 1303 | 54.4 | Deleted - Conformance Test Aspects - Enable bearer independent CS architecture | 260d | 2001-03-05 A | 2002-03-01 A |  | 100% | 2001-03-05 | 2002-03-01 | 260d |  | T1 | 2080h | 2080h | Rel-4 | Ingbert |  | TP-15 | CSSPLIT-TEST |  |  |
| 1304 | 55 | **MExE enhancements Rel-4** | 511d | 2000-01-03 A | 2001-12-14 A |  | 100% | 2000-01-03 | 2001-12-14 | 511d |  | T2 | 19032h | 19032h | Rel-4 | Kimmo |  |  | MEXE |  |  |
| 1305 | 55.1 | **MExE Security Analysis Activity** | 474d | 2000-02-22 A | 2001-12-14 A |  | 100% | 2000-02-22 | 2001-12-14 | 474d |  | S3 | 8464h | 8464h | Rel-4 | Dionisio |  |  | MEXE-SEC | BT | colin.blanchard@bt.com |
| 1306 | 55.1.1 | Stage 3 | 370d | 2000-07-17 A | 2001-12-14 A |  | 100% | 2000-07-17 | 2001-12-14 | 370d | finish no earlier than 2001-12-14 | S3 | 2960h | 2960h | Rel-4 | Dionisio |  |  | MEXE1-SEC |  |  |
| 1307 | 55.1.2 | Terminal aspects | 214d | 2000-02-22 A | 2000-12-15 A |  | 100% | 2000-02-22 | 2000-12-15 | 214d | finish no earlier than 2000-12-15 | T2 | 1712h | 1712h | Rel-4 |  |  |  |  |  |  |
| 1308 | 55.2 | **MExE Rel4 Improvements and Investigations** | 251d | 2000-01-03 A | 2000-12-15 A |  | 100% | 2000-01-03 | 2000-12-15 | 251d |  | T2 | 6480h | 6480h | Rel-4 |  | 22.057, 23.057 |  | MEXE-ENHANC | Motorola | Mark Cataldo |
| 1309 | 55.2.1 | 3rd MExE classmark | 251d | 2000-01-03 A | 2000-12-15 A |  | 100% | 2000-01-03 | 2000-12-15 | 251d | finish no earlier than 2000-12-15 | T2 | 2000h | 2000h | Rel-4 |  | 22.057, 23.057 |  |  | Motorola | Mark Cataldo |
| 1310 | 55.2.2 | FS on Secure download mechanism and capabilities to support SDR concepts | 225d | 2000-02-07 A | 2000-12-15 A |  | 100% | 2000-02-07 | 2000-12-15 | 225d | finish no earlier than 2000-12-15 | T2 | 1800h | 1800h | Rel-4 |  | 22.057, 23.057 |  |  | Motorola | Mark Cataldo |
| 1311 | 55.2.3 | FS on Support of MP3/MPEG4 content | 225d | 2000-02-07 A | 2000-12-15 A |  | 100% | 2000-02-07 | 2000-12-15 | 225d | finish no earlier than 2000-12-15 | T2 | 1800h | 1800h | Rel-4 |  | 22.057, 23.057 |  |  | Motorola | Mark Cataldo |

Notes:
- 1287: -
- 1288: -
- 1289: -
- 1290: Marked as closed 12/2008 (was marked 60% complete)
- 1291: Marked as stopped 12/2008
- 1292: duration set to 6 months (was 0), finish date set
- 1293: -
- 1294: DAB 12.12.01 should be 100% hence closed
- 1295: R00 stage 2 at least 80 % complete in TSGS #8 21.-23.6.2000
- 1296: -
- 1297: -
- 1298: -
- 1299: -
- 1300: -
- 1301: -
- 1302: Requirements capture: S3#14 (Aug 00), Feature specification: S3#15 (Sep 00), Definition of architecture. Should be included in general LI work mentioned above.
- 1303: Marked as stopped 12/2008
- 1304: -
- 1305: Presentation to S3 of threats and countermeasures analysis: S3#15, Feature specification: S3#16. S3#18: WID updated
- 1306: Analysis undertaken by T2. No additional analysis needed for Rel-4
- 1307: -
- 1308: -
- 1309: Additional features for MExE R2000
- 1310: -
- 1311: -

| ID | WBS | Task | Duration | Start | Finish | Complete | Baseline start | Baseline finish | Baseline duration | Constraint | Resources | Work | Actual work | Text1 | Text6 | Text8 | Text3 | Text4 | Text5 |
| --- | --- | --- | --- | --- | --- | --- | --- | --- | --- | --- | --- | --- | --- | --- | --- | --- | --- | --- | --- |
| 1312 | 56 | **Tandem Free aspects for 3G and between 2G and 3G systems** | 344d | 2000-02-22 A | 2001-06-15 A | 100% | 2000-02-22 | 2001-06-15 | 344d |  | S4 | 9696h | 9696h | TFO | Rel-4 | Paolo |  |  |  |
| 1313 | 56.1 | **Tandem Free AMR** | 344d | 2000-02-22 A | 2001-06-15 A | 100% | 2000-02-22 | 2001-06-15 | 344d |  | S4 | 6944h | 6944h | TFO-AMR | Rel-4 | Paolo |  |  |  |
| 1314 | 56.1.1 | Specification | 284d | 2000-02-22 A | 2001-03-23 A | 100% | 2000-02-22 | 2001-03-23 | 284d | start no earlier than 2000-02-22 | S4 | 2272h | 2272h |  | Rel-4 | Paolo | 28.062 |  |  |
| 1315 | 56.1.2 | **Impact on:** | 115d | 2001-01-08 A | 2001-06-15 A | 100% | 2001-01-08 | 2001-06-15 | 115d |  | NP | 1920h | 1920h |  | Rel-4 | Kimmo |  |  |  |
| 1316 | 56.1.2.1 | CN | 60d | 2001-03-26 A | 2001-06-15 A | 100% | 2001-03-26 | 2001-06-15 | 60d | finish no earlier than 2001-06-15 | NP | 480h | 480h |  | Rel-4 | Kimmo |  |  |  |
| 1317 | 56.1.2.2 | GERAN | 65d | 2001-01-08 A | 2001-04-06 A | 100% | 2001-01-08 | 2001-04-06 | 65d | finish no earlier than 2001-04-06 | GP | 520h | 520h |  | Rel-4 | Paolo |  |  |  |
| 1318 | 57 | **Advanced Speech Call Items enhancements_REL-4** | 334d | 2000-12-03 A | 2002-03-14 A | 100% | 2000-12-03 | 2002-03-14 | 334d |  | N1 | 5925.6h | 5925.6h | ASCI | Rel-4 | Frederic |  | Nortel | sonia.garapaty@nortelnetworks.com |
| 1319 | 57.1 | Stage 2 | 326.7d | 2000-12-03 A | 2002-03-14 A | 100% | 2000-12-03 | 2002-03-14 | 326.7d | finish no earlier than 2002-03-14 | N4 | 2613.6h | 2613.6h |  | Rel-4 | Kimmo | 23.067, 24.067 | Sagem | Vivien Perlic |
| 1320 | 57.2 | Stages 2 and 3 on A interface | 80d | 2000-12-03 A | 2001-03-23 A | 100% | 2000-12-03 | 2001-03-23 | 80d | finish no earlier than 2001-03-23 | N1 | 640h | 640h |  | Rel-4 | Frederic | 44.068, 44.069, 24.008 | Nortel | sonia.garapaty@nortelnetworks.com |
| 1321 | 58 | **700 MHz spectrum support** | 776d | 2000-01-03 A | 2002-12-20 A | 100% | 2000-01-03 | 2002-12-20 | 776d |  | GP | 25016h | 25016h | 700SS | Rel-4 | Paolo |  |  |  |
| 1322 | 58.1 | **GERAN support for the 700 MHz band** | 276d | 2000-01-03 A | 2001-01-19 A | 100% | 2000-01-03 | 2001-01-19 | 276d |  | GP | 8808h | 8808h |  | Rel-4 | Paolo |  |  |  |
| 1323 | 58.1.1 | Signalling support | 276d | 2000-01-03 A | 2001-01-19 A | 100% | 2000-01-03 | 2001-01-19 | 276d | finish no earlier than 2001-01-19 | GP | 2200h | 2200h |  | Rel-4 | Paolo |  |  |  |
| 1324 | 58.1.2 | Physical layer definitions | 276d | 2000-01-03 A | 2001-01-19 A | 100% | 2000-01-03 | 2001-01-19 | 276d | finish no earlier than 2001-01-19 | GP | 2200h | 2200h |  | Rel-4 | Paolo |  |  |  |
| 1325 | 58.1.3 | Receiver performance and RF budget | 276d | 2000-01-03 A | 2001-01-19 A | 100% | 2000-01-03 | 2001-01-19 | 276d | finish no earlier than 2001-01-19 | GP | 2200h | 2200h |  | Rel-4 | Paolo |  |  |  |
| 1326 | 58.2 | **GERAN MS Conformance test for 700 MHz band** | 175d | 2001-04-02 A | 2001-11-30 A | 100% | 2001-04-02 | 2001-11-30 | 175d |  | GP | 2800h | 2800h |  | Rel-4 | Paolo |  |  |  |
| 1327 | 58.2.1 | MS test | 175d | 2001-04-02 A | 2001-11-30 A | 100% | 2001-04-02 | 2001-11-30 | 175d | finish no earlier than 2001-11-30 | GP | 1400h | 1400h |  | Rel-4 | Paolo |  |  |  |
| 1328 | 58.3 | **GERAN BTS Conformance test for 700 MHz band** | 450d | 2001-04-02 A | 2002-12-20 A | 100% | 2001-04-02 | 2002-12-20 | 450d |  | GP | 7200h | 7200h |  | Rel-4 | Paolo |  |  |  |
| 1329 | 58.3.1 | BTS test | 450d | 2001-04-02 A | 2002-12-20 A | 100% | 2001-04-02 | 2002-12-20 | 450d | finish no earlier than 2002-12-20 | GP | 3600h | 3600h |  | Rel-4 | Paolo |  |  |  |
| 1330 | 59 | Operator Determined Barring for Packet Oriented Services | 208d | 2000-06-01 A | 2001-03-19 A | 100% | 2000-06-01 | 2001-03-19 | 208d | finish no earlier than 2001-03-19 | NP | 1664h | 1664h | ODB | Rel-4 |  |  | NEC | Toshiyuki Tamura (tamurato@aj.jp.nec.com) |
| 1331 | 60 | **UMTS QoS Architecture for PS Domain** | 759d | 2000-01-03 A | 2002-11-27 A | 100% | 2000-01-03 | 2002-11-27 | 759d |  | S2 | 41312h | 41312h | QoSPS | Rel-4 | Maurice |  | Ericsson | Ina.widegren@era.ericsson.se |
| 1332 | 60.1 | Architecture | 153d | 2000-06-05 A | 2001-01-03 A | 100% | 2000-06-05 | 2001-01-03 | 153d | finish no earlier than 2001-01-03 | S2 | 1224h | 1224h |  | Rel-4 | Maurice | 23.107 |  |  |
| 1333 | 60.2 | Charging and OAM&P for QoS Management | 201d | 2001-09-21 A | 2002-06-28 A | 100% | 2001-09-21 | 2002-06-28 | 201d | finish no earlier than 2002-06-28 | S5 | 1608h | 1608h | QoSPS-OAM | Rel-4 | Dionisio | 32-series | VoiceStream, Motorola |  |
| 1334 | 60.3 | **RAB Quality of Service (re)Negotiation over Iu** | 155d | 2000-08-21 A | 2001-03-23 A | 100% | 2000-08-21 | 2001-03-23 | 155d |  | R3 | 3648h | 3648h | QoSPS-MAPEND-RABQoS | Rel-4 | Juha | 25.413 | Ericsson | A. Molander |
| 1335 | 60.3.1 | RAB Quality of Service Negotiation over Iu | 155d | 2000-08-21 A | 2001-03-23 A | 100% | 2000-08-21 | 2001-03-23 | 155d | finish no earlier than 2001-03-23 | R3 | 1240h | 1240h | QoSPS-MAPEND-RABQoS-Negot | Rel-4 | Juha |  | Ericsson | A. Molander |
| 1336 | 60.3.2 | RAB Quality of Service Negotiation over Iu during relocation | 16d | 2001-03-02 A | 2001-03-23 A | 100% | 2001-03-02 | 2001-03-23 | 16d | start no earlier than 2001-03-02 | R3 | 128h | 128h | QoSPS-MAPEND-RABQoS-NegotReloc | Rel-4 | Juha |  |  |  |
| 1337 | 60.3.3 | RAB Quality of Service Re-Negotiation over Iu | 130d | 2000-09-25 A | 2001-03-23 A | 100% | 2000-09-25 | 2001-03-23 | 130d | finish no earlier than 2001-03-23 | R3 | 1040h | 1040h | QoSPS-MAPEND-RABQoS-ReNegot | Rel-4 | Juha |  | Motorola | S. Irwin |

Notes:
- 1312: RAN and CN to verify no problems for GSM terminals roaming in 3G R99
- 1313: RAN and CN to verify UMTS_AMR_2 support
- 1314: -
- 1315: "Implementation" changed to "Impact on:" by A. Sultan (for better wording)
- 1316: RAN and CN to verify UMTS_AMR_2 support
- 1317: End date Modified from June to March to have it in Rel4
- 1318: Approved at CN#10
- 1319: CN4#11 30/11/02: no inputs received in CN4
- 1320: -
- 1321: -
- 1322: -
- 1323: -
- 1324: -
- 1325: -
- 1326: -
- 1327: -
- 1328: -
- 1329: -
- 1330: Completed WI missing from the P-plan Added for tracking
- 1331: -
- 1332: -
- 1333: -
- 1334: -
- 1335: -
- 1336: -
- 1337: -

| ID | WBS | Task | Duration | Start | Finish | Complete | Baseline start | Baseline finish | Baseline duration | Constraint | Resources | Work | Actual work | Text1 | Text6 | Text8 | Text12 | Text4 | Text5 | Text3 |
| --- | --- | --- | --- | --- | --- | --- | --- | --- | --- | --- | --- | --- | --- | --- | --- | --- | --- | --- | --- | --- |
| 1338 | 60.4 | **GERAN QoS Aspects - Handovers: maintenance of real-time QoS while moving between cells in the PLMN including inter-SGSN and SRNS relocation or possibly other mechanisms** | 501d | 2000-01-03 A | 2001-11-30 A | 100% | 2000-01-03 | 2001-11-30 | 501d |  | GP | 14456h | 14456h | GERQoS | Rel-4 | Paolo |  |  |  |  |
| 1339 | 60.4.1 | **Handover Concept for the PS domain** | 501d | 2000-01-03 A | 2001-11-30 A | 100% | 2000-01-03 | 2001-11-30 | 501d |  | GP | 10448h | 10448h |  | Rel-4 | Paolo |  |  |  |  |
| 1340 | 60.4.1.1 | Stable RT handover report 25.936 including header removal | 14d | 2000-01-03 A | 2000-01-19 A | 100% | 2000-01-03 | 2000-01-19 | 14d | start no earlier than 2000-01-03 | GP [92.9%] | 104h | 104h |  | Rel-4 | Paolo |  |  |  |  |
| 1341 | 60.4.1.2 | Update of stage 2 | 293d | 2000-01-03 A | 2001-02-13 A | 100% | 2000-01-03 | 2001-02-13 | 293d | finish no earlier than 2001-02-13 | GP | 2336h | 2336h |  | Rel-4 | Paolo |  |  |  |  |
| 1342 | 60.4.1.3 | Update of relevant stage 3 specs -> RRC | 501d | 2000-01-03 A | 2001-11-30 A | 100% | 2000-01-03 | 2001-11-30 | 501d | finish no earlier than 2001-11-30 | G2 | 4000h | 4000h |  | Rel-4 | Gert |  |  |  |  |
| 1343 | 60.5 | **Deleted - GERAN MS Conformance test for inter-system and intra-system Packet data real-time Handover** | 324d | 2001-08-31 A | 2002-11-27 A | 100% | 2001-08-31 | 2002-11-27 | 324d |  | G4,R3 | 12960h | 12960h | GERQoS-Mstest | Rel-4 | Paolo | GP-12 |  |  |  |
| 1344 | 60.5.1 | **Deleted - Handover for the PS domain** | 324d | 2001-08-31 A | 2002-11-27 A | 100% | 2001-08-31 | 2002-11-27 | 324d |  | G4,R3 | 10368h | 10368h |  | Rel-4 | Paolo | GP-12 |  |  |  |
| 1345 | 60.5.1.1 | Deleted - Stable RT handover report 25.936 including header removal | 324d | 2001-08-31 A | 2002-11-27 A | 100% | 2001-08-31 | 2002-11-27 | 324d | finish no earlier than 2002-11-27 | G4,R3 | 2592h | 2592h |  | Rel-4 | Paolo | GP-12 |  |  |  |
| 1346 | 60.5.1.2 | Deleted - Update of stage 2 | 324d | 2001-08-31 A | 2002-11-27 A | 100% | 2001-08-31 | 2002-11-27 | 324d | finish no earlier than 2002-11-27 | G4,R3 | 2592h | 2592h |  | Rel-4 | Paolo | GP-12 |  |  |  |
| 1347 | 60.5.1.3 | Deleted - Update of relevant stage 3 specs | 324d | 2001-08-31 A | 2002-11-27 A | 100% | 2001-08-31 | 2002-11-27 | 324d | finish no earlier than 2002-11-27 | G4,R3 | 2592h | 2592h |  | Rel-4 | Paolo | GP-12 |  |  |  |
| 1348 | 60.6 | PS-domain handover for real-time services | 155d | 2000-08-28 A | 2001-03-30 A | 100% | 2000-08-28 | 2001-03-30 | 155d | finish no earlier than 2001-03-30 | R3 | 1240h | 1240h | QoSPS-PSdoRTS | Rel-4 | Juha |  | Nokia | A. Lansisalmi |  |
| 1349 | 60.7 | Deleted - RAB QoS Renegotiation at Relocation | 58d | 2001-01-03 A | 2001-03-23 A | 100% | 2001-01-03 | 2001-03-23 | 58d | finish no earlier than 2001-03-23 | R3 | 464h | 464h |  | Rel-4 | Juha | RP-11 |  |  | 25.851, 25.946 |
| 1350 | 61 | **small Technical Enhancements and Improvements for Rel4** | 2178d? | 2000-01-03 A | 2008-05-06 A | 100% | 2000-01-03 | 2008-05-06 | 2178d? |  | All | 17424h | 17424h | TEI4 | Rel-4 |  |  |  |  |  |
| 1351 | 418.1 | Small Technical Enhancements and Improvements for Rel-4 Conformance Testing | 2178d? | 2000-01-03 A | 2008-05-06 A | 100% | 2000-01-03 | 2008-05-06 | 2178d? | finish no earlier than 2008-12-31 | R5,T1 | 17424h | 17424h | TEI4_Test | Rel-4 | Ingbert |  |  |  |  |
| 1352 | 62 | **Rel-4 Evolutions of the transport in the UTRAN** | 525d | 2000-08-21 A | 2002-08-23 A | 100% | 2000-08-21 | 2002-08-23 | 525d |  | RP | 8600h | 8600h | ETRAN | Rel-4 | Issam |  | Alcatel | Francois Courau |  |
| 1353 | 62.1 | QoS optimization for AAL2 connections over Iub and Iur interfaces | 160d | 2000-08-21 A | 2001-03-30 A | 100% | 2000-08-21 | 2001-03-30 | 160d | finish no earlier than 2001-03-30 | R3 | 1280h | 1280h | ETRAN-QoSAAL2 | Rel-4 | Juha |  | Japan Telecom | T. Yoshimura |  |
| 1354 | 62.2 | Transport bearer modification procedure on Iub, Iur, and Iu | 130d | 2000-10-02 A | 2001-03-30 A | 100% | 2000-10-02 | 2001-03-30 | 130d | finish no earlier than 2001-03-30 | R3 | 1040h | 1040h | ETRAN-MigrMod | Rel-4 | Juha |  | Japan Telecom | T. Yoshimura |  |
| 1355 | 62.3 | **Deleted - Conformance Test Aspects of Rel-4 evolutions of the transport in UTRAN** | 130d | 2002-02-25 A | 2002-08-23 A | 100% | 2002-02-25 | 2002-08-23 | 130d |  | T1 | 2080h | 2080h |  | Rel-4 | Ingbert |  |  |  |  |
| 1356 | 62.3.1 | Deleted - Testing RAB support enhancements | 130d | 2002-02-25 A | 2002-08-23 A | 100% | 2002-02-25 | 2002-08-23 | 130d | finish no earlier than 2002-08-23 | T1 | 1040h | 1040h | CT-RABS? | Rel-4 | Ingbert |  |  |  | 34.108, 34. 121, 34.122, 34.123 p 1,2, 34.123 pt 3 |
| 1357 | 63 | **Rel-4 Evolutions of the transport in the CN** | 215d | 2000-05-29 A | 2001-03-23 A | 100% | 2000-05-29 | 2001-03-23 | 215d |  | N4,N1,N2,S2 | 7968h | 7968h | CNTRSP | Rel-4 | Kimmo |  |  |  |  |
| 1358 | 63.1 | **IP Transport of CN protocols (e.g., CAP, MAP)** | 77d | 2000-12-07 A | 2001-03-23 A | 100% | 2000-12-07 | 2001-03-23 | 77d |  | N4 | 2808h | 2808h | SS7IP | Rel-4 | Kimmo |  |  |  |  |
| 1359 | 63.1.1 | **Stage 3** | 77d | 2000-12-07 A | 2001-03-23 A | 100% | 2000-12-07 | 2001-03-23 | 77d |  | N4 | 2192h | 2192h |  | Rel-4 | Kimmo |  |  |  |  |
| 1360 | 63.1.1.1 | CAP | 77d | 2000-12-07 A | 2001-03-23 A | 100% | 2000-12-07 | 2001-03-23 | 77d | finish no earlier than 2001-03-23 | N2 | 616h | 616h |  | Rel-4 | Kimmo |  |  |  |  |
| 1361 | 63.1.1.2 | MAP | 77d | 2000-12-07 A | 2001-03-23 A | 100% | 2000-12-07 | 2001-03-23 | 77d | finish no earlier than 2001-03-23 | N4 | 616h | 616h |  | Rel-4 | Kimmo |  |  |  |  |
| 1362 | 63.1.1.3 | BSSAP+ | 43d | 2001-01-15 A | 2001-03-14 A | 100% | 2001-01-15 | 2001-03-14 | 43d | finish no earlier than 2001-03-14 | N1 | 344h | 344h | SS7IP-BSSAP+ | Rel-4 | Frederic |  |  |  |  |

Notes:
- 1338: -
- 1339: -
- 1340: -
- 1341: -
- 1342: -
- 1343: Still exist? To be clarified by GERAN4/5. Marked as stopped 12/2008
- 1344: Marked as stopped 12/2008
- 1345: Marked as stopped 12/2008
- 1346: Marked as stopped 12/2008
- 1347: Marked as stopped 12/2008
- 1348: -
- 1349: Marked as stopped 12/2008
- 1350: "Joker" WI, to be used for a Rel 4 CR not related to any feature and with very limited impact on the system
- 1351: "Joker" WI, to be used for small modifications applicable to Rel 4 conformance testing. Moved in from the Stoyan/Testing WP
- 1352: -
- 1353: -
- 1354: -
- 1355: Marked as stopped 12/2008
- 1356: Marked as stopped 12/2008
- 1357: -
- 1358: -
- 1359: -
- 1360: -
- 1361: -
- 1362: -

| ID | WBS | Task | Duration | Start | Finish | Complete | Baseline start | Baseline finish | Baseline duration | Constraint | Resources | Work | Actual work | Text4 | Text5 | Text6 | Text8 | Text1 | Text3 | Text12 |
| --- | --- | --- | --- | --- | --- | --- | --- | --- | --- | --- | --- | --- | --- | --- | --- | --- | --- | --- | --- | --- |
| 1363 | 63.2 | **FS on Transport and control separation in the PS CN domain** | 215d | 2000-05-29 A | 2001-03-23 A | 100% | 2000-05-29 | 2001-03-23 | 215d |  | S2 | 3440h | 3440h | Ericsson | Juan-Antonio.Ibanez@eed.ericsson.se | Rel-4 | Maurice |  |  |  |
| 1364 | 63.2.1 | Architectural impacts | 215d | 2000-05-29 A | 2001-03-23 A | 100% | 2000-05-29 | 2001-03-23 | 215d | finish no earlier than 2001-03-23 | S2 | 1720h | 1720h |  |  | Rel-4 | Maurice |  |  |  |
| 1365 | 64 | **Rel-4 Improvements of Radio Interface** | 700d | 2000-07-10 A | 2003-03-14 A | 100% | 2000-07-10 | 2003-03-14 | 700d |  | RP | 28624h | 28624h |  |  | Rel-4 |  | RInImp |  |  |
| 1366 | 64.1 | UTRA repeater specification (master) | 183d | 2000-07-10 A | 2001-03-21 A | 100% | 2000-07-10 | 2001-03-21 | 183d | finish no earlier than 2001-03-21 | R4 | 1464h | 1464h | Mikom, Allgon | T. Kummetz, Mikom; Alf Ahlström, Allgon | Rel-4 | Issam | RInImp-REP |  |  |
| 1367 | 64.2 | DSCH power control improvement in soft handover | 140d | 2000-09-11 A | 2001-03-23 A | 100% | 2000-09-11 | 2001-03-23 | 140d | finish no earlier than 2001-03-23 | R1 | 1120h | 1120h | Nokia | antti.toskala@nokia.com | Rel-4 | Patrick | RInImp-DSCHsho |  |  |
| 1368 | 64.3 | UMTS 1800 | 320d | 2000-09-25 A | 2001-12-14 A | 100% | 2000-09-25 | 2001-12-14 | 320d | finish no earlier than 2001-12-14 | R4 | 2560h | 2560h | Motorola | Howard Benn | Rel-4 | Issam | RInImp-UMTS18 |  |  |
| 1369 | 64.4 | UMTS 1900 | 195d | 2001-03-19 A | 2001-12-14 A | 100% | 2001-03-19 | 2001-12-14 | 195d | finish no earlier than 2001-12-14 | R4 | 1560h | 1560h | Motorola | Howard Benn | Rel-4 | Issam | RInImp-UMTS19 | 25.101 |  |
| 1370 | 64.5 | FS on High Speed downlink packet access | 155d | 2000-08-21 A | 2001-03-23 A | 100% | 2000-08-21 | 2001-03-23 | 155d | finish no earlier than 2001-03-23 | R2 | 1240h | 1240h | Motorola | A. Ghosh | Rel-4 | Joern | RInImp-HSDPA |  |  |
| 1371 | 64.6 | Deleted - FS on improved common DL channel for Cell-FACH state | 340d | 2000-09-11 A | 2001-12-28 A | 100% | 2000-09-11 | 2001-12-28 | 340d | finish no earlier than 2001-12-28 | R2 | 2720h | 2720h | GBT | J. Kwak | Rel-4 | Joern | RInImp-DLCFACH |  | RP-14 |
| 1372 | 64.7 | **Conformance Test Spec. Rel-4 improvements in Radio Interface** | 375d | 2001-10-08 A | 2003-03-14 A | 100% | 2001-10-08 | 2003-03-14 | 375d |  | T1 | 12360h | 12360h |  |  | Rel-4 | Ingbert |  |  |  |
| 1373 | 64.7.1 | Deleted - Testing Improved usage of downlink resource in FDD for CCTrCHs of dedicated type | 140d | 2002-02-18 A | 2002-08-30 A | 100% | 2002-02-18 | 2002-08-30 | 140d | finish no earlier than 2002-08-30 | T1 | 1120h | 1120h |  |  | Rel-4 | Ingbert |  |  | TP-17 |
| 1374 | 64.7.2 | Deleted - Testing Terminal Power saving features | 140d | 2002-02-18 A | 2002-08-30 A | 100% | 2002-02-18 | 2002-08-30 | 140d | finish no earlier than 2002-08-30 | T1 | 1120h | 1120h |  |  | Rel-4 | Ingbert |  |  | TP-17 |
| 1375 | 64.7.3 | Deleted - Testing DSCH power control improvement in soft handover | 140d | 2002-02-18 A | 2002-08-30 A | 100% | 2002-02-18 | 2002-08-30 | 140d | finish no earlier than 2002-08-30 | T1 | 1120h | 1120h |  |  | Rel-4 | Ingbert |  |  | TP-17 |
| 1376 | 64.7.4 | Testing UMTS 1800 | 180d | 2001-10-08 A | 2002-06-14 A | 100% | 2001-10-08 | 2002-06-14 | 180d | finish no earlier than 2002-06-14 | T1 | 1440h | 1440h |  |  | Rel-4 | Ingbert |  | 34.108, 34,121, 34.122, 34.123-1 |  |
| 1377 | 64.7.5 | Testing UMTS 1900 | 180d | 2001-10-08 A | 2002-06-14 A | 100% | 2001-10-08 | 2002-06-14 | 180d | finish no earlier than 2002-06-14 | T1 | 1440h | 1440h |  |  | Rel-4 | Ingbert |  | 34.108, 34,121, 34.122, 34.123-1 |  |
| 1378 | 64.7.6 | Testing UMTS 1800 - TTCN | 195d | 2002-06-17 A | 2003-03-14 A | 100% | 2002-06-17 | 2003-03-14 | 195d | finish no earlier than 2003-03-14 | T1 | 1560h | 1560h |  |  | Rel-4 | Ingbert |  | 34.123-3 |  |
| 1379 | 64.7.7 | Testing UMTS 1900 - TTCN | 195d | 2002-06-17 A | 2003-03-14 A | 100% | 2002-06-17 | 2003-03-14 | 195d | finish no earlier than 2003-03-14 | T1 | 1560h | 1560h |  |  | Rel-4 | Ingbert |  | 34.123-3 |  |
| 1380 | 65 | **Rel-4 RAN improvements** | 938d? | 2000-08-14 A | 2004-03-17 A | 100% | 2000-08-14 | 2004-03-17 | 938d? |  | RP | 29336h | 29336h |  |  | Rel-4 |  | RANimp |  |  |
| 1381 | 65.1 | Node B synchronization for TDD | 160d | 2000-08-14 A | 2001-03-23 A | 100% | 2000-08-14 | 2001-03-23 | 160d | finish no earlier than 2001-03-23 | R1 | 1280h | 1280h | Siemens | S. Oestreich | Rel-4 | Patrick | RANimp-NBsync |  |  |
| 1382 | 65.2 | RAB support enhancement for Rel-4 | 155d | 2000-08-21 A | 2001-03-23 A | 100% | 2000-08-21 | 2001-03-23 | 155d | finish no earlier than 2001-03-23 | R2 | 1240h | 1240h | Ericsson | M. Israelsson, A. Krishnarajah | Rel-4 | Joern | RANimp-RABSE |  |  |
| 1383 | 65.4 | **Deleted - Conformance Test Aspects - Rel-4 RAN Improvements** | 577d? | 2002-01-01 A | 2004-03-17 A | 100% | 2002-01-01 | 2004-03-17 | 577d? |  | T1 | 19312h | 19312h |  |  | Rel-4 | Ingbert |  |  |  |
| 1384 | 65.4.1 | Deleted - Testing Radio access bearer support enhancments | 175d | 2002-01-01 A | 2002-09-02 A | 100% | 2002-01-01 | 2002-09-02 | 175d | finish no earlier than 2002-09-02 | T1 | 1400h | 1400h |  |  | Rel-4 | Ingbert |  |  | TP-17 |
| 1385 | 65.4.2 | Deleted - Testing RAB support enhancements-Robust Header Compression | 332d | 2002-05-28 A | 2003-09-03 A | 100% | 2002-05-28 | 2003-09-03 | 332d | finish no earlier than 2003-09-03 | T1 | 2656h | 2656h |  |  | Rel-4 | Ingbert | RABimp-RoCH | 34.123-1, -2 | TP-21 |
| 1386 | 65.4.3 | Deleted - Testing RAB support enhancements-Robust Header Compression - TTCN | 472d | 2002-05-28 A | 2004-03-17 A | 100% | 2002-05-28 | 2004-03-17 | 472d | finish no earlier than 2004-03-17 | T1 | 3776h | 3776h |  |  | Rel-4 | Ingbert |  | 34.123-3 | TP-23 |
| 1387 | 65.4.4 | Testing of Extended Robut Header Compression | 270d | 2002-09-18 A | 2003-09-30 A | 100% | 2002-09-18 | 2003-09-30 | 270d | finish no earlier than 2003-09-30 | T1 | 2160h | 2160h |  |  | Rel-4 | Ingbert | Ext-RoHC | 34.123-1, -2 |  |
| 1388 | 65.4.5 | Deleted - Testing of Extended Robut Header Compression - TTCN | 325d | 2002-09-18 A | 2003-12-16 A | 100% | 2002-09-18 | 2003-12-16 | 325d | finish no earlier than 2003-12-16 | T1 | 2600h | 2600h |  |  | Rel-4 | Ingbert |  | 34.123-3 | TP-22 |
| 1389 | 422.3.6 | Deleted - General changes to TS34.121 corresponding to release 4 | 263d? | 2003-03-03 A | 2004-03-03 A | 100% | 2003-03-03 | 2004-03-03 | 263d? | finish no earlier than 2004-03-03 | T1 | 2104h | 2104h |  |  | Rel-4 | Ingbert | RANimp-test | 34.108, 34.121 | TP-23 |

Notes:
- 1363: -
- 1364: -
- 1365: -
- 1366: -
- 1367: -
- 1368: -
- 1369: -
- 1370: -
- 1371: Stopped at RP#14
- 1372: -
- 1373: Marked as stopped 12/2008
- 1374: Marked as stopped 12/2008
- 1375: Marked as stopped 12/2008
- 1376: -
- 1377: -
- 1378: -
- 1379: -
- 1380: -
- 1381: -
- 1382: 29 Nov 2000: split into ROHC and non-ROHC part; 5 Mar 2001: splitting off of ROHC for Rel-4 agreed by R2
- 1383: Marked as stopped 12/2008
- 1384: Marked as stopped 12/2008
- 1385: UID changed. Marked as stopped 12/2008
- 1386: UID changed. Marked as stopped 12/2008
- 1387: Marked as closed 12/2008 (was marked 15% complete)
- 1388: Marked as stopped 12/2008
- 1389: Marked as stopped 12/2008

| ID | WBS | Task | Type | Duration | Start | Finish | Complete | Baseline start | Baseline finish | Baseline duration | Total slack | Constraint | Resources | Work | Actual work | Text1 | Text6 | Text8 | Text3 | Text4 | Text5 | Text12 |
| --- | --- | --- | --- | --- | --- | --- | --- | --- | --- | --- | --- | --- | --- | --- | --- | --- | --- | --- | --- | --- | --- | --- |
| 1390 | 67 | **Rel-4 Terminal interfaces** |  | 315d | 2000-01-03 A | 2001-03-15 A | 100% | 2000-01-03 | 2001-03-15 | 315d |  |  | T2 | 14296h | 14296h | TI | Rel-4 | Kimmo |  |  |  |  |
| 1391 | 67.1 | **AT commands enhancements** |  | 314d | 2000-01-03 A | 2001-03-14 A | 100% | 2000-01-03 | 2001-03-14 | 314d |  |  | T2 | 5016h | 5016h | TI-ATC | Rel-4 |  | 27.007 |  |  |  |
| 1392 | 67.1.1 | Specification of AT commands for new services |  | 314d | 2000-01-03 A | 2001-03-14 A | 100% | 2000-01-03 | 2001-03-14 | 314d |  | finish no earlier than 2001-03-14 | T2 | 2504h | 2504h |  | Rel-4 |  | 27.007 |  |  |  |
| 1393 | 67.2 | **Wide Area Data Synchronization** |  | 314d | 2000-01-03 A | 2001-03-14 A | 100% | 2000-01-03 | 2001-03-14 | 314d |  |  | T2 | 5016h | 5016h | TI-WADS | Rel-4 |  |  |  |  |  |
| 1394 | 67.2.1 | Continues evolution of Synchronization protocol |  | 314d | 2000-01-03 A | 2001-03-14 A | 100% | 2000-01-03 | 2001-03-14 | 314d |  | finish no earlier than 2001-03-14 | T2 | 2504h | 2504h | TI-SYNC-EVOL | Rel-4 |  | 27.903, 27.103 |  |  |  |
| 1395 | 67.3 | Terminal local model |  | 218d | 2000-05-16 A | 2001-03-15 A | 100% | 2000-05-16 | 2001-03-15 | 218d |  | finish no earlier than 2001-03-15 | T2 | 1744h | 1744h | TLM | Rel-4 |  | 23.227 | Ericsson | Olga.Tome@ECS.ERICSSON.SE |  |
| 1396 | 69 | **Rel-4 UICC/(U)SIM enhancements and interworking** |  | 175d | 2000-07-24 A | 2001-03-23 A | 100% | 2000-07-24 | 2001-03-23 | 175d |  |  | T3 | 2800h | 2800h | UICC1 | Rel-4 | Xavier |  |  |  |  |
| 1397 | 69.1 | Common PCN Handset Specification (CPHS) |  | 175d | 2000-07-24 A | 2001-03-23 A | 100% | 2000-07-24 | 2001-03-23 | 175d |  | finish no earlier than 2001-03-23 | T3 | 1400h | 1400h | UICC1-CPHS | Rel-4 |  | 27.103 | One2One |  |  |
| 1398 | 70 | **Rel-4 (U)SIM toolkit enhancements** |  | 210d | 2000-06-05 A | 2001-03-23 A | 100% | 2000-06-05 | 2001-03-23 | 210d |  |  | T3 | 3360h | 3360h | USAT1-LocLnk | Rel-4 | Xavier |  | Gemplus | Jean-Francois Rubon |  |
| 1399 | 70.1 | USAT local link |  | 210d | 2000-06-05 A | 2001-03-23 A | 100% | 2000-06-05 | 2001-03-23 | 210d |  | finish no earlier than 2001-03-23 | T3 | 1680h | 1680h | USAT1-LocLnk | Rel-4 | Xavier |  | Gemplus | Jean-Francois Rubon |  |
| 1400 | 71 | **Rel-4 Security enhancements** |  | 576d | 2000-01-03 A | 2002-03-15 A | 100% | 2000-01-03 | 2002-03-15 | 576d |  |  | S3 | 24152h | 24152h |  | Rel-4 | Dionisio |  | Vodafone | Peter.Howard@vodafone.com |  |
| 1401 | 71.1 | Evolution of GSM CS algorithms (e.g. A5/3 development and deployment) |  | 272d | 2000-01-03 A | 2001-01-15 A | 100% | 2000-01-03 | 2001-01-15 | 272d |  | finish no earlier than 2001-01-15 | S3 | 2168h | 2168h | SEC1-CSALGO1 | Rel-4 | Dionisio |  |  |  |  |
| 1402 | 71.2 | **Evolution of GSM PS algorithms (e.g. GEA 2 deployment)** |  | 219d | 2000-02-22 A | 2000-12-22 A | 100% | 2000-02-22 | 2000-12-22 | 219d |  |  | S3 | 6024h | 6024h | SEC1-PSALGO1 | Rel-4 | Dionisio |  |  |  |  |
| 1403 | 71.2.1 | Main aspects |  | 199d | 2000-02-22 A | 2000-11-24 A | 100% | 2000-02-22 | 2000-11-24 | 199d |  | finish no earlier than 2000-11-24 | S3 | 1592h | 1592h | SEC1-PSALGO1 | Rel-4 | Dionisio |  |  |  |  |
| 1404 | 71.2.2 | Impact on GTP |  | 200d | 2000-03-20 A | 2000-12-22 A | 100% | 2000-03-20 | 2000-12-22 | 200d |  | finish no earlier than 2000-12-22 | N4 | 1600h | 1600h | SEC1-PSALGO1 | Rel-4 | Kimmo |  |  |  |  |
| 1405 | 71.2.3 | GEA capability indication in MS CM |  | 135d | 2000-06-19 A | 2000-12-22 A | 100% | 2000-06-19 | 2000-12-22 | 135d |  | finish no earlier than 2000-12-22 | N1 | 1080h | 1080h | SEC1-PSALGO1-GEACAP | Rel-4 | Frederic |  | Vodafone Airtouch | Duncan Mills |  |
| 1406 | 71.3 | **Deleted - MAP application layer security** |  | 576d | 2000-01-03 A | 2002-03-15 A | 100% | 2000-01-03 | 2002-03-15 | 576d |  |  | S3 | 11352h | 11352h | SEC1-MAPAL | Rel-4 | Dionisio |  |  |  | SP-15 |
| 1407 | 71.3.1 | Deleted - Main aspects |  | 199d | 2000-02-21 A | 2001-03-29 A | 100% | 2000-02-21 | 2001-03-29 | 199d |  | start no earlier than 2000-02-21 | S3 | 1592h | 1592h |  | Rel-4 | Dionisio |  |  |  | SP-11 |
| 1408 | 71.3.2 | Deleted - Other stage 3 aspects |  | 199d | 2000-02-22 A | 2000-11-24 A | 100% | 2000-02-22 | 2000-11-24 | 199d |  | finish no earlier than 2000-11-24 | N4 | 1592h | 1592h |  | Rel-4 | Kimmo |  |  |  | CP-10 |
| 1409 | 71.3.3 | Deleted - Visibility and Configurability of security |  | 576d | 2000-01-03 A | 2002-03-15 A | 100% | 2000-01-03 | 2002-03-15 | 576d |  | finish no earlier than 2002-03-15 | S3 | 4600h | 4600h | SEC1-VCS | Rel-4 | Dionisio |  | France Telecom | Sebastien.nguyenngoc@rd.francetelecom.com | SP-15 |
| 1410 | 72 | **Rel-4 Charging and OAM&P** |  | 221d | 2000-12-01 A | 2001-10-05 A | 100% | 2000-12-01 | 2001-10-05 | 221d |  |  | S5 | 10472h | 10472h | OAM | Rel-4 | Dionisio |  | VoiceStream, Motorola |  |  |
| 1411 | 72.1 | Rel4 Principles, high level Requirements and Architecture |  | 145d | 2000-12-01 A | 2001-06-21 A | 100% | 2000-12-01 | 2001-06-21 | 145d |  | finish no earlier than 2001-06-21 | S5 | 1160h | 1160h | OAM-AR/PR | Rel-4 | Dionisio | 32.101, 32.102 | Motorola, Telia | Michael.Truss@MOTOROLA.COM; Tommy.R.Berggren@TELIA.SE |  |
| 1412 | 72.2 | Rel4 Performance Management |  | 216d | 2000-12-01 A | 2001-09-28 A | 100% | 2000-12-01 | 2001-09-28 | 216d |  | finish no earlier than 2001-06-21 | S5 | 1728h | 1728h |  | Rel-4 | Dionisio | 32.4xy, 52.402 | T-Mobile | karl-heinz.nenner@t-mobile.de |  |
| 1413 | 72.3 | Fault Management |  | 221d | 2000-12-01 A | 2001-10-05 A | 100% | 2000-12-01 | 2001-10-05 | 221d |  | finish no earlier than 2001-06-21 | S5 | 1768h | 1768h |  | Rel-4 | Dionisio | 32.111-1/4 | Lucent |  |  |
| 1414 | 72.4 | Configuration Management |  | 145d | 2000-12-01 A | 2001-06-21 A | 100% | 2000-12-01 | 2001-06-21 | 145d |  | finish no earlier than 2001-06-21 | S5 | 1160h | 1160h | OAM-CM | Rel-4 | Dionisio | 32.106-1/8 | Ericsson | thomas.tovinger@ericsson.com |  |
| 1415 | 72.5 | Rel4 Charging Management |  | 216d | 2000-12-01 A | 2001-09-28 A | 100% | 2000-12-01 | 2001-09-28 | 216d |  | finish no earlier than 2001-06-21 | S5 | 1728h | 1728h | OAM-CH | Rel-4 | Dionisio | 32.200, 32.205, 32.215, 32.235 | T-Mobile | karl-heinz.nenner@t-mobile.de |  |
| 1416 | 72.6 | UTRAN Operations and Maintenance procedures |  | 145d | 2000-12-01 A | 2001-06-21 A | 100% | 2000-12-01 | 2001-06-21 | 145d |  | finish no earlier than 2001-06-21 | S5 | 1160h | 1160h | UOAM | Rel-4 | Dionisio | 32.800 | Mannesmann Mobilfunk | bert.boden@d2mannesmann.de |  |
| 1417 | 428 | Release 1999 Features | milestone | 0d? | 2000-01-01 | 2000-01-01 |  | 2000-01-01 | 2000-01-01 | 0d? | 3057d |  | NP,SP,TP,SMG |  |  |  | R99 |  |  |  |  |  |

Notes:
- 1390: -
- 1391: -
- 1392: goal not completely achieved because of missing input
- 1393: AS: Rel5 changed to Rel4 according to SP#10 decision, milestone on testing added
- 1394: -
- 1395: -
- 1396: -
- 1397: 28/5/2001: CRs approved at TP-11. WI complete.
- 1398: -
- 1399: 25/5/2001:CR was approved at TP-11. WI is complete
- 1400: Added BB UE authentication and rapporteur added. TO BE DELETED
- 1401: Approved SP#17
- 1402: A5/3 development will consider new GEA algorithm based on Kasumi
- 1403: Complete TSG#09 (09/2000). S3#17: Proposed for deletion. TO BE DELETED
- 1404: -
- 1405: -
- 1406: REPLACED BY NDS-MAP and NDS-IP. Completed Auto Key Management -> Rel-6. Marked as stopped 12/2008
- 1407: UID changed. Marked as stopped 12/2008
- 1408: UID changed. Marked as stopped 12/2008
- 1409: CR approved at SA3#21 awaiting comments from CN1. Marked as stopped 12/2008
- 1410: SP#13 approved WID
- 1411: -
- 1412: -
- 1413: -
- 1414: -
- 1415: -
- 1416: -
- 1417: -

| ID | WBS | Task | Duration | Start | Finish | Complete | Baseline start | Baseline finish | Baseline duration | Constraint | Resources | Work | Actual work | Text1 | Text6 |
| --- | --- | --- | --- | --- | --- | --- | --- | --- | --- | --- | --- | --- | --- | --- | --- |
| 1418 | 429 | **Operations, Administration, Maintenance and Provisioning (OAM&P)** | 261d? | 1999-01-01 A | 1999-12-31 A | 100% | 1999-01-01 | 1999-12-31 | 261d? |  | S5 | 12528h | 12528h | OAM | R99 |
| 1419 | 429.1 | OAM Principles and High-level Requirements | 261d? | 1999-01-01 A | 1999-12-31 A | 100% | 1999-01-01 | 1999-12-31 | 261d? | start no earlier than 1999-01-01 | S5 | 2088h | 2088h | PR, Princs_&_Reqs_(PR) | R99 |
| 1420 | 429.2 | OAM Architecture | 261d? | 1999-01-01 A | 1999-12-31 A | 100% | 1999-01-01 | 1999-12-31 | 261d? | start no earlier than 1999-01-01 | S5 | 2088h | 2088h | OAMAR, AR, Telecom_Management_Arch_(AR) | R99 |
| 1421 | 429.3 | OAM Configuration Management | 261d? | 1999-01-01 A | 1999-12-31 A | 100% | 1999-01-01 | 1999-12-31 | 261d? | start no earlier than 1999-01-01 | S5 | 2088h | 2088h | OAMCM, CM | R99 |
| 1422 | 429.4 | OAM Fault Management | 261d? | 1999-01-01 A | 1999-12-31 A | 100% | 1999-01-01 | 1999-12-31 | 261d? | start no earlier than 1999-01-01 | S5 | 2088h | 2088h | OAMFM | R99 |
| 1423 | 429.5 | OAM Performance Management | 261d? | 1999-01-01 A | 1999-12-31 A | 100% | 1999-01-01 | 1999-12-31 | 261d? | start no earlier than 1999-01-01 | S5 | 2088h | 2088h | OAMPM, PM | R99 |
| 1424 | 430 | GPRS_Mobile_IP_interworking | 261d? | 1999-01-01 A | 1999-12-31 A | 100% | 1999-01-01 | 1999-12-31 | 261d? | start no earlier than 1999-01-01 | N3 | 2088h | 2088h | GPRS_Mobile_IP_interworking | R99 |
| 1425 | 431 | 2G3Ghandover | 261d? | 1999-01-01 A | 1999-12-31 A | 100% | 1999-01-01 | 1999-12-31 | 261d? | start no earlier than 1999-01-01 | SMG2 | 2088h | 2088h | 2G3Ghandover | R99 |
| 1426 | 432 | Data & Data_CleanUp | 261d? | 1999-01-01 A | 1999-12-31 A | 100% | 1999-01-01 | 1999-12-31 | 261d? | start no earlier than 1999-01-01 | SMG1 | 2088h | 2088h | Data, Data_CleanUp | R99 |
| 1427 | 433 | Unstructured Supplementary Service Data | 261d? | 1999-01-01 A | 1999-12-31 A | 100% | 1999-01-01 | 1999-12-31 | 261d? | start no earlier than 1999-01-01 | SMG1,N4 | 2088h | 2088h | USSD | R99 |
| 1428 | 434 | Network Identity and Timezone (NITZ) | 261d? | 1999-01-01 A | 1999-12-31 A | 100% | 1999-01-01 | 1999-12-31 | 261d? | start no earlier than 1999-01-01 | SMG1,SMG3 | 2088h | 2088h | NITZ | R99 |
| 1429 | 435 | Packet Flow Management | 261d? | 1999-01-01 A | 1999-12-31 A | 100% | 1999-01-01 | 1999-12-31 | 261d? | start no earlier than 1999-01-01 | SMG2 | 2088h | 2088h | Packet_Flow_Management | R99 |
| 1430 | 436 | GPRS_Point-To-Multipoint Group call | 261d? | 1999-01-01 A | 1999-12-31 A | 100% | 1999-01-01 | 1999-12-31 | 261d? | start no earlier than 1999-01-01 | SMG1 | 2088h | 2088h | GPRS_PTMG | R99 |
| 1431 | 437 | **Call Forwarding** | 261d? | 1999-01-01 A | 1999-12-31 A | 100% | 1999-01-01 | 1999-12-31 | 261d? |  | SMG1,N2,N4 | 8352h | 8352h |  | R99 |
| 1432 | 437.1 | Call Forwarding enhancements | 261d? | 1999-01-01 A | 1999-12-31 A | 100% | 1999-01-01 | 1999-12-31 | 261d? | start no earlier than 1999-01-01 | N4,N2 | 2088h | 2088h | CF_enhancements | R99 |
| 1433 | 437.2 | Call_Forwarding | 261d? | 1999-01-01 A | 1999-12-31 A | 100% | 1999-01-01 | 1999-12-31 | 261d? | start no earlier than 1999-01-01 | SMG1,N2 | 2088h | 2088h | Call_Forwarding | R99 |
| 1434 | 437.3 | Call_Forwarding_Enhancements | 261d? | 1999-01-01 A | 1999-12-31 A | 100% | 1999-01-01 | 1999-12-31 | 261d? | start no earlier than 1999-01-01 | N4 | 2088h | 2088h | Call_Forwarding_Enhancements | R99 |
| 1435 | 438 | **Quality of Service** | 261d? | 1999-01-01 A | 1999-12-31 A | 100% | 1999-01-01 | 1999-12-31 | 261d? |  | S2,T2,N1,N2,N4 | 10440h | 10440h |  | R99 |
| 1436 | 438.1 | End-to-end UMTS Quality of Service management | 261d? | 1999-01-01 A | 1999-12-31 A | 100% | 1999-01-01 | 1999-12-31 | 261d? | start no earlier than 1999-01-01 | S2,T2,N1,N2,N4 | 2088h | 2088h | QoS | R99 |
| 1437 | 438.2 | End-to-end QoS for PS Domain including IMS | 261d? | 1999-01-01 A | 1999-12-31 A | 100% | 1999-01-01 | 1999-12-31 | 261d? | start no earlier than 1999-01-01 | S2 | 2088h | 2088h | E2EQoS | R99 |
| 1438 | 438.3 | GPRS-enhanced_QoS | 261d? | 1999-01-01 A | 1999-12-31 A | 100% | 1999-01-01 | 1999-12-31 | 261d? | start no earlier than 1999-01-01 | T2 | 2088h | 2088h | GPRS-enhanced_QoS | R99 |
| 1439 | 438.4 | QoS_enhancements | 261d? | 1999-01-01 A | 1999-12-31 A | 100% | 1999-01-01 | 1999-12-31 | 261d? | start no earlier than 1999-01-01 | N2,N1,N4 | 2088h | 2088h | QoS_enhancements | R99 |
| 1440 | 439 | Support of Localised Service Area | 261d? | 1999-01-01 A | 1999-12-31 A | 100% | 1999-01-01 | 1999-12-31 | 261d? | start no earlier than 1999-01-01 | SMG2,SMG3,SMG7,N2 | 2088h | 2088h | SoLSA | R99 |
| 1441 | 440 | Transcoder_location | 261d? | 1999-01-01 A | 1999-12-31 A | 100% | 1999-01-01 | 1999-12-31 | 261d? | start no earlier than 1999-01-01 | S2 | 2088h | 2088h | Transcoder_location | R99 |
| 1442 | 441 | Antenna_test_methods | 261d? | 1999-01-01 A | 1999-12-31 A | 100% | 1999-01-01 | 1999-12-31 | 261d? | start no earlier than 1999-01-01 | SMG2 | 2088h | 2088h | Antenna_test_methods | R99 |

Notes:
- 1418: WID SP-99581 SA5 Year 2000 Work plan
- 1419: WID SP-99581 SA5 Year 2000 Work plan / Text3: 32.101
- 1420: WID SP-99581 SA5 Year 2000 Work plan / Text3: 32.101, 32.102
- 1421: WID SP-99273 Configuration management / Text3: 32.106, 32.106-1, 32.106-2, 32.106-3, 32.106-4, 32.106-5, 32.106-6, 32.106-7, 32.106-8
- 1422: WID SP-99272 Fault management / Text3: 32.111, 32.111-1, 32.111-2, 32.111-3, 32.111-4
- 1423: WID SP-99274 Performance management / Text3: 12.04, 32.104
- 1424: - / Text3: 29.061
- 1425: - / Text3: 04.18, 04.60, 05.02, 05.08, 05.10, 08.08, 29.010
- 1426: - / Text3: 02.01, 02.02, 02.04, 02.34
- 1427: No additional features for R99. / Text3: 02.04, 02.90, 23.090, 29.002
- 1428: - / Text3: 02.42, 04.08
- 1429: - / Text3: 08.18
- 1430: - / Text3: 02.60
- 1431: -
- 1432: No additional features for R99. / Text3: 23.078, 23.079, 23.082, 29.002, 29.078
- 1433: - / Text3: 02.82, 29.002
- 1434: - / Text3: 23.082
- 1435: WID SMG 98-0781 End To End UMTS QoS Management
- 1436: WID SMG 98-0781 End To End UMTS QoS Management / Text3: 23.107, 23.907, 24.008
- 1437: - / Text3: 23.060, 23.170
- 1438: AT-commands for Enhanced QoS Support management / Text3: 27.007
- 1439: - / Text3: 23.008, 23.016, 24.008, 29.002, 29.060
- 1440: Mechanism which can be used as a platform for providing special tariffs and/or special set of service features for certain subscribers within a regionally restricted area or areas. No additional features for R99. / Text3: 04.08, 04.18, 08.08, 11.10-1, 29.002
- 1441: UE location identification: background information and associated primitives 2. Transcoder location at the core network and source depending coding belonging to the non-access stratum. / Text3: 23.110
- 1442: - / Text3: 03.30

| ID | WBS | Task | Type | Duration | Start | Finish | Complete | Baseline start | Baseline finish | Baseline duration | Constraint | Resources | Work | Actual work | Text6 | Text8 | Text3 |
| --- | --- | --- | --- | --- | --- | --- | --- | --- | --- | --- | --- | --- | --- | --- | --- | --- | --- |
| 1443 | 442 | **Codec** |  | 261d? | 1999-01-01 A | 1999-12-31 A | 100% | 1999-01-01 | 1999-12-31 | 261d? |  | S4 | 14616h | 14616h | R99 | Paolo |  |
| 1444 | 442.1 | Codec(s)_for_Multimedia_Telephony_Service |  | 261d? | 1999-01-01 A | 1999-12-31 A | 100% | 1999-01-01 | 1999-12-31 | 261d? | start no earlier than 1999-01-01 | S4 | 2088h | 2088h | R99 | Paolo | 26.911, 26.104, 26.111 |
| 1445 | 442.2 | QoS for Speech and Multimedia Codec |  | 261d? | 1999-01-01 A | 1999-12-31 A | 100% | 1999-01-01 | 1999-12-31 | 261d? | start no earlier than 1999-01-01 | S4 | 2088h | 2088h | R99 | Paolo | 26.102, 26.912 |
| 1446 | 442.3 | Tandem Free Operation - Adaptive Multi-Rate codec types |  | 261d? | 1999-01-01 A | 1999-12-31 A | 100% | 1999-01-01 | 1999-12-31 | 261d? | start no earlier than 1999-01-01 | S4 | 2088h | 2088h | R99 | Paolo | 26.103 |
| 1447 | 442.4 | Noise Suppression for AMR |  | 261d? | 1999-01-01 A | 1999-12-31 A | 100% | 1999-01-01 | 1999-12-31 | 261d? | start no earlier than 1999-01-01 | S4 | 2088h | 2088h | R99 | Paolo | 06.77, 06.78 |
| 1448 | 442.5 | Out-of-Band Transcoder |  | 261d? | 1999-01-01 A | 1999-12-31 A | 100% | 1999-01-01 | 1999-12-31 | 261d? | start no earlier than 1999-01-01 | N1 | 2088h | 2088h | R99 |  | 23.009, 24.008 |
| 1449 | 442.6 | Out-of-Band Transcoder Control |  | 261d? | 1999-01-01 A | 1999-12-31 A | 100% | 1999-01-01 | 1999-12-31 | 261d? | start no earlier than 1999-01-01 | N1 | 2088h | 2088h | R99 |  | 24.008 CR#0572 in NP-020220 |
| 1450 | 443 | Call Control improvements |  | 261d? | 1999-01-01 A | 1999-12-31 A | 100% | 1999-01-01 | 1999-12-31 | 261d? | start no earlier than 1999-01-01 | N1 | 2088h | 2088h | R99 |  | 24.007, 24.008 |
| 1451 | 444 | Multimedia |  | 261d? | 1999-01-01 A | 1999-12-31 A | 100% | 1999-01-01 | 1999-12-31 | 261d? | start no earlier than 1999-01-01 | N1,N3 | 2088h | 2088h | R99 |  | 24.008, 27.001, 29.007 |
| 1452 | 445 | Sub-System Number allocation for RANAP, RNSAP |  | 261d? | 1999-01-01 A | 1999-12-31 A | 100% | 1999-01-01 | 1999-12-31 | 261d? | start no earlier than 1999-01-01 | N2 | 2088h | 2088h | R99 |  | 23.003 |
| 1453 | 446 | Intranet / ISP access with DHCP end-to-end |  | 261d? | 1999-01-01 A | 1999-12-31 A | 100% | 1999-01-01 | 1999-12-31 | 261d? | start no earlier than 1999-01-01 | N3 | 2088h | 2088h | R99 |  | 29.061 |
| 1454 | 447 | Point_to_Multipoint_Services |  | 261d? | 1999-01-01 A | 1999-12-31 A | 100% | 1999-01-01 | 1999-12-31 | 261d? | start no earlier than 1999-01-01 | N3 | 2088h | 2088h | R99 |  | 29.061 |
| 1455 | 448 | Realtime_NT_FAX_in_UMTS |  | 261d? | 1999-01-01 A | 1999-12-31 A | 100% | 1999-01-01 | 1999-12-31 | 261d? | start no earlier than 1999-01-01 | N3 | 2088h | 2088h | R99 |  | 27.001, 27.003 |
| 1456 | 449 | Gateway Location Register (GLR) - Mobile Application Part (MAP) specification |  | 261d? | 1999-01-01 A | 1999-12-31 A | 100% | 1999-01-01 | 1999-12-31 | 261d? | start no earlier than 1999-01-01 | N4 | 2088h | 2088h | R99 |  | 29.120 |
| 1457 | 450 | Prepaging |  | 261d? | 1999-01-01 A | 1999-12-31 A | 100% | 1999-01-01 | 1999-12-31 | 261d? | start no earlier than 1999-01-01 | N2,N4 | 2088h | 2088h | R99 |  | 23.018, 23.082, 29.002 |
| 1458 | 451 | Downlink Advanced Receiver Performance |  | 261d? | 1999-01-01 A | 1999-12-31 A | 100% | 1999-01-01 | 1999-12-31 | 261d? | start no earlier than 1999-01-01 | SMG | 2088h | 2088h | R99 |  | 05.09 |
| 1459 | 452 | Harmonized Standard |  | 261d? | 1999-01-01 A | 1999-12-31 A | 100% | 1999-01-01 | 1999-12-31 | 261d? | start no earlier than 1999-01-01 | SMG2 | 2088h | 2088h | R99 |  | 13.21 |
| 1460 | 453 | Streamlining of specifications |  | 261d? | 1999-01-01 A | 1999-12-31 A | 100% | 1999-01-01 | 1999-12-31 | 261d? | start no earlier than 1999-01-01 | N3 | 2088h | 2088h | R99 |  | 27.060, 29.061 |
| 1461 | 454 | R99_Service_Clean_up |  | 261d? | 1999-01-01 A | 1999-12-31 A | 100% | 1999-01-01 | 1999-12-31 | 261d? | start no earlier than 1999-01-01 | N3 | 2088h | 2088h | R99 |  | 03.10, 27.001, 27.002, 27.003, 27.060, 29.007, 29.061 |
| 1462 | 455 | **small Technical Enhancements and Improvements for R99** |  | 261d? | 1999-01-01 A | 1999-12-31 A | 100% | 1999-01-01 | 1999-12-31 | 261d? |  | N3 | 6264h | 6264h | R99 |  |  |
| 1463 | 455.1 | TEI_[CS_Data] |  | 261d? | 1999-01-01 A | 1999-12-31 A | 100% | 1999-01-01 | 1999-12-31 | 261d? | start no earlier than 1999-01-01 | N3 | 2088h | 2088h | R99 |  |  |
| 1464 | 455.2 | TEI_[GPRS] |  | 261d? | 1999-01-01 A | 1999-12-31 A | 100% | 1999-01-01 | 1999-12-31 | 261d? | start no earlier than 1999-01-01 | N3 | 2088h | 2088h | R99 |  |  |
| 1465 | 456 | **R99 UE Conformance Testing** |  | 261d? | 1999-01-01 A | 1999-12-31 A | 100% | 1999-01-01 | 1999-12-31 | 261d? |  | R5,T1 | 4176h | 4176h | R99 |  | 34.108, 34.121, 34.122, 34.123-1, 34.123-2, 34.123-3 |
| 1466 | 456.1 | Deleted - RTEI |  | 261d? | 1999-01-01 A | 1999-12-31 A | 100% | 1999-01-01 | 1999-12-31 | 261d? | start no earlier than 1999-01-01 | T1 | 2088h | 2088h | R99 |  | 34.123-1 CR#0650, 0651, 34.123-3 CR#0148, 0149, 0150 |
| 1467 | 456.2 | Common test environments for User Equipment (UE); Conformance testing | milestone | 0d? | 1999-01-01 A | 1999-01-01 A | 100% | 1999-01-01 | 1999-01-01 | 0d? | start no earlier than 1999-01-01 | R5,T1 |  |  | R99 |  | 34.108 |
| 1468 | 456.3 | Terminal conformance specification, Radio transmission and reception (FDD) | milestone | 0d? | 1999-01-01 A | 1999-01-01 A | 100% | 1999-01-01 | 1999-01-01 | 0d? | start no earlier than 1999-01-01 | R5,T1 |  |  | R99 |  | 34.121 |
| 1469 | 456.4 | Terminal conformance specification, Radio transmission and reception (TDD) | milestone | 0d? | 1999-01-01 A | 1999-01-01 A | 100% | 1999-01-01 | 1999-01-01 | 0d? | start no earlier than 1999-01-01 | R5,T1 |  |  | R99 |  | 34.122 |
| 1470 | 456.5 | UE conformance specification; Part 1: Protocol conformance specification | milestone | 0d? | 1999-01-01 A | 1999-01-01 A | 100% | 1999-01-01 | 1999-01-01 | 0d? | start no earlier than 1999-01-01 | R5,T1 |  |  | R99 |  | 34.123-1 |
| 1471 | 456.6 | UE conformance specification; Part 2: Implementation Conformance Statement (ICS) specification | milestone | 0d? | 1999-01-01 A | 1999-01-01 A | 100% | 1999-01-01 | 1999-01-01 | 0d? | start no earlier than 1999-01-01 | R5,T1 |  |  | R99 |  | 34.123-2 |
| 1472 | 456.7 | UE conformance specification; Part 3: Abstract test suites (ATSs) | milestone | 0d? | 1999-01-01 A | 1999-01-01 A | 100% | 1999-01-01 | 1999-01-01 | 0d? | start no earlier than 1999-01-01 | R5,T1 |  |  | R99 |  | 34.123-3 |
| 1473 | 457 | Deleted - Dual Tone Multi-Frequency signalling : Support in the whole 3GPP system |  | 261d? | 1999-01-01 A | 1999-12-31 A | 100% | 1999-01-01 | 1999-12-31 | 261d? | start no earlier than 1999-01-01 | N1 | 2088h | 2088h | R99 |  | 23.014 CR#0004 |
| 1474 | 458 | Deleted - Intersystem_Change |  | 261d? | 1999-01-01 A | 1999-12-31 A | 100% | 1999-01-01 | 1999-12-31 | 261d? | start no earlier than 1999-01-01 | G3new | 2088h | 2088h | R99 |  | 04.18 CR#A243 |
| 1475 | 459 | Deleted - Long_Forwardedto_Numbers |  | 261d? | 1999-01-01 A | 1999-12-31 A | 100% | 1999-01-01 | 1999-12-31 | 261d? | start no earlier than 1999-01-01 | N2 | 2088h | 2088h | R99 |  | 29.002 |
| 1476 | 460 | Deleted - RANimp-FSEarlyUE |  | 261d? | 1999-01-01 A | 1999-12-31 A | 100% | 1999-01-01 | 1999-12-31 | 261d? | start no earlier than 1999-01-01 | R3 | 2088h | 2088h | R99 |  | 25.413 CR#0520, 0538, 0565, 0563, 0541, 0540, 0539, 0547 |
| 1477 | 461 | Combined GSM and Mobile IP mobility handling in UMTS IP CN |  | 261d? | 1999-01-01 A | 1999-12-31 A | 100% | 1999-01-01 | 1999-12-31 | 261d? | start no earlier than 1999-01-01 | S2 | 2088h | 2088h | R99 |  | 23.923 |
| 1478 | 462 | UE Capabilities Requirements |  | 261d? | 1999-01-01 A | 1999-12-31 A | 100% | 1999-01-01 | 1999-12-31 | 261d? | start no earlier than 1999-01-01 | T2 | 2088h | 2088h | R99 |  | 21.904 |
| 1479 | 463 | Electrical safety requirements and regulations |  | 261d? | 1999-01-01 A | 1999-12-31 A | 100% | 1999-01-01 | 1999-12-31 | 261d? | start no earlier than 1999-01-01 | T2 | 2088h | 2088h | R99 |  | 34.907 |
| 1480 | 464 | Specific Absorbtion Rate (SAR) requirements and regulations in different regions |  | 261d? | 1999-01-01 A | 1999-12-31 A | 100% | 1999-01-01 | 1999-12-31 | 261d? | start no earlier than 1999-01-01 | T2 | 2088h | 2088h | R99 |  | 34.925 |
| 1481 | 465 | Multi-mode UE issues |  | 261d? | 1999-01-01 A | 1999-12-31 A | 100% | 1999-01-01 | 1999-12-31 | 261d? | start no earlier than 1999-01-01 | T2 | 2088h | 2088h | R99 |  | 21.810, 21.910 |
| 1482 | 466 | Provision of fax service in GSM and UMTS |  | 261d? | 1999-01-01 A | 1999-12-31 A | 100% | 1999-01-01 | 1999-12-31 | 261d? | start no earlier than 1999-01-01 | T2 | 2088h | 2088h | R99 |  | 22.945 |
| 1483 | 467 | Separating Radio Resources and Mobility Management specific parts of the MS Classmark |  | 261d? | 1999-01-01 A | 1999-12-31 A | 100% | 1999-01-01 | 1999-12-31 | 261d? | start no earlier than 1999-01-01 | T2 | 2088h | 2088h | R99 |  | 23.814 |

Notes:
- 1443: -
- 1444: - / Text1: Multimedia_Codec, CSM, WI2MMC, Codec(s)_for_CS_MM_Tel._Serv, Codec(s)_for_MM_Tel_Service, Codec_for_Multimedia_Telephony
- 1445: - / Text1: QoS_for_Speech_&_MM_Codecs_/_AMR
- 1446: UMTS_AMR2 is default Codec Type in R99 dual_mode terminals / Text1: TFOAMR
- 1447: Combination of the AMR speech codec and the Noise Suppression function. TS 06.77 and TR 06.78 only apply to GSM. They apply to UMTS from Rel-4 onwards, when they were converted to TS 26.077 and TR 26.078. / Text1: AMRNS
- 1448: Transcoder handling in the CN at inter-system handover and relocation + Introduction of UMTS AMR / Text1: OoBT
- 1449: 24.008 CR#0572 in NP-020220 was approved under this WI / Text1: OoBTC
- 1450: Minor improvements to 24.007 and 24.008 to increase the number of simultaneous calls/sessions from the present 7: the TI value is increased (NP-99441). / Text1: CC_Related_items
- 1451: - / Text1: Multimedia
- 1452: Sub-System Number allocation for Radio Access Network Application Part, Radio Network Subsystem Application Part / Text1: SSN_allocation
- 1453: Access to an Intranet/ISP with DHCP end to end / Text1: ISPaccess
- 1454: Support for the IP-Multicast protocol / Text1: Point_to_Multipoint_Services
- 1455: Asynchronous Interface for real-time NT Fax + Introduction of Asynchronous interface for Real-time non-transparent FAX / Text1: Realtime_NT_FAX_in_UMTS
- 1456: - / Text1: GLR
- 1457: - / Text1: Prepaging
- 1458: Re-definition of channel quality measure used for AMR link adaptation for DARP MS
- 1459: - / Text1: HS
- 1460: - / Text1: Streamlining
- 1461: - / Text1: R99_Service_Clean_up
- 1462: - / Text1: TEI
- 1463: - / Text1: TEI_[CS_Data]
- 1464: - / Text1: TEI_[GPRS]
- 1465: Specifies Conformance Tests for a 3G UE to be recognised as 3GPP-standard compliant. A 3GPP-external body, GCF (Global Certification Forum), delivers certificates to prove that a UE has correctly passed tests and is then conform to the 3GPP standard. / Text1: TEI_Test
- 1466: No CR or new TS/TR approved under this WI / Text1: RTEI
- 1467: - / Text1: TEI_Test
- 1468: measurement procedures for the conformance test of the UE that contain transmitting characteristics, receiving characteristics and performance requirements in addition to requirements for support of RRM (Radio Resource Management) in FDD mode. / Text1: TEI_Test
- 1469: measurement procedures for the conformance test of the UE that contain transmitting characteristics, receiving characteristics and performance requirements in addition to requirements for support of RRM (Radio Resource Management) in TDD mode. / Text1: TEI_Test
- 1470: TS 34.123, composed of three parts, actually specifies the protocol conformance testing for the 3G UE. Part 1 describes the overall test structure. / Text1: TEI_Test
- 1471: Part 2 contains the applicability of each test case defined as the Implementation Conformance Statement (ICS) proforma, in compliance with the relevant requirements, and in accordance with the relevant guidance given in ISO/IEC 9646-7 and ETS 300 406. / Text1: TEI_Test
- 1472: Part 3 specifies the protocol conformance testing in TTCN for the 3G UE at the Uu interface. It defines the TTCN test specification and design considerations in Abstract Test Suites based on the test cases specified in prose in part 1. / Text1: TEI_Test
- 1473: No CR or new TS/TR approved under this WI / Text1: DTMF
- 1474: No CR or new TS/TR approved under this WI / Text1: Intersystem_Change
- 1475: - / Text1: Long_Forwardedto_Numbers
- 1476: No CR or new TS/TR approved under this WI / Text1: RANimp-FSEarlyUE
- 1477: -
- 1478: Moved to CT1 at TSG-T closure / Text1: UCR
- 1479: Moved to RAN4 at TSG-T closure. TR summarizes differences between international and national standards relevant to IEC60950 and refers to regulations for conformity assessment due to different regulatory environments in different countries / regions.
- 1480: Moved to RAN4 at TSG-T closure.
- 1481: Moved to CT1 at TSG-T closure. Consequences on roaming capabilities and service availability (e.g. handover) of multi-mode UEs while roaming in various regions with various network configurations. Case studies for each of the possible scenarios in specs
- 1482: CP#27: Moved to C1 on closure of T2; see TP-050062. CP#28: C1->C3
- 1483: CP#27: change of WG as a result of closure of CN and T.
